# PEP_Chiapas_v27'07'15

Schedule from MS Project, 2016-01-05 to 2018-05-28, status date 2016-02-01, costs in $.

## Calendars

- Estándar: Mon-Fri 09:00-13:00, 15:00-19:00; Sat-Sun off.

## Schedule

| ID | WBS | Task | Duration | Start | Finish | Predecessors | Total slack | Free slack | Cost | Text1 |
| --- | --- | --- | --- | --- | --- | --- | --- | --- | --- | --- |
| 1 | 1 | **1. Fortalecimiento de la oferta y de la demanda de servicios de salud para la mujer en edad fértil (preconcepción, embarazo, parto y puerperio) y el neonato** | 543d | 2016-02-01 | 2018-02-28 |  | 63d |  | 1,512,587 |  |
| 2 | 1.1 | **Planificación familiar** | 520d | 2016-02-02 | 2018-01-29 |  | 85d |  | 466,500 |  |
| 3 | 1.1.1 | **54.3% de mujeres en edad reproductiva que no desean quedar embarazadas que utilizan métodos de planificación familiar** | 520d | 2016-02-02 | 2018-01-29 |  | 85d |  | 466,500 |  |
| 4 | 1.1.1.1 | **P1. 60, 000 MER (30 municipios) cubiertas con métodos de Planificación familiar** | 520d | 2016-02-02 | 2018-01-29 |  | 85d |  | 266,500 |  |
| 5 | 1.1.1.1.1 | **Promoción de métodos de PF al total de mujeres y hombres en edad reproductiva en servicios de salud** | 504d | 2016-02-02 | 2018-01-05 |  | 101d |  | 4,000 | RRA |
| 6 | 1.1.1.1.1.1 | **Implementación de la captación de los hombres y mujeres en la "hoja de línea de vida" u hoja filtro** | 35d | 2016-02-02 | 2016-03-21 |  | 570d |  | 4,000 |  |
| 7 | 1.1.1.1.1.1.1 | Elaboración de la hoja filtro | 5d | 2016-02-02 | 2016-02-08 | 1369 | 570d | 0d |  |  |
| 8 | 1.1.1.1.1.1.2 | Acuerdo sobre homogenización del instrumentos a utilizar | 5d | 2016-02-09 | 2016-02-15 | 7 | 570d | 0d |  |  |
| 9 | 1.1.1.1.1.1.3 | Impresión y distribución de hojas a los servicios | 20d | 2016-02-16 | 2016-03-14 | 8 | 570d | 0d | 4,000 |  |
| 10 | 1.1.1.1.1.1.4 | Comunidado para su implementación rutinaria | 5d | 2016-03-15 | 2016-03-21 | 9 | 570d |  |  |  |
| 11 | 1.1.1.1.1.2 | Realización de la consejería cuando se identifica la necesidad | 200d | 2016-02-02 | 2016-11-07 | 1369 | 405d |  |  |  |
| 12 | 1.1.1.1.1.3 | Registro como usuario (a) en caso afirmativo con método de PF | 200d | 2016-02-02 | 2016-11-07 | 1369 | 405d |  |  |  |
| 13 | 1.1.1.1.1.4 | **Monitoreo de usuarias activas y plan de acción correctivo** | 444d | 2016-04-26 | 2018-01-05 |  | 101d |  |  |  |
| 14 | 1.1.1.1.1.4.1 | Informe trimestral del monitoreo de usuarias | 3d | 2016-04-26 | 2016-04-28 | 1369FS+60d | 101d | 0d |  |  |
| 15 | 1.1.1.1.1.4.2 | Informe trimestral del monitoreo de usuarias | 3d | 2016-07-22 | 2016-07-26 | 14FS+60d | 101d | 0d |  |  |
| 16 | 1.1.1.1.1.4.3 | Informe trimestral del monitoreo de usuarias | 3d | 2016-10-19 | 2016-10-21 | 15FS+60d | 101d | 0d |  |  |
| 17 | 1.1.1.1.1.4.4 | Informe trimestral del monitoreo de usuarias | 3d | 2017-01-16 | 2017-01-18 | 16FS+60d | 101d | 0d |  |  |
| 18 | 1.1.1.1.1.4.5 | Informe trimestral del monitoreo de usuarias | 3d | 2017-04-13 | 2017-04-17 | 17FS+60d | 101d | 0d |  |  |
| 19 | 1.1.1.1.1.4.6 | Informe trimestral del monitoreo de usuarias | 3d | 2017-07-11 | 2017-07-13 | 18FS+60d | 101d | 0d |  |  |
| 20 | 1.1.1.1.1.4.7 | Informe trimestral del monitoreo de usuarias | 3d | 2017-10-06 | 2017-10-10 | 19FS+60d | 101d | 0d |  |  |
| 21 | 1.1.1.1.1.4.8 | Informe trimestral del monitoreo de usuarias | 3d | 2018-01-03 | 2018-01-05 | 20FS+60d | 101d |  |  |  |
| 22 | 1.1.1.1.2 | **Implementación en comunidades de estrategia de distribución de métodos de acuerdo a lineamiento de PF** | 520d | 2016-02-02 | 2018-01-29 |  | 85d |  | 262,500 |  |
| 23 | 1.1.1.1.2.1 | **Coordinar con PROSPERA el enfatizar los temas de PF según la estrategia definida** | 220d | 2016-02-02 | 2016-12-05 |  | 385d |  |  |  |
| 24 | 1.1.1.1.2.1.1 | Acciones de coordinación para el año 2016 | 10d | 2016-02-02 | 2016-02-15 | 1369 | 385d | 0d |  |  |
| 25 | 1.1.1.1.2.1.2 | Acciones de coordinación para el año 2017 | 10d | 2016-11-22 | 2016-12-05 | 24FS+200d | 385d |  |  |  |
| 26 | 1.1.1.1.2.2 | Identificación de los voluntarios que harán distribución comunitaria | 40d | 2016-02-16 | 2016-04-11 | 24 | 475d | 0d |  |  |

| ID | WBS | Task | Duration | Start | Finish | Predecessors | Total slack | Free slack | Constraint | Cost |
| --- | --- | --- | --- | --- | --- | --- | --- | --- | --- | --- |
| 27 | 1.1.1.1.2.3 | **Insumos y equipos basicos para voluntarios (chalecos, bolsos y otros)** | 125d | 2016-02-02 | 2016-07-25 |  | 480d |  |  |  |
| 28 | 1.1.1.1.2.3.1 | Identificación de necesidades | 15d | 2016-02-02 | 2016-02-22 | 1369 | 480d | 0d |  |  |
| 29 | 1.1.1.1.2.3.2 | Especificaciones técnicas | 10d | 2016-02-23 | 2016-03-07 | 28 | 480d | 0d |  |  |
| 30 | 1.1.1.1.2.3.3 | Selección de proveedor | 40d | 2016-03-08 | 2016-05-02 | 29 | 480d | 0d |  |  |
| 31 | 1.1.1.1.2.3.4 | Recepción y distribución de los equipos | 60d | 2016-05-03 | 2016-07-25 | 30 | 480d |  |  |  |
| 32 | 1.1.1.1.2.4 | Capacitación de los voluntarios | 80d | 2016-04-12 | 2016-08-01 | 26 | 475d |  |  |  |
| 33 | 1.1.1.1.2.5 | **Implementación incentivos a voluntarios por tareas realizadas** | 437d | 2016-02-02 | 2017-10-04 |  | 168d |  |  | 262,500 |
| 34 | 1.1.1.1.2.5.1 | Diseño y socialización del mecanismo de incentivos | 5d | 2016-02-16 | 2016-02-22 | 24 | 550d | 0d |  |  |
| 35 | 1.1.1.1.2.5.2 | Preparación institucional para el incentivo | 40d | 2016-02-23 | 2016-04-18 | 34 | 550d |  |  |  |
| 36 | 1.1.1.1.2.5.3 | **Aplicación del mecanismo de incentivos** | 437d | 2016-02-02 | 2017-10-04 |  | 168d |  |  | 262,500 |
| 37 | 1.1.1.1.2.5.3.1 | **Aplicación del esquema de incentivos comunitrario en PF** | 437d | 2016-02-02 | 2017-10-04 |  | 168d |  |  | 262,500 |
| 38 | 1.1.1.1.2.5.3.1.1 | Aplicación del esquema de incentivos comunitrario en PF 1 | 3d | 2016-02-02 | 2016-02-04 |  | 602d |  | start no earlier than 2016-02-02 | 12,500 |
| 39 | 1.1.1.1.2.5.3.1.2 | Aplicación del esquema de incentivos comunitrario en PF 2 | 3d | 2016-03-02 | 2016-03-04 |  | 581d |  | start no earlier than 2016-03-02 | 12,500 |
| 40 | 1.1.1.1.2.5.3.1.3 | Aplicación del esquema de incentivos comunitrario en PF 3 | 3d | 2016-04-04 | 2016-04-06 |  | 558d |  | start no earlier than 2016-04-02 | 12,500 |
| 41 | 1.1.1.1.2.5.3.1.4 | Aplicación del esquema de incentivos comunitrario en PF 4 | 3d | 2016-05-02 | 2016-05-04 |  | 538d |  | start no earlier than 2016-05-02 | 12,500 |
| 42 | 1.1.1.1.2.5.3.1.5 | Aplicación del esquema de incentivos comunitrario en PF 5 | 3d | 2016-06-02 | 2016-06-06 |  | 515d |  | start no earlier than 2016-06-02 | 12,500 |
| 43 | 1.1.1.1.2.5.3.1.6 | Aplicación del esquema de incentivos comunitrario en PF 6 | 3d | 2016-07-04 | 2016-07-06 |  | 493d |  | start no earlier than 2016-07-02 | 12,500 |
| 44 | 1.1.1.1.2.5.3.1.7 | Aplicación del esquema de incentivos comunitrario en PF 7 | 3d | 2016-08-02 | 2016-08-04 |  | 472d |  | start no earlier than 2016-08-02 | 12,500 |
| 45 | 1.1.1.1.2.5.3.1.8 | Aplicación del esquema de incentivos comunitrario en PF 8 | 3d | 2016-09-02 | 2016-09-06 |  | 449d |  | start no earlier than 2016-09-02 | 12,500 |
| 46 | 1.1.1.1.2.5.3.1.9 | Aplicación del esquema de incentivos comunitrario en PF 9 | 3d | 2016-10-03 | 2016-10-05 |  | 428d |  | start no earlier than 2016-10-02 | 12,500 |
| 47 | 1.1.1.1.2.5.3.1.10 | Aplicación del esquema de incentivos comunitrario en PF 10 | 3d | 2016-11-02 | 2016-11-04 |  | 406d |  | start no earlier than 2016-11-02 | 12,500 |
| 48 | 1.1.1.1.2.5.3.1.11 | Aplicación del esquema de incentivos comunitrario en PF 11 | 3d | 2016-12-02 | 2016-12-06 |  | 384d |  | start no earlier than 2016-12-02 | 12,500 |
| 49 | 1.1.1.1.2.5.3.1.12 | Aplicación del esquema de incentivos comunitrario en PF 12 | 3d | 2017-01-02 | 2017-01-04 |  | 363d |  | start no earlier than 2017-01-02 | 12,500 |
| 50 | 1.1.1.1.2.5.3.1.13 | Aplicación del esquema de incentivos comunitrario en PF 13 | 3d | 2017-02-02 | 2017-02-06 |  | 340d |  | start no earlier than 2017-02-02 | 12,500 |
| 51 | 1.1.1.1.2.5.3.1.14 | Aplicación del esquema de incentivos comunitrario en PF 14 | 3d | 2017-03-02 | 2017-03-06 |  | 320d |  | start no earlier than 2017-03-02 | 12,500 |
| 52 | 1.1.1.1.2.5.3.1.15 | Aplicación del esquema de incentivos comunitrario en PF 15 | 3d | 2017-04-03 | 2017-04-05 |  | 298d |  | start no earlier than 2017-04-02 | 12,500 |
| 53 | 1.1.1.1.2.5.3.1.16 | Aplicación del esquema de incentivos comunitrario en PF 16 | 3d | 2017-05-02 | 2017-05-04 |  | 277d |  | start no earlier than 2017-05-02 | 12,500 |
| 54 | 1.1.1.1.2.5.3.1.17 | Aplicación del esquema de incentivos comunitrario en PF 17 | 3d | 2017-06-02 | 2017-06-06 |  | 254d |  | start no earlier than 2017-06-02 | 12,500 |
| 55 | 1.1.1.1.2.5.3.1.18 | Aplicación del esquema de incentivos comunitrario en PF 18 | 3d | 2017-07-03 | 2017-07-05 |  | 233d |  | start no earlier than 2017-07-02 | 12,500 |
| 56 | 1.1.1.1.2.5.3.1.19 | Aplicación del esquema de incentivos comunitrario en PF 19 | 3d | 2017-08-02 | 2017-08-04 |  | 211d |  | start no earlier than 2017-08-02 | 12,500 |
| 57 | 1.1.1.1.2.5.3.1.20 | Aplicación del esquema de incentivos comunitrario en PF 20 | 3d | 2017-09-04 | 2017-09-06 |  | 188d |  | start no earlier than 2017-09-02 | 12,500 |
| 58 | 1.1.1.1.2.5.3.1.21 | Aplicación del esquema de incentivos comunitrario en PF 21 | 3d | 2017-10-02 | 2017-10-04 |  | 168d |  | start no earlier than 2017-10-02 | 12,500 |

| ID | WBS | Task | Duration | Start | Finish | Predecessors | Total slack | Free slack |
| --- | --- | --- | --- | --- | --- | --- | --- | --- |
| 59 | 1.1.1.1.2.6 | **Monitoreo del funcionamiento de la estrategia comunitaria** | 460d | 2016-04-26 | 2018-01-29 |  | 85d |  |
| 60 | 1.1.1.1.2.6.1 | Informes de monitoreo de la estrategia comunitaria | 5d | 2016-04-26 | 2016-05-02 | 1369FS+60d | 85d | 0d |
| 61 | 1.1.1.1.2.6.2 | Informes de monitoreo de la estrategia comunitaria | 5d | 2016-07-26 | 2016-08-01 | 60FS+60d | 85d | 0d |
| 62 | 1.1.1.1.2.6.3 | Informes de monitoreo de la estrategia comunitaria | 5d | 2016-10-25 | 2016-10-31 | 61FS+60d | 85d | 0d |
| 63 | 1.1.1.1.2.6.4 | Informes de monitoreo de la estrategia comunitaria | 5d | 2017-01-24 | 2017-01-30 | 62FS+60d | 85d | 0d |
| 64 | 1.1.1.1.2.6.5 | Informes de monitoreo de la estrategia comunitaria | 5d | 2017-04-25 | 2017-05-01 | 63FS+60d | 85d | 0d |
| 65 | 1.1.1.1.2.6.6 | Informes de monitoreo de la estrategia comunitaria | 5d | 2017-07-25 | 2017-07-31 | 64FS+60d | 85d | 0d |
| 66 | 1.1.1.1.2.6.7 | Informes de monitoreo de la estrategia comunitaria | 5d | 2017-10-24 | 2017-10-30 | 65FS+60d | 85d | 0d |
| 67 | 1.1.1.1.2.6.8 | Informes de monitoreo de la estrategia comunitaria | 5d | 2018-01-23 | 2018-01-29 | 66FS+60d | 85d |  |
| 68 | 1.1.1.2 | **P2. 301 unidades médicas abastacidas permanentemente con métodos de PF** | 520d | 2016-02-02 | 2018-01-29 |  | 85d |  |
| 69 | 1.1.1.2.1 | **375 personal de salud capacitado en nuevos mecanismos y herramienta para la gestión logística de suministros de PF** | 80d | 2016-02-02 | 2016-05-23 |  | 525d |  |
| 70 | 1.1.1.2.1.1 | Programación de necesidades por unidades para 2015 | 20d | 2016-02-02 | 2016-02-29 | 1369 | 525d | 0d |
| 71 | 1.1.1.2.1.2 | 4 talleres en la Jurisdicción de San Cristobal | 60d | 2016-03-01 | 2016-05-23 | 70 | 525d |  |
| 72 | 1.1.1.2.1.3 | 2 talleres en la Jurisdicción de Ococingo | 60d | 2016-03-01 | 2016-05-23 | 70 | 525d |  |
| 73 | 1.1.1.2.1.4 | 2 talleres en la Jurisdicción de Palenque | 60d | 2016-03-01 | 2016-05-23 | 70 | 525d |  |
| 74 | 1.1.1.2.1.5 | 3 talleres en la Jurisdicción de Pichucalco | 60d | 2016-03-01 | 2016-05-23 | 70 | 525d |  |
| 75 | 1.1.1.2.2 | **Seguimiento a la adquisición de los métodos de PF** | 420d | 2016-02-02 | 2017-09-11 |  | 185d |  |
| 76 | 1.1.1.2.2.1 | **Estimacion de necesidades de métodos para 2016 y 2017** | 210d | 2016-02-02 | 2016-11-21 |  | 395d |  |
| 77 | 1.1.1.2.2.1.1 | Estimación necesidades ajustadas para el 2016 | 15d | 2016-02-02 | 2016-02-22 | 1369 | 395d | 0d |
| 78 | 1.1.1.2.2.1.2 | Estimación necesidades para el 2017 | 15d | 2016-11-01 | 2016-11-21 | 77FS+180d | 395d |  |
| 79 | 1.1.1.2.2.2 | **Seguimiento a la solicitud de métodos de PF a nivel Federal** | 360d | 2016-04-26 | 2017-09-11 |  | 185d |  |
| 80 | 1.1.1.2.2.2.1 | Seguimiento a la solicitud del 2016 | 120d | 2016-04-26 | 2016-10-10 | 1369FS+60d | 185d | 0d |
| 81 | 1.1.1.2.2.2.2 | Seguimiento a la solicitud del 2017 | 120d | 2017-03-28 | 2017-09-11 | 80FS+120d | 185d |  |
| 82 | 1.1.1.2.2.3 | **Adquisición de emergencia de métodos de planificación** | 110d | 2016-05-24 | 2016-10-24 |  | 415d |  |
| 83 | 1.1.1.2.2.3.1 | Acuerdo institucional sobre la necesidad de adquisición | 10d | 2016-05-24 | 2016-06-06 | 1369FS+80d | 415d | 0d |
| 84 | 1.1.1.2.2.3.2 | Especificaciones técnicas | 5d | 2016-06-07 | 2016-06-13 | 83 | 415d | 0d |
| 85 | 1.1.1.2.2.3.3 | Selección del proveedor | 40d | 2016-06-14 | 2016-08-08 | 84 | 415d | 0d |
| 86 | 1.1.1.2.2.3.4 | Recepción de los métodos de anticoncepcción | 40d | 2016-08-09 | 2016-10-03 | 85 | 415d | 0d |
| 87 | 1.1.1.2.2.3.5 | Distribución de los métodos | 15d | 2016-10-04 | 2016-10-24 | 86 | 415d |  |

| ID | WBS | Task | Duration | Start | Finish | Total slack | Constraint |
| --- | --- | --- | --- | --- | --- | --- | --- |
| 88 | 1.1.1.2.3 | **Distribución oportuna de los métodos a jurísdicciones y unidades de salud y reporte del consumo** | 517d | 2016-02-05 | 2018-01-29 | 85d |  |
| 89 | 1.1.1.2.3.1 | **Reuniones mensuales de zonales con unidades de salud** | 435d | 2016-02-05 | 2017-10-05 | 167d |  |
| 90 | 1.1.1.2.3.1.1 | **Reuniones zonales para temas de distribución comunitaria de PF** | 435d | 2016-02-05 | 2017-10-05 | 167d |  |
| 91 | 1.1.1.2.3.1.1.1 | Reuniones zonales para temas de distribución comunitaria de PF 1 | 1d | 2016-02-05 | 2016-02-05 | 601d | start no earlier than 2016-02-05 |
| 92 | 1.1.1.2.3.1.1.2 | Reuniones zonales para temas de distribución comunitaria de PF 2 | 1d | 2016-03-07 | 2016-03-07 | 580d | start no earlier than 2016-03-05 |
| 93 | 1.1.1.2.3.1.1.3 | Reuniones zonales para temas de distribución comunitaria de PF 3 | 1d | 2016-04-05 | 2016-04-05 | 559d | start no earlier than 2016-04-05 |
| 94 | 1.1.1.2.3.1.1.4 | Reuniones zonales para temas de distribución comunitaria de PF 4 | 1d | 2016-05-05 | 2016-05-05 | 537d | start no earlier than 2016-05-05 |
| 95 | 1.1.1.2.3.1.1.5 | Reuniones zonales para temas de distribución comunitaria de PF 5 | 1d | 2016-06-06 | 2016-06-06 | 515d | start no earlier than 2016-06-05 |
| 96 | 1.1.1.2.3.1.1.6 | Reuniones zonales para temas de distribución comunitaria de PF 6 | 1d | 2016-07-05 | 2016-07-05 | 494d | start no earlier than 2016-07-05 |
| 97 | 1.1.1.2.3.1.1.7 | Reuniones zonales para temas de distribución comunitaria de PF 7 | 1d | 2016-08-05 | 2016-08-05 | 471d | start no earlier than 2016-08-05 |
| 98 | 1.1.1.2.3.1.1.8 | Reuniones zonales para temas de distribución comunitaria de PF 8 | 1d | 2016-09-05 | 2016-09-05 | 450d | start no earlier than 2016-09-05 |
| 99 | 1.1.1.2.3.1.1.9 | Reuniones zonales para temas de distribución comunitaria de PF 9 | 1d | 2016-10-05 | 2016-10-05 | 428d | start no earlier than 2016-10-05 |
| 100 | 1.1.1.2.3.1.1.10 | Reuniones zonales para temas de distribución comunitaria de PF 10 | 1d | 2016-11-07 | 2016-11-07 | 405d | start no earlier than 2016-11-05 |
| 101 | 1.1.1.2.3.1.1.11 | Reuniones zonales para temas de distribución comunitaria de PF 11 | 1d | 2016-12-05 | 2016-12-05 | 385d | start no earlier than 2016-12-05 |
| 102 | 1.1.1.2.3.1.1.12 | Reuniones zonales para temas de distribución comunitaria de PF 12 | 1d | 2017-01-05 | 2017-01-05 | 362d | start no earlier than 2017-01-05 |
| 103 | 1.1.1.2.3.1.1.13 | Reuniones zonales para temas de distribución comunitaria de PF 13 | 1d | 2017-02-06 | 2017-02-06 | 340d | start no earlier than 2017-02-05 |
| 104 | 1.1.1.2.3.1.1.14 | Reuniones zonales para temas de distribución comunitaria de PF 14 | 1d | 2017-03-06 | 2017-03-06 | 320d | start no earlier than 2017-03-05 |
| 105 | 1.1.1.2.3.1.1.15 | Reuniones zonales para temas de distribución comunitaria de PF 15 | 1d | 2017-04-05 | 2017-04-05 | 298d | start no earlier than 2017-04-05 |
| 106 | 1.1.1.2.3.1.1.16 | Reuniones zonales para temas de distribución comunitaria de PF 16 | 1d | 2017-05-05 | 2017-05-05 | 276d | start no earlier than 2017-05-05 |
| 107 | 1.1.1.2.3.1.1.17 | Reuniones zonales para temas de distribución comunitaria de PF 17 | 1d | 2017-06-05 | 2017-06-05 | 255d | start no earlier than 2017-06-05 |
| 108 | 1.1.1.2.3.1.1.18 | Reuniones zonales para temas de distribución comunitaria de PF 18 | 1d | 2017-07-05 | 2017-07-05 | 233d | start no earlier than 2017-07-05 |
| 109 | 1.1.1.2.3.1.1.19 | Reuniones zonales para temas de distribución comunitaria de PF 19 | 1d | 2017-08-07 | 2017-08-07 | 210d | start no earlier than 2017-08-05 |
| 110 | 1.1.1.2.3.1.1.20 | Reuniones zonales para temas de distribución comunitaria de PF 20 | 1d | 2017-09-05 | 2017-09-05 | 189d | start no earlier than 2017-09-05 |
| 111 | 1.1.1.2.3.1.1.21 | Reuniones zonales para temas de distribución comunitaria de PF 21 | 1d | 2017-10-05 | 2017-10-05 | 167d | start no earlier than 2017-10-05 |

| ID | WBS | Task | Duration | Start | Finish | Predecessors | Total slack | Free slack | Constraint |
| --- | --- | --- | --- | --- | --- | --- | --- | --- | --- |
| 112 | 1.1.1.2.3.2 | **Reuniones mensuales de equipos zonales y jurisdiccionales** | 435d | 2016-02-05 | 2017-10-05 |  | 167d |  |  |
| 113 | 1.1.1.2.3.2.1 | **Reuniones zonales para temas de distribución comunitaria de PF** | 435d | 2016-02-05 | 2017-10-05 |  | 167d |  |  |
| 114 | 1.1.1.2.3.2.1.1 | Reuniones zonales para temas de distribución comunitaria de PF 1 | 1d | 2016-02-05 | 2016-02-05 |  | 601d |  | start no earlier than 2016-02-05 |
| 115 | 1.1.1.2.3.2.1.2 | Reuniones zonales para temas de distribución comunitaria de PF 2 | 1d | 2016-03-07 | 2016-03-07 |  | 580d |  | start no earlier than 2016-03-05 |
| 116 | 1.1.1.2.3.2.1.3 | Reuniones zonales para temas de distribución comunitaria de PF 3 | 1d | 2016-04-05 | 2016-04-05 |  | 559d |  | start no earlier than 2016-04-05 |
| 117 | 1.1.1.2.3.2.1.4 | Reuniones zonales para temas de distribución comunitaria de PF 4 | 1d | 2016-05-05 | 2016-05-05 |  | 537d |  | start no earlier than 2016-05-05 |
| 118 | 1.1.1.2.3.2.1.5 | Reuniones zonales para temas de distribución comunitaria de PF 5 | 1d | 2016-06-06 | 2016-06-06 |  | 515d |  | start no earlier than 2016-06-05 |
| 119 | 1.1.1.2.3.2.1.6 | Reuniones zonales para temas de distribución comunitaria de PF 6 | 1d | 2016-07-05 | 2016-07-05 |  | 494d |  | start no earlier than 2016-07-05 |
| 120 | 1.1.1.2.3.2.1.7 | Reuniones zonales para temas de distribución comunitaria de PF 7 | 1d | 2016-08-05 | 2016-08-05 |  | 471d |  | start no earlier than 2016-08-05 |
| 121 | 1.1.1.2.3.2.1.8 | Reuniones zonales para temas de distribución comunitaria de PF 8 | 1d | 2016-09-05 | 2016-09-05 |  | 450d |  | start no earlier than 2016-09-05 |
| 122 | 1.1.1.2.3.2.1.9 | Reuniones zonales para temas de distribución comunitaria de PF 9 | 1d | 2016-10-05 | 2016-10-05 |  | 428d |  | start no earlier than 2016-10-05 |
| 123 | 1.1.1.2.3.2.1.10 | Reuniones zonales para temas de distribución comunitaria de PF 10 | 1d | 2016-11-07 | 2016-11-07 |  | 405d |  | start no earlier than 2016-11-05 |
| 124 | 1.1.1.2.3.2.1.11 | Reuniones zonales para temas de distribución comunitaria de PF 11 | 1d | 2016-12-05 | 2016-12-05 |  | 385d |  | start no earlier than 2016-12-05 |
| 125 | 1.1.1.2.3.2.1.12 | Reuniones zonales para temas de distribución comunitaria de PF 12 | 1d | 2017-01-05 | 2017-01-05 |  | 362d |  | start no earlier than 2017-01-05 |
| 126 | 1.1.1.2.3.2.1.13 | Reuniones zonales para temas de distribución comunitaria de PF 13 | 1d | 2017-02-06 | 2017-02-06 |  | 340d |  | start no earlier than 2017-02-05 |
| 127 | 1.1.1.2.3.2.1.14 | Reuniones zonales para temas de distribución comunitaria de PF 14 | 1d | 2017-03-06 | 2017-03-06 |  | 320d |  | start no earlier than 2017-03-05 |
| 128 | 1.1.1.2.3.2.1.15 | Reuniones zonales para temas de distribución comunitaria de PF 15 | 1d | 2017-04-05 | 2017-04-05 |  | 298d |  | start no earlier than 2017-04-05 |
| 129 | 1.1.1.2.3.2.1.16 | Reuniones zonales para temas de distribución comunitaria de PF 16 | 1d | 2017-05-05 | 2017-05-05 |  | 276d |  | start no earlier than 2017-05-05 |
| 130 | 1.1.1.2.3.2.1.17 | Reuniones zonales para temas de distribución comunitaria de PF 17 | 1d | 2017-06-05 | 2017-06-05 |  | 255d |  | start no earlier than 2017-06-05 |
| 131 | 1.1.1.2.3.2.1.18 | Reuniones zonales para temas de distribución comunitaria de PF 18 | 1d | 2017-07-05 | 2017-07-05 |  | 233d |  | start no earlier than 2017-07-05 |
| 132 | 1.1.1.2.3.2.1.19 | Reuniones zonales para temas de distribución comunitaria de PF 19 | 1d | 2017-08-07 | 2017-08-07 |  | 210d |  | start no earlier than 2017-08-05 |
| 133 | 1.1.1.2.3.2.1.20 | Reuniones zonales para temas de distribución comunitaria de PF 20 | 1d | 2017-09-05 | 2017-09-05 |  | 189d |  | start no earlier than 2017-09-05 |
| 134 | 1.1.1.2.3.2.1.21 | Reuniones zonales para temas de distribución comunitaria de PF 21 | 1d | 2017-10-05 | 2017-10-05 |  | 167d |  | start no earlier than 2017-10-05 |
| 135 | 1.1.1.2.3.3 | **Monitoreo de la distribución y distribución de métodos de PF** | 460d | 2016-04-26 | 2018-01-29 |  | 85d |  |  |
| 136 | 1.1.1.2.3.3.1 | Sesiones trimestrales de monitoreo | 5d | 2016-04-26 | 2016-05-02 | 1369FS+60d | 85d | 0d |  |
| 137 | 1.1.1.2.3.3.2 | Sesiones trimestrales de monitoreo | 5d | 2016-07-26 | 2016-08-01 | 136FS+60d | 85d | 0d |  |
| 138 | 1.1.1.2.3.3.3 | Sesiones trimestrales de monitoreo | 5d | 2016-10-25 | 2016-10-31 | 137FS+60d | 85d | 0d |  |
| 139 | 1.1.1.2.3.3.4 | Sesiones trimestrales de monitoreo | 5d | 2017-01-24 | 2017-01-30 | 138FS+60d | 85d | 0d |  |
| 140 | 1.1.1.2.3.3.5 | Sesiones trimestrales de monitoreo | 5d | 2017-04-25 | 2017-05-01 | 139FS+60d | 85d | 0d |  |
| 141 | 1.1.1.2.3.3.6 | Sesiones trimestrales de monitoreo | 5d | 2017-07-25 | 2017-07-31 | 140FS+60d | 85d | 0d |  |
| 142 | 1.1.1.2.3.3.7 | Sesiones trimestrales de monitoreo | 5d | 2017-10-24 | 2017-10-30 | 141FS+60d | 85d | 0d |  |
| 143 | 1.1.1.2.3.3.8 | Sesiones trimestrales de monitoreo | 5d | 2018-01-23 | 2018-01-29 | 142FS+60d | 85d |  |  |

| ID | WBS | Task | Duration | Start | Finish | Predecessors | Total slack | Free slack | Cost |
| --- | --- | --- | --- | --- | --- | --- | --- | --- | --- |
| 144 | 1.1.1.3 | **P3: 1,300 médicos, enfermeras y COCS capacitados en la CONSEJERÍA de PF y estrategia de cambio de comportamiento** | 185d | 2016-02-02 | 2016-10-17 |  | 420d |  | 200,000 |
| 145 | 1.1.1.3.1 | **Selección de firma consultora** | 50d | 2016-02-02 | 2016-04-11 |  | 420d |  |  |
| 146 | 1.1.1.3.1.1 | Términos de referencia | 10d | 2016-02-02 | 2016-02-15 | 1369 | 420d | 0d |  |
| 147 | 1.1.1.3.1.2 | Proceso de adquisición de la firma consultora | 40d | 2016-02-16 | 2016-04-11 | 146 | 420d | 0d |  |
| 148 | 1.1.1.3.2 | **posicionamiento de la firma consultora** | 25d | 2016-04-12 | 2016-05-16 |  | 530d |  |  |
| 149 | 1.1.1.3.2.1 | Comunicación formal sobre el ptoceso formativo y de acompañamiento | 5d | 2016-04-12 | 2016-04-18 | 147 | 530d | 0d |  |
| 150 | 1.1.1.3.2.2 | Reuniones de trabajo en las juridiscciones de presentación y logítica | 20d | 2016-04-19 | 2016-05-16 | 149 | 530d |  |  |
| 151 | 1.1.1.3.3 | **Capacitación de Médicos, Enfermeras y COCS en las unidades de salud** | 185d | 2016-02-02 | 2016-10-17 |  | 420d |  | 200,000 |
| 152 | 1.1.1.3.3.1 | Establecimiento del cronograma de formación y los elementos logísticos | 5d | 2016-04-12 | 2016-04-18 | 147 | 420d | 0d |  |
| 153 | 1.1.1.3.3.2 | **Capacitación dinámica y participativa** | 145d | 2016-02-02 | 2016-08-22 |  | 460d |  | 200,000 |
| 154 | 1.1.1.3.3.2.1 | Terminos de referencia | 5d | 2016-02-02 | 2016-02-08 | 1369 | 460d | 0d |  |
| 155 | 1.1.1.3.3.2.2 | Selección de la Firma | 40d | 2016-02-09 | 2016-04-04 | 154 | 460d | 0d |  |
| 156 | 1.1.1.3.3.2.3 | Proceso formativo dinámico y participativo (médicos, enfermeras y COCS) Firma consultora | 100d | 2016-04-05 | 2016-08-22 | 155 | 460d |  | 200,000 |
| 157 | 1.1.1.3.3.3 | Seguimiento al proceso de capacitación | 130d | 2016-04-19 | 2016-10-17 | 152 | 420d |  |  |
| 158 | 1.1.1.4 | **P4: 2,000 puerperas adoptan un método de PF post evento obstétrico** | 495d | 2016-02-02 | 2017-12-25 |  | 110d |  |  |
| 159 | 1.1.1.4.1 | **100% de mujeres embarazada con consejería y referidas para anticoncepción** | 480d | 2016-02-02 | 2017-12-04 |  | 125d |  |  |
| 160 | 1.1.1.4.1.1 | Consejería en el control prenatal | 480d | 2016-02-02 | 2017-12-04 | 1369 | 125d |  |  |
| 161 | 1.1.1.4.1.2 | Mujer aceptante es referida | 480d | 2016-02-02 | 2017-12-04 | 1369 | 125d |  |  |
| 162 | 1.1.1.4.1.3 | Comunicación de referencia al hospital respectivo | 480d | 2016-02-02 | 2017-12-04 | 1369 | 125d |  |  |
| 163 | 1.1.1.4.2 | **Consejería en el puerperio inmediato y tardío sobre anticoncepción** | 480d | 2016-02-02 | 2017-12-04 |  | 125d |  |  |
| 164 | 1.1.1.4.2.1 | Información en la admisión | 480d | 2016-02-02 | 2017-12-04 | 1369 | 125d |  |  |
| 165 | 1.1.1.4.2.2 | Consejería en el puerperio sobre anticoncepción | 480d | 2016-02-02 | 2017-12-04 | 1369 | 125d |  |  |
| 166 | 1.1.1.4.3 | **Adquisición de insumos esenciales de anticoncepción quirúrgica** | 105d | 2016-02-02 | 2016-06-27 |  | 500d |  |  |
| 167 | 1.1.1.4.3.1 | Identificación de necesidades | 10d | 2016-02-02 | 2016-02-15 | 1369 | 500d | 0d |  |
| 168 | 1.1.1.4.3.2 | Especificaciones técnicas | 15d | 2016-02-16 | 2016-03-07 | 167 | 500d | 0d |  |
| 169 | 1.1.1.4.3.3 | selección del proveedor | 40d | 2016-03-08 | 2016-05-02 | 168 | 500d | 0d |  |
| 170 | 1.1.1.4.3.4 | recepción de los insumos | 40d | 2016-05-03 | 2016-06-27 | 169 | 500d |  |  |

| ID | WBS | Task | Type | Duration | Start | Finish | Predecessors | Total slack | Free slack | Constraint | Cost | Text1 |
| --- | --- | --- | --- | --- | --- | --- | --- | --- | --- | --- | --- | --- |
| 171 | 1.1.1.4.4 | **Realización del APEO en los hospitales** |  | 495d | 2016-02-02 | 2017-12-25 |  | 110d |  |  |  |  |
| 172 | 1.1.1.4.4.1 | Aplicado proceso de articulación con sala de operaciones (OTB) |  | 480d | 2016-02-02 | 2017-12-04 | 1369 | 125d |  |  |  |  |
| 173 | 1.1.1.4.4.2 | Entrega de los otros métodos |  | 480d | 2016-02-02 | 2017-12-04 | 1369 | 125d |  |  |  |  |
| 174 | 1.1.1.4.4.3 | **Monitoreo de las metas de APEO** |  | 395d | 2016-06-21 | 2017-12-25 |  | 110d |  |  |  |  |
| 175 | 1.1.1.4.4.3.1 | Monitoreo de la implementación de la estrategia |  | 5d | 2016-06-21 | 2016-06-27 | 1369FS+100d | 110d | 0d |  |  |  |
| 176 | 1.1.1.4.4.3.2 | Monitoreo del cumplimiento de metas de APEO |  | 5d | 2016-09-20 | 2016-09-26 | 175FS+60d | 110d | 0d |  |  |  |
| 177 | 1.1.1.4.4.3.3 | Monitoreo del cumplimiento de metas de APEO |  | 5d | 2016-12-20 | 2016-12-26 | 176FS+60d | 110d | 0d |  |  |  |
| 178 | 1.1.1.4.4.3.4 | Monitoreo del cumplimiento de metas de APEO |  | 5d | 2017-03-21 | 2017-03-27 | 177FS+60d | 110d | 0d |  |  |  |
| 179 | 1.1.1.4.4.3.5 | Monitoreo del cumplimiento de metas de APEO |  | 5d | 2017-06-20 | 2017-06-26 | 178FS+60d | 110d | 0d |  |  |  |
| 180 | 1.1.1.4.4.3.6 | Monitoreo del cumplimiento de metas de APEO |  | 5d | 2017-09-19 | 2017-09-25 | 179FS+60d | 110d | 0d |  |  |  |
| 181 | 1.1.1.4.4.3.7 | Monitoreo del cumplimiento de metas de APEO |  | 5d | 2017-12-19 | 2017-12-25 | 180FS+60d | 110d |  |  |  |  |
| 182 | 1.2 | **CONE** |  | 543d | 2016-02-01 | 2018-02-28 |  | 63d |  |  | 619,737 |  |
| 183 | 1.2.1 | Indicador: 11.8% de MER recibieron en su embarazo más recientes al menos 5 atenciones prenatales realizadas por Médicos enfermeras o COCS de acuerdo a las mejores prácticas. | milestone | 0d | 2018-01-31 | 2018-01-31 |  | 84d |  | start no earlier than 2018-01-31 |  |  |
| 184 | 1.2.2 | Indicador: 37,4 de MER cuyo parto más reciente fue realizado por personal calificado en servicios de salud (en 2 años) | milestone | 0d | 2018-01-31 | 2018-01-31 |  | 84d |  | start no earlier than 2018-01-31 |  |  |
| 185 | 1.2.3 | **Indicador: 33% de MER recibieron cuidados post parto por personal calificado antes de los 7 días después de su parto más reciente (2 años)** |  | 543d | 2016-02-01 | 2018-02-28 |  | 63d |  |  | 619,737 |  |
| 186 | 1.2.3.1 | **P1: 301 unidades de salud abastecidas con los materiales impresos requeridos para el funcionamiento de la estrategia de CONE** |  | 105d | 2016-02-02 | 2016-06-27 |  | 500d |  |  |  | JIV |
| 187 | 1.2.3.1.1 | **Impresos materiales para la estrategia CONE** |  | 105d | 2016-02-02 | 2016-06-27 |  | 500d |  |  |  |  |
| 188 | 1.2.3.1.1.1 | Definición de los materiales a imprimir |  | 20d | 2016-02-02 | 2016-02-29 | 1369 | 500d | 0d |  |  |  |
| 189 | 1.2.3.1.1.2 | Diseño gráfico de los materiales |  | 20d | 2016-03-01 | 2016-03-28 | 188 | 500d | 0d |  |  |  |
| 190 | 1.2.3.1.1.3 | Contratación de los talleres gráficos |  | 5d | 2016-03-29 | 2016-04-04 | 189 | 500d | 0d |  |  |  |
| 191 | 1.2.3.1.1.4 | Recepción de los materiales |  | 30d | 2016-04-05 | 2016-05-16 | 190 | 500d | 0d |  |  |  |
| 192 | 1.2.3.1.1.5 | Distribución de los materiales |  | 30d | 2016-05-17 | 2016-06-27 | 191 | 500d |  |  |  |  |
| 193 | 1.2.3.2 | **P2: 11,000 Mujeres embarazadas que recibieron 5 controles de calidad, parto institucional y cuidados post parto** |  | 543d | 2016-02-01 | 2018-02-28 |  | 63d |  |  | 226,137 | JIV |
| 194 | 1.2.3.2.1 | **Todas las unidades de salud con búsqueda activa de embarazadas** |  | 520d | 2016-02-02 | 2018-01-29 |  | 85d |  |  |  |  |
| 195 | 1.2.3.2.1.1 | **Censo de embarazadas actualizado permanentemente** |  | 460d | 2016-04-26 | 2018-01-29 |  | 85d |  |  |  |  |
| 196 | 1.2.3.2.1.1.1 | Análisis trimestral del censo de embarazadas según metas |  | 5d | 2016-04-26 | 2016-05-02 | 1369FS+60d | 85d | 0d |  |  |  |
| 197 | 1.2.3.2.1.1.2 | Análisis trimestral del censo de embarazadas según metas |  | 5d | 2016-07-26 | 2016-08-01 | 196FS+60d | 85d | 0d |  |  |  |
| 198 | 1.2.3.2.1.1.3 | Análisis trimestral del censo de embarazadas según metas |  | 5d | 2016-10-25 | 2016-10-31 | 197FS+60d | 85d | 0d |  |  |  |
| 199 | 1.2.3.2.1.1.4 | Análisis trimestral del censo de embarazadas según metas |  | 5d | 2017-01-24 | 2017-01-30 | 198FS+60d | 85d | 0d |  |  |  |
| 200 | 1.2.3.2.1.1.5 | Análisis trimestral del censo de embarazadas según metas |  | 5d | 2017-04-25 | 2017-05-01 | 199FS+60d | 85d | 0d |  |  |  |
| 201 | 1.2.3.2.1.1.6 | Análisis trimestral del censo de embarazadas según metas |  | 5d | 2017-07-25 | 2017-07-31 | 200FS+60d | 85d | 0d |  |  |  |
| 202 | 1.2.3.2.1.1.7 | Análisis trimestral del censo de embarazadas según metas |  | 5d | 2017-10-24 | 2017-10-30 | 201FS+60d | 85d | 0d |  |  |  |
| 203 | 1.2.3.2.1.1.8 | Análisis trimestral del censo de embarazadas según metas |  | 5d | 2018-01-23 | 2018-01-29 | 202FS+60d | 85d |  |  |  |  |

| ID | WBS | Task | Duration | Start | Finish | Predecessors | Total slack | Free slack | Constraint |
| --- | --- | --- | --- | --- | --- | --- | --- | --- | --- |
| 204 | 1.2.3.2.1.2 | **Plan comunitario de búsqueda de embarazadas a través Pasantes de enfermeria, auxiliares de salud, beneficiarias de PROSPERA, utilizando hoja filtro y formato de línea de vida** | 70d | 2016-02-02 | 2016-05-09 |  | 535d |  |  |
| 205 | 1.2.3.2.1.2.1 | Actualizaciòn de contenidos y elementos del plan comunitario | 20d | 2016-02-02 | 2016-02-29 | 1369 | 585d |  |  |
| 206 | 1.2.3.2.1.2.2 | Inventario del recurso comunitario disponible | 30d | 2016-02-02 | 2016-03-14 | 1369 | 535d | 0d |  |
| 207 | 1.2.3.2.1.2.3 | Comunicación con los recursos comunitarios para activarlos en este esfuerzo | 40d | 2016-03-15 | 2016-05-09 | 206 | 535d |  |  |
| 208 | 1.2.3.2.1.3 | **Reactivación en el uso de pruebas rápidas de embarazo para captación temprana** | 436d | 2016-02-05 | 2017-10-06 |  | 166d |  |  |
| 209 | 1.2.3.2.1.3.1 | Analisis de la situación del uso en cada unidad de salud | 20d | 2016-03-01 | 2016-03-28 | 1369FS+20d | 545d | 0d |  |
| 210 | 1.2.3.2.1.3.2 | Definición de acciones para reactivar su aplicación | 20d | 2016-03-29 | 2016-04-25 | 209 | 545d |  |  |
| 211 | 1.2.3.2.1.3.3 | **Compra de emergencia de pruebas rápidas de embarazo y pruebas rápidas de laboratorio** | 135d | 2016-07-19 | 2017-01-23 |  | 290d |  |  |
| 212 | 1.2.3.2.1.3.3.1 | identificación de necesidades | 10d | 2016-07-19 | 2016-08-01 | 1369FS+120d | 290d | 0d |  |
| 213 | 1.2.3.2.1.3.3.2 | especificaciones técnicas | 15d | 2016-08-02 | 2016-08-22 | 212 | 290d | 0d |  |
| 214 | 1.2.3.2.1.3.3.3 | selección de proveedor | 30d | 2016-08-23 | 2016-10-03 | 213 | 290d | 0d |  |
| 215 | 1.2.3.2.1.3.3.4 | recepción de las pruebas rápidas de embarazo | 40d | 2016-10-04 | 2016-11-28 | 214 | 290d | 0d |  |
| 216 | 1.2.3.2.1.3.3.5 | Recepción pruebas rápidas de laboratorio | 40d | 2016-11-29 | 2017-01-23 | 215 | 290d | 0d |  |
| 217 | 1.2.3.2.1.3.4 | **Monitoreo periódico del uso de pruebas rápidas** | 436d | 2016-02-05 | 2017-10-06 |  | 166d |  |  |
| 218 | 1.2.3.2.1.3.4.1 | Monitoreo periódico del uso de pruebas rápidas 1 | 2d | 2016-02-05 | 2016-02-08 |  | 600d |  | start no earlier than 2016-02-05 |
| 219 | 1.2.3.2.1.3.4.2 | Monitoreo periódico del uso de pruebas rápidas 2 | 2d | 2016-03-07 | 2016-03-08 |  | 579d |  | start no earlier than 2016-03-05 |
| 220 | 1.2.3.2.1.3.4.3 | Monitoreo periódico del uso de pruebas rápidas 3 | 2d | 2016-04-05 | 2016-04-06 |  | 558d |  | start no earlier than 2016-04-05 |
| 221 | 1.2.3.2.1.3.4.4 | Monitoreo periódico del uso de pruebas rápidas 4 | 2d | 2016-05-05 | 2016-05-06 |  | 536d |  | start no earlier than 2016-05-05 |
| 222 | 1.2.3.2.1.3.4.5 | Monitoreo periódico del uso de pruebas rápidas 5 | 2d | 2016-06-06 | 2016-06-07 |  | 514d |  | start no earlier than 2016-06-05 |
| 223 | 1.2.3.2.1.3.4.6 | Monitoreo periódico del uso de pruebas rápidas 6 | 2d | 2016-07-05 | 2016-07-06 |  | 493d |  | start no earlier than 2016-07-05 |
| 224 | 1.2.3.2.1.3.4.7 | Monitoreo periódico del uso de pruebas rápidas 7 | 2d | 2016-08-05 | 2016-08-08 |  | 470d |  | start no earlier than 2016-08-05 |
| 225 | 1.2.3.2.1.3.4.8 | Monitoreo periódico del uso de pruebas rápidas 8 | 2d | 2016-09-05 | 2016-09-06 |  | 449d |  | start no earlier than 2016-09-05 |
| 226 | 1.2.3.2.1.3.4.9 | Monitoreo periódico del uso de pruebas rápidas 9 | 2d | 2016-10-05 | 2016-10-06 |  | 427d |  | start no earlier than 2016-10-05 |
| 227 | 1.2.3.2.1.3.4.10 | Monitoreo periódico del uso de pruebas rápidas 10 | 2d | 2016-11-07 | 2016-11-08 |  | 404d |  | start no earlier than 2016-11-05 |
| 228 | 1.2.3.2.1.3.4.11 | Monitoreo periódico del uso de pruebas rápidas 11 | 2d | 2016-12-05 | 2016-12-06 |  | 384d |  | start no earlier than 2016-12-05 |
| 229 | 1.2.3.2.1.3.4.12 | Monitoreo periódico del uso de pruebas rápidas 12 | 2d | 2017-01-05 | 2017-01-06 |  | 361d |  | start no earlier than 2017-01-05 |
| 230 | 1.2.3.2.1.3.4.13 | Monitoreo periódico del uso de pruebas rápidas 13 | 2d | 2017-02-06 | 2017-02-07 |  | 339d |  | start no earlier than 2017-02-05 |
| 231 | 1.2.3.2.1.3.4.14 | Monitoreo periódico del uso de pruebas rápidas 14 | 2d | 2017-03-06 | 2017-03-07 |  | 319d |  | start no earlier than 2017-03-05 |
| 232 | 1.2.3.2.1.3.4.15 | Monitoreo periódico del uso de pruebas rápidas 15 | 2d | 2017-04-05 | 2017-04-06 |  | 297d |  | start no earlier than 2017-04-05 |
| 233 | 1.2.3.2.1.3.4.16 | Monitoreo periódico del uso de pruebas rápidas 16 | 2d | 2017-05-05 | 2017-05-08 |  | 275d |  | start no earlier than 2017-05-05 |
| 234 | 1.2.3.2.1.3.4.17 | Monitoreo periódico del uso de pruebas rápidas 17 | 2d | 2017-06-05 | 2017-06-06 |  | 254d |  | start no earlier than 2017-06-05 |
| 235 | 1.2.3.2.1.3.4.18 | Monitoreo periódico del uso de pruebas rápidas 18 | 2d | 2017-07-05 | 2017-07-06 |  | 232d |  | start no earlier than 2017-07-05 |
| 236 | 1.2.3.2.1.3.4.19 | Monitoreo periódico del uso de pruebas rápidas 19 | 2d | 2017-08-07 | 2017-08-08 |  | 209d |  | start no earlier than 2017-08-05 |
| 237 | 1.2.3.2.1.3.4.20 | Monitoreo periódico del uso de pruebas rápidas 20 | 2d | 2017-09-05 | 2017-09-06 |  | 188d |  | start no earlier than 2017-09-05 |
| 238 | 1.2.3.2.1.3.4.21 | Monitoreo periódico del uso de pruebas rápidas 21 | 2d | 2017-10-05 | 2017-10-06 |  | 166d |  | start no earlier than 2017-10-05 |

| ID | WBS | Task | Type | Duration | Start | Finish | Predecessors | Total slack | Free slack | Constraint |
| --- | --- | --- | --- | --- | --- | --- | --- | --- | --- | --- |
| 239 | 1.2.3.2.2 | **Implementación del plan de parto Individual y comunitario** |  | 370d | 2016-02-02 | 2017-07-03 |  | 235d |  |  |
| 240 | 1.2.3.2.2.1 | **Implementación del plan de parto Individual y comunitario** |  | 370d | 2016-02-02 | 2017-07-03 |  | 235d |  |  |
| 241 | 1.2.3.2.2.1.1 | Directriz de adopción del plan de parto individual y comunitario | milestone | 10d | 2016-02-02 | 2016-02-15 | 1369 | 235d | 0d |  |
| 242 | 1.2.3.2.2.1.2 | **Monitoreo de la efectividad del plan de parto** |  | 300d | 2016-05-10 | 2017-07-03 |  | 235d |  |  |
| 243 | 1.2.3.2.2.1.2.1 | Acción de monitoreo |  | 5d | 2016-05-10 | 2016-05-16 | 241FS+60d | 235d | 0d |  |
| 244 | 1.2.3.2.2.1.2.2 | Acción de monitoreo |  | 5d | 2016-11-01 | 2016-11-07 | 243FS+120d | 235d | 0d |  |
| 245 | 1.2.3.2.2.1.2.3 | Acción de monitoreo | milestone | 5d | 2017-04-25 | 2017-05-01 | 244FS+120d | 235d | 0d |  |
| 246 | 1.2.3.2.2.1.2.4 | Acción de monitoreo |  | 5d | 2017-06-27 | 2017-07-03 | 245FS+40d | 235d |  |  |
| 247 | 1.2.3.2.3 | **Parteras técnicas profesionales y enfermeras obstétricas para CONE básicos** |  | 543d | 2016-02-01 | 2018-02-28 |  | 63d |  |  |
| 248 | 1.2.3.2.3.1 | **contratación de las parteras y enfermeras obstétricas** |  | 80d | 2016-02-02 | 2016-05-23 | 1369 | 465d | 0d |  |
| 249 | 1.2.3.2.3.1.1 | Términos de referencia |  | 10d | 2016-02-02 | 2016-02-15 |  | 465d | 0d |  |
| 250 | 1.2.3.2.3.1.2 | Selección del personal |  | 30d | 2016-02-16 | 2016-03-28 | 249 | 465d | 0d |  |
| 251 | 1.2.3.2.3.1.3 | Reclutamiento |  | 30d | 2016-03-29 | 2016-05-09 | 250 | 465d | 0d |  |
| 252 | 1.2.3.2.3.1.4 | Firma de los contratos |  | 10d | 2016-05-10 | 2016-05-23 | 251 | 465d |  |  |
| 253 | 1.2.3.2.3.2 | **Servicios de las parteras profesionales (15) y enfermeras obstétricas (6)** |  | 543d | 2016-02-01 | 2018-02-28 |  | 63d |  |  |
| 254 | 1.2.3.2.3.2.1 | **Servicios de partera profesional** |  | 515d | 2016-02-01 | 2018-01-19 |  | 91d |  |  |
| 255 | 1.2.3.2.3.2.1.1 | Servicios de partera profesional 1 |  | 1mo | 2016-02-01 | 2016-02-26 |  | 586d |  | start no earlier than 2016-02-01 |
| 256 | 1.2.3.2.3.2.1.2 | Servicios de partera profesional 2 |  | 1mo | 2016-03-01 | 2016-03-28 |  | 565d |  | start no earlier than 2016-03-01 |
| 257 | 1.2.3.2.3.2.1.3 | Servicios de partera profesional 3 |  | 1mo | 2016-04-01 | 2016-04-28 |  | 542d |  | start no earlier than 2016-04-01 |
| 258 | 1.2.3.2.3.2.1.4 | Servicios de partera profesional 4 |  | 1mo | 2016-05-02 | 2016-05-27 |  | 521d |  | start no earlier than 2016-05-01 |
| 259 | 1.2.3.2.3.2.1.5 | Servicios de partera profesional 5 |  | 1mo | 2016-06-01 | 2016-06-28 |  | 499d |  | start no earlier than 2016-06-01 |
| 260 | 1.2.3.2.3.2.1.6 | Servicios de partera profesional 6 |  | 1mo | 2016-07-01 | 2016-07-28 |  | 477d |  | start no earlier than 2016-07-01 |
| 261 | 1.2.3.2.3.2.1.7 | Servicios de partera profesional 7 |  | 1mo | 2016-08-01 | 2016-08-26 |  | 456d |  | start no earlier than 2016-08-01 |
| 262 | 1.2.3.2.3.2.1.8 | Servicios de partera profesional 8 |  | 1mo | 2016-09-01 | 2016-09-28 |  | 433d |  | start no earlier than 2016-09-01 |
| 263 | 1.2.3.2.3.2.1.9 | Servicios de partera profesional 9 |  | 1mo | 2016-10-03 | 2016-10-28 |  | 411d |  | start no earlier than 2016-10-01 |
| 264 | 1.2.3.2.3.2.1.10 | Servicios de partera profesional 10 |  | 1mo | 2016-11-01 | 2016-11-28 |  | 390d |  | start no earlier than 2016-11-01 |
| 265 | 1.2.3.2.3.2.1.11 | Servicios de partera profesional 11 |  | 1mo | 2016-12-01 | 2016-12-28 |  | 368d |  | start no earlier than 2016-12-01 |
| 266 | 1.2.3.2.3.2.1.12 | Servicios de partera profesional 12 |  | 1mo | 2017-01-02 | 2017-01-27 |  | 346d |  | start no earlier than 2017-01-01 |
| 267 | 1.2.3.2.3.2.1.13 | Servicios de partera profesional 13 |  | 1mo | 2017-02-01 | 2017-02-28 |  | 324d |  | start no earlier than 2017-02-01 |
| 268 | 1.2.3.2.3.2.1.14 | Servicios de partera profesional 14 |  | 1mo | 2017-03-01 | 2017-03-28 |  | 304d |  | start no earlier than 2017-03-01 |
| 269 | 1.2.3.2.3.2.1.15 | Servicios de partera profesional 15 |  | 1mo | 2017-04-03 | 2017-04-28 |  | 281d |  | start no earlier than 2017-04-01 |
| 270 | 1.2.3.2.3.2.1.16 | Servicios de partera profesional 16 |  | 1mo | 2017-05-01 | 2017-05-26 |  | 261d |  | start no earlier than 2017-05-01 |
| 271 | 1.2.3.2.3.2.1.17 | Servicios de partera profesional 17 |  | 1mo | 2017-06-01 | 2017-06-28 |  | 238d |  | start no earlier than 2017-06-01 |
| 272 | 1.2.3.2.3.2.1.18 | Servicios de partera profesional 18 |  | 1mo | 2017-07-03 | 2017-07-28 |  | 216d |  | start no earlier than 2017-07-01 |
| 273 | 1.2.3.2.3.2.1.19 | Servicios de partera profesional 19 |  | 1mo | 2017-08-01 | 2017-08-28 |  | 195d |  | start no earlier than 2017-08-01 |
| 274 | 1.2.3.2.3.2.1.20 | Servicios de partera profesional 20 |  | 1mo | 2017-09-01 | 2017-09-28 |  | 172d |  | start no earlier than 2017-09-01 |
| 275 | 1.2.3.2.3.2.1.21 | Servicios de partera profesional 21 |  | 1mo | 2017-10-02 | 2017-10-27 |  | 91d | 0d | start no earlier than 2017-10-01 |
| 276 | 1.2.3.2.3.2.1.22 | Servicios de partera profesional 22 |  | 1mo | 2017-10-30 | 2017-11-24 | 275 | 91d | 0d |  |
| 277 | 1.2.3.2.3.2.1.23 | Servicios de partera profesional 23 |  | 1mo | 2017-11-27 | 2017-12-22 | 276 | 91d | 0d |  |
| 278 | 1.2.3.2.3.2.1.24 | Servicios de partera profesional 24 |  | 1mo | 2017-12-25 | 2018-01-19 | 277 | 91d |  |  |

| ID | WBS | Task | Duration | Start | Finish | Predecessors | Total slack | Free slack | Constraint | Text1 |
| --- | --- | --- | --- | --- | --- | --- | --- | --- | --- | --- |
| 279 | 1.2.3.2.3.2.2 | **Enfermeras osbtétricas y perinatales (6)** | 456d | 2016-06-01 | 2018-02-28 |  | 63d |  |  |  |
| 280 | 1.2.3.2.3.2.2.1 | enfermeras ostétricas 1 | 22d | 2016-06-01 | 2016-06-30 | 1369 | 63d | 0d | start no earlier than 2016-06-01 |  |
| 281 | 1.2.3.2.3.2.2.2 | enfermeras ostétricas 2 | 22d | 2016-07-01 | 2016-08-01 | 280 | 63d | 0d | start no earlier than 2016-02-01 |  |
| 282 | 1.2.3.2.3.2.2.3 | enfermeras ostétricas 3 | 22d | 2016-08-02 | 2016-08-31 | 281 | 63d | 0d | start no earlier than 2016-03-01 |  |
| 283 | 1.2.3.2.3.2.2.4 | enfermeras ostétricas 4 | 22d | 2016-09-01 | 2016-09-30 | 282 | 63d | 0d | start no earlier than 2016-04-01 |  |
| 284 | 1.2.3.2.3.2.2.5 | enfermeras ostétricas 5 | 22d | 2016-10-03 | 2016-11-01 | 283 | 63d | 0d | start no earlier than 2016-05-01 |  |
| 285 | 1.2.3.2.3.2.2.6 | enfermeras ostétricas 6 | 22d | 2016-11-02 | 2016-12-01 | 284 | 63d | 0d | start no earlier than 2016-06-01 |  |
| 286 | 1.2.3.2.3.2.2.7 | enfermeras ostétricas 7 | 22d | 2016-12-02 | 2017-01-02 | 285 | 63d | 0d | start no earlier than 2016-07-01 |  |
| 287 | 1.2.3.2.3.2.2.8 | enfermeras ostétricas 8 | 22d | 2017-01-03 | 2017-02-01 | 286 | 63d | 0d | start no earlier than 2016-08-01 |  |
| 288 | 1.2.3.2.3.2.2.9 | enfermeras ostétricas 9 | 21d | 2017-02-02 | 2017-03-02 | 287 | 63d | 0d | start no earlier than 2016-09-01 |  |
| 289 | 1.2.3.2.3.2.2.10 | enfermeras ostétricas 10 | 21d | 2017-03-03 | 2017-03-31 | 288 | 63d | 0d | start no earlier than 2016-10-01 |  |
| 290 | 1.2.3.2.3.2.2.11 | enfermeras ostétricas 11 | 22d | 2017-04-03 | 2017-05-02 | 289 | 63d | 0d | start no earlier than 2016-11-01 |  |
| 291 | 1.2.3.2.3.2.2.12 | enfermeras ostétricas 12 | 22d | 2017-05-03 | 2017-06-01 | 290 | 63d | 0d | start no earlier than 2016-12-01 |  |
| 292 | 1.2.3.2.3.2.2.13 | enfermeras ostétricas 13 | 21d | 2017-06-02 | 2017-06-30 | 291 | 63d | 0d | start no earlier than 2017-01-01 |  |
| 293 | 1.2.3.2.3.2.2.14 | enfermeras ostétricas 14 | 21d | 2017-07-03 | 2017-07-31 | 292 | 63d | 0d | start no earlier than 2017-02-01 |  |
| 294 | 1.2.3.2.3.2.2.15 | enfermeras ostétricas 15 | 22d | 2017-08-01 | 2017-08-30 | 293 | 63d | 0d | start no earlier than 2017-03-01 |  |
| 295 | 1.2.3.2.3.2.2.16 | enfermeras ostétricas 16 | 22d | 2017-08-31 | 2017-09-29 | 294 | 63d | 0d | start no earlier than 2017-04-01 |  |
| 296 | 1.2.3.2.3.2.2.17 | enfermeras ostétricas 17 | 22d | 2017-10-02 | 2017-10-31 | 295 | 63d | 0d | start no earlier than 2017-05-01 |  |
| 297 | 1.2.3.2.3.2.2.18 | enfermeras ostétricas 18 | 22d | 2017-11-01 | 2017-11-30 | 296 | 63d | 0d | start no earlier than 2017-06-01 |  |
| 298 | 1.2.3.2.3.2.2.19 | enfermeras ostétricas 19 | 22d | 2017-12-01 | 2018-01-01 | 297 | 63d | 0d | start no earlier than 2017-07-01 |  |
| 299 | 1.2.3.2.3.2.2.20 | enfermeras ostétricas 20 | 22d | 2018-01-02 | 2018-01-31 | 298 | 63d | 0d | start no earlier than 2017-08-01 |  |
| 300 | 1.2.3.2.3.2.2.21 | enfermeras ostétricas 21 | 1mo | 2018-02-01 | 2018-02-28 | 299 | 63d |  | start no earlier than 2017-09-01 |  |
| 301 | 1.2.3.2.3.3 | Comunicación a la comunidad la disponibilidad de la parteras (perifoneo) | 60d | 2016-05-24 | 2016-08-15 | 248 | 465d |  |  |  |
| 302 | 1.2.3.2.3.4 | **Seguimiento evaluativo del desempeño** | 460d | 2016-04-26 | 2018-01-29 |  | 85d |  |  | JIV |
| 303 | 1.2.3.2.3.4.1 | Informe trimestral de avance y evaluación | 5d | 2016-04-26 | 2016-05-02 | 1369FS+60d | 85d | 0d |  |  |
| 304 | 1.2.3.2.3.4.2 | Informe trimestral de avance y evaluación | 5d | 2016-07-26 | 2016-08-01 | 303FS+60d | 85d | 0d |  |  |
| 305 | 1.2.3.2.3.4.3 | Informe trimestral de avance y evaluación | 5d | 2016-10-25 | 2016-10-31 | 304FS+60d | 85d | 0d |  |  |
| 306 | 1.2.3.2.3.4.4 | Informe trimestral de avance y evaluación | 5d | 2017-01-24 | 2017-01-30 | 305FS+60d | 85d | 0d |  |  |
| 307 | 1.2.3.2.3.4.5 | Informe trimestral de avance y evaluación | 5d | 2017-04-25 | 2017-05-01 | 306FS+60d | 85d | 0d |  |  |
| 308 | 1.2.3.2.3.4.6 | Informe trimestral de avance y evaluación | 5d | 2017-07-25 | 2017-07-31 | 307FS+60d | 85d | 0d |  |  |
| 309 | 1.2.3.2.3.4.7 | Informe trimestral de avance y evaluación | 5d | 2017-10-24 | 2017-10-30 | 308FS+60d | 85d | 0d |  |  |
| 310 | 1.2.3.2.3.4.8 | Informe trimestral de avance y evaluación | 5d | 2018-01-23 | 2018-01-29 | 309FS+60d | 85d |  |  |  |

| ID | WBS | Task | Type | Duration | Start | Finish | Predecessors | Total slack | Free slack | Cost | Text1 |
| --- | --- | --- | --- | --- | --- | --- | --- | --- | --- | --- | --- |
| 311 | 1.2.3.2.3.5 | **Activación de un diálogo de política en torno a la contratación de parteras profesionales y enfermeras obstétricas** |  | 270d | 2017-01-03 | 2018-01-15 |  | 95d |  |  |  |
| 312 | 1.2.3.2.3.5.1 | Taller de análisis sobre el avance del mecanismo |  | 30d | 2017-01-03 | 2017-02-13 | 1369FS+240d | 95d | 0d |  |  |
| 313 | 1.2.3.2.3.5.2 | Diálogo de políticas sobre la permanencia del mecanismo de las parteras profesionales |  | 120d | 2017-08-01 | 2018-01-15 | 312FS+120d | 95d |  |  |  |
| 314 | 1.2.3.2.4 | **Piloto de recursos humanos para prestación servicios de salud** |  | 330d | 2016-02-02 | 2017-05-08 |  | 215d |  | 226,137 |  |
| 315 | 1.2.3.2.4.1 | **Implementado del modelo de RRHH** |  | 240d | 2016-02-02 | 2017-01-02 |  | 215d |  | 211,137 |  |
| 316 | 1.2.3.2.4.1.1 | Selección de las modalidades de prestación de serviicos priorizadas |  | 5d | 2016-02-02 | 2016-02-08 | 1369 | 580d | 0d |  |  |
| 317 | 1.2.3.2.4.1.2 | Contratación del personal según las modalidades acordadas |  | 20d | 2016-02-09 | 2016-03-07 | 316 | 580d |  |  |  |
| 318 | 1.2.3.2.4.1.3 | Definición de los mecanismos administrativos de operativización |  | 20d | 2016-02-09 | 2016-03-07 | 316 | 580d |  |  |  |
| 319 | 1.2.3.2.4.1.4 | Operativización de las modalidades seleccionadas |  | 240d | 2016-02-02 | 2017-01-02 | 1369 | 215d | 0d | 211,137 |  |
| 320 | 1.2.3.2.4.1.5 | Socialización |  | 120d | 2016-02-02 | 2016-07-18 | 1369 | 485d |  |  |  |
| 321 | 1.2.3.2.4.1.6 | Seguimiento a la implementacion del Piloto |  | 240d | 2016-02-02 | 2017-01-02 | 1369 | 365d |  |  |  |
| 322 | 1.2.3.2.4.2 | **Evaluación de resultados e impacto** |  | 90d | 2017-01-03 | 2017-05-08 |  | 215d |  | 15,000 |  |
| 323 | 1.2.3.2.4.2.1 | Definición del alcance de la evaluación |  | 5d | 2017-01-03 | 2017-01-09 | 319 | 215d | 0d |  |  |
| 324 | 1.2.3.2.4.2.2 | Terminos de referencia |  | 5d | 2017-01-10 | 2017-01-16 | 323 | 215d | 0d |  |  |
| 325 | 1.2.3.2.4.2.3 | Selección del consultor |  | 20d | 2017-01-17 | 2017-02-13 | 324 | 215d | 0d |  |  |
| 326 | 1.2.3.2.4.2.4 | Desarrollo de la consultoría |  | 60d | 2017-02-14 | 2017-05-08 | 325 | 215d | 0d | 15,000 |  |
| 327 | 1.2.3.2.5 | **Vacunacion a todas las embarazadas con Td, Tdpa e influenza** |  | 300d | 2016-02-02 | 2017-03-27 |  | 305d |  |  | JIV |
| 328 | 1.2.3.2.5.1 | Análisis de las causas del bajo nivel de vacunación de embarazadas en TD… |  | 60d | 2016-02-02 | 2016-04-25 | 1369 | 305d | 0d |  |  |
| 329 | 1.2.3.2.5.2 | Plan comunicacional para elevar los indices de vacunación en embarazadas |  | 40d | 2016-04-26 | 2016-06-20 | 328 | 305d | 0d |  |  |
| 330 | 1.2.3.2.5.3 | Implementación del plan comunicacional |  | 200d | 2016-06-21 | 2017-03-27 | 329 | 305d |  |  |  |
| 331 | 1.2.3.3 | **P3: Casas maternas habilitadas y funcionando** |  | 502d | 2016-02-02 | 2018-01-03 |  | 103d |  |  |  |
| 332 | 1.2.3.3.1 | **Sistematización y capacitación para operación de las casas maternas** |  | 110d | 2016-02-02 | 2016-07-04 |  | 205d |  |  |  |
| 333 | 1.2.3.3.1.1 | **Sistematización del modelo y selección de las comunidades donde operarán las posadas AME** |  | 100d | 2016-02-02 | 2016-06-20 |  | 205d |  |  |  |
| 334 | 1.2.3.3.1.1.1 | Sistematización de experiencias existentes |  | 30d | 2016-02-02 | 2016-03-14 | 1369 | 205d | 0d |  |  |
| 335 | 1.2.3.3.1.1.2 | Organización del modelo operativo y división de responsabilidades y roles (comunidad ISECH) | milestone | 20d | 2016-03-15 | 2016-04-11 | 334 | 205d | 0d |  |  |
| 336 | 1.2.3.3.1.1.3 | Análisis integral de la situación existente en las casa actuales |  | 30d | 2016-04-12 | 2016-05-23 | 335 | 205d | 0d |  |  |
| 337 | 1.2.3.3.1.1.4 | Plan de mejora de las casas existentes | milestone | 20d | 2016-05-24 | 2016-06-20 | 336 | 345d | 0d |  |  |
| 338 | 1.2.3.3.1.2 | Diseno del plan de capacitación y selección de los participantes |  | 40d | 2016-03-15 | 2016-05-09 | 334 | 215d | 0d |  |  |
| 339 | 1.2.3.3.1.3 | Desarrollo de la capacitación |  | 40d | 2016-05-10 | 2016-07-04 | 338 | 215d | 0d |  |  |

| ID | WBS | Task | Type | Duration | Start | Finish | Predecessors | Total slack | Free slack |
| --- | --- | --- | --- | --- | --- | --- | --- | --- | --- |
| 340 | 1.2.3.3.2 | **Negociación con la comunidad y funcionamiento de las casas maternas** |  | 280d | 2016-07-05 | 2017-07-31 |  | 215d |  |
| 341 | 1.2.3.3.2.1 | **Sensibilización a la comunidad y las autoridades comunitarias** |  | 60d | 2016-07-05 | 2016-09-26 |  | 215d |  |
| 342 | 1.2.3.3.2.1.1 | Participar en talleres comunitarios y otras actividades comunales |  | 20d | 2016-07-05 | 2016-08-01 | 339 | 215d | 0d |
| 343 | 1.2.3.3.2.1.2 | Diálogo con las autoridades municipales | milestone | 20d | 2016-08-02 | 2016-08-29 | 342 | 215d | 0d |
| 344 | 1.2.3.3.2.1.3 | Consulta comunitaria y acuerdos para el establecimiento y mejora de la posada AME |  | 20d | 2016-08-30 | 2016-09-26 | 343 | 215d | 0d |
| 345 | 1.2.3.3.2.2 | **Identificar el equipo gestor del proyecto de casas maternas** |  | 10d | 2016-09-27 | 2016-10-10 |  | 215d |  |
| 346 | 1.2.3.3.2.2.1 | Identificación del equipo gestor a nivel de la comunidad | milestone | 10d | 2016-09-27 | 2016-10-10 | 344 | 425d |  |
| 347 | 1.2.3.3.2.2.2 | Identificación del equipo gestor a nivel del Hospital |  | 10d | 2016-09-27 | 2016-10-10 | 344 | 215d | 0d |
| 348 | 1.2.3.3.2.3 | **Plan de trabajo del equipo gestor** |  | 210d | 2016-10-11 | 2017-07-31 |  | 215d |  |
| 349 | 1.2.3.3.2.3.1 | Diseno del plan de trabajo por casa materna | milestone | 10d | 2016-10-11 | 2016-10-24 | 347 | 215d | 0d |
| 350 | 1.2.3.3.2.3.2 | Ejecución de las acciones para instalación y operación de las posada AME |  | 200d | 2016-10-25 | 2017-07-31 | 349 | 215d |  |
| 351 | 1.2.3.3.3 | **Habilitación de las casas maternas** |  | 270d | 2016-06-21 | 2017-07-03 |  | 235d |  |
| 352 | 1.2.3.3.3.1 | **casas maternas en operación (3 casas)** |  | 160d | 2016-06-21 | 2017-01-30 |  | 345d |  |
| 353 | 1.2.3.3.3.1.1 | Adquisición de mobiliario complementarios |  | 30d | 2016-06-21 | 2016-08-01 | 337 | 475d |  |
| 354 | 1.2.3.3.3.1.2 | Capacitación al personal de la casa materna |  | 40d | 2016-06-21 | 2016-08-15 | 337 | 345d | 0d |
| 355 | 1.2.3.3.3.1.3 | **Implementación del plan de habilitación y mejora** |  | 120d | 2016-08-16 | 2017-01-30 |  | 345d |  |
| 356 | 1.2.3.3.3.1.3.1 | Apoyo en gastos operativos y despensas |  | 120d | 2016-08-16 | 2017-01-30 | 354 | 345d |  |
| 357 | 1.2.3.3.3.2 | **Casas maternas nuevas operando en el 2016 (5 posadas)** |  | 60d | 2016-09-27 | 2016-12-19 |  | 375d |  |
| 358 | 1.2.3.3.3.2.1 | Adquisición de mobiliario y equipo |  | 60d | 2016-09-27 | 2016-12-19 | 344 | 375d |  |
| 359 | 1.2.3.3.3.2.2 | Capacitación al personal de la casa materna |  | 60d | 2016-09-27 | 2016-12-19 | 344 | 375d |  |
| 360 | 1.2.3.3.3.3 | **Casas maternas nuevas operando en el 2017 (8 posadas)** |  | 120d | 2017-01-17 | 2017-07-03 |  | 235d |  |
| 361 | 1.2.3.3.3.3.1 | Adquisición de mobiliario y equipo |  | 60d | 2017-01-17 | 2017-04-10 | 1369FS+250d | 235d | 0d |
| 362 | 1.2.3.3.3.3.2 | Capacitación al personal de la casa materna |  | 60d | 2017-04-11 | 2017-07-03 | 361 | 235d |  |
| 363 | 1.2.3.3.4 | **Seguimiento y divulgación de resultados** |  | 462d | 2016-03-29 | 2018-01-03 |  | 103d |  |
| 364 | 1.2.3.3.4.1 | **Seguimiento de la operación** |  | 462d | 2016-03-29 | 2018-01-03 |  | 103d |  |
| 365 | 1.2.3.3.4.1.1 | Diseno de instrumentos y mecanismos de monitoreo | milestone | 20d | 2016-05-24 | 2016-06-20 | 336 | 505d |  |

| ID | WBS | Task | Type | Duration | Start | Finish | Predecessors | Total slack | Free slack | Constraint |
| --- | --- | --- | --- | --- | --- | --- | --- | --- | --- | --- |
| 366 | 1.2.3.3.4.1.2 | **Monitoreo del funcionamiento y vinculacion de casas maternas** |  | 462d | 2016-03-29 | 2018-01-03 |  | 103d |  |  |
| 367 | 1.2.3.3.4.1.2.1 | **Monitoreo de la Operación** |  | 462d | 2016-03-29 | 2018-01-03 |  | 103d |  |  |
| 368 | 1.2.3.3.4.1.2.1.1 | Monitoreo de la Operación 1 |  | 22d | 2016-03-29 | 2016-04-27 | 1369FS+40d | 103d | 0d | start no earlier than 2015-01-05 |
| 369 | 1.2.3.3.4.1.2.1.2 | Monitoreo de la Operación 2 |  | 22d | 2016-04-28 | 2016-05-27 | 368 | 103d | 0d | start no earlier than 2015-02-05 |
| 370 | 1.2.3.3.4.1.2.1.3 | Monitoreo de la Operación 3 |  | 22d | 2016-05-30 | 2016-06-28 | 369 | 103d | 0d | start no earlier than 2015-03-05 |
| 371 | 1.2.3.3.4.1.2.1.4 | Monitoreo de la Operación 4 |  | 22d | 2016-06-29 | 2016-07-28 | 370 | 103d | 0d | start no earlier than 2015-04-05 |
| 372 | 1.2.3.3.4.1.2.1.5 | Monitoreo de la Operación 5 |  | 22d | 2016-07-29 | 2016-08-29 | 371 | 103d | 0d | start no earlier than 2015-05-05 |
| 373 | 1.2.3.3.4.1.2.1.6 | Monitoreo de la Operación 6 | milestone | 22d | 2016-08-30 | 2016-09-28 | 372 | 103d | 0d | start no earlier than 2015-06-05 |
| 374 | 1.2.3.3.4.1.2.1.7 | Monitoreo de la Operación 7 |  | 22d | 2016-09-29 | 2016-10-28 | 373 | 103d | 0d | start no earlier than 2015-07-05 |
| 375 | 1.2.3.3.4.1.2.1.8 | Monitoreo de la Operación 8 |  | 22d | 2016-10-31 | 2016-11-29 | 374 | 103d | 0d | start no earlier than 2015-08-05 |
| 376 | 1.2.3.3.4.1.2.1.9 | Monitoreo de la Operación 9 |  | 22d | 2016-11-30 | 2016-12-29 | 375 | 103d | 0d | start no earlier than 2015-09-05 |
| 377 | 1.2.3.3.4.1.2.1.10 | Monitoreo de la Operación 10 |  | 22d | 2016-12-30 | 2017-01-30 | 376 | 103d | 0d | start no earlier than 2015-10-05 |
| 378 | 1.2.3.3.4.1.2.1.11 | Monitoreo de la Operación 11 |  | 22d | 2017-01-31 | 2017-03-01 | 377 | 103d | 0d | start no earlier than 2015-11-05 |
| 379 | 1.2.3.3.4.1.2.1.12 | Monitoreo de la Operación 12 | milestone | 22d | 2017-03-02 | 2017-03-31 | 378 | 103d | 0d | start no earlier than 2015-12-05 |
| 380 | 1.2.3.3.4.1.2.1.13 | Monitoreo de la Operación 13 |  | 22d | 2017-04-03 | 2017-05-02 | 379 | 103d | 0d | start no earlier than 2016-01-05 |
| 381 | 1.2.3.3.4.1.2.1.14 | Monitoreo de la Operación 14 |  | 22d | 2017-05-03 | 2017-06-01 | 380 | 103d | 0d | start no earlier than 2016-02-05 |
| 382 | 1.2.3.3.4.1.2.1.15 | Monitoreo de la Operación 15 |  | 22d | 2017-06-02 | 2017-07-03 | 381 | 103d | 0d | start no earlier than 2016-03-05 |
| 383 | 1.2.3.3.4.1.2.1.16 | Monitoreo de la Operación 16 |  | 22d | 2017-07-04 | 2017-08-02 | 382 | 103d | 0d |  |
| 384 | 1.2.3.3.4.1.2.1.17 | Monitoreo de la Operación 17 |  | 22d | 2017-08-03 | 2017-09-01 | 383 | 103d | 0d |  |
| 385 | 1.2.3.3.4.1.2.1.18 | Monitoreo de la Operación 18 |  | 22d | 2017-09-04 | 2017-10-03 | 384 | 103d | 0d |  |
| 386 | 1.2.3.3.4.1.2.1.19 | Monitoreo de la Operación 19 |  | 22d | 2017-10-04 | 2017-11-02 | 385 | 103d | 0d |  |
| 387 | 1.2.3.3.4.1.2.1.20 | Monitoreo de la Operación 20 |  | 22d | 2017-11-03 | 2017-12-04 | 386 | 103d | 0d |  |
| 388 | 1.2.3.3.4.1.2.1.21 | Monitoreo de la Operación 21 |  | 22d | 2017-12-05 | 2018-01-03 | 387 | 103d |  |  |
| 389 | 1.2.3.3.4.2 | **Divulgación y comunicación** |  | 280d | 2016-07-19 | 2017-08-14 |  | 205d |  |  |
| 390 | 1.2.3.3.4.2.1 | Elaboración plan de divulgación y comunicación | milestone | 40d | 2016-07-19 | 2016-09-12 | 336FS+40d | 205d | 0d |  |
| 391 | 1.2.3.3.4.2.2 | Acciones de comunicación |  | 240d | 2016-09-13 | 2017-08-14 | 390 | 205d |  |  |

| ID | WBS | Task | Duration | Start | Finish | Predecessors | Total slack | Free slack | Text1 |
| --- | --- | --- | --- | --- | --- | --- | --- | --- | --- |
| 392 | 1.2.3.4 | **P4: 3,300 mujeres embrazadas y neonatos de alto riesgo por año referidas efectiva al nivel de atención requerido para su adecuada atención** | 365d | 2016-02-02 | 2017-06-26 |  | 240d |  |  |
| 393 | 1.2.3.4.1 | **Impresión de la guía operativa de Referencia y hojas de referencia/contra-referencia** | 125d | 2017-01-03 | 2017-06-26 |  | 240d |  |  |
| 394 | 1.2.3.4.1.1 | Definición de los materiales a imprimir | 20d | 2017-01-03 | 2017-01-30 | 1369FS+240d | 240d | 0d |  |
| 395 | 1.2.3.4.1.2 | Diseño gráfico de los materiales | 20d | 2017-01-31 | 2017-02-27 | 394 | 240d | 0d |  |
| 396 | 1.2.3.4.1.3 | Selección de los talleres gráficos estatales | 5d | 2017-02-28 | 2017-03-06 | 395 | 240d | 0d |  |
| 397 | 1.2.3.4.1.4 | Recepción de los manuales y hojas de referencia | 40d | 2017-03-07 | 2017-05-01 | 396 | 240d | 0d |  |
| 398 | 1.2.3.4.1.5 | Distribución de los manuales | 40d | 2017-05-02 | 2017-06-26 | 397 | 240d |  |  |
| 399 | 1.2.3.4.1.6 | Capacitación al personal en uso adecuado de las guías en CONE´s y Hospitales | 60d | 2017-01-31 | 2017-04-24 | 394 | 285d |  |  |
| 400 | 1.2.3.4.2 | **Funcionamiento adecuado del mecanismo de traslado** | 320d | 2016-02-02 | 2017-04-24 |  | 285d |  |  |
| 401 | 1.2.3.4.2.1 | **Capacitación de choferes** | 320d | 2016-02-02 | 2017-04-24 |  | 285d |  |  |
| 402 | 1.2.3.4.2.1.1 | Capacitación a operador de ambulancias en 2016 | 40d | 2016-02-02 | 2016-03-28 | 1369 | 285d | 0d |  |
| 403 | 1.2.3.4.2.1.2 | Capacitación a operador de ambulancias en 2017 | 40d | 2017-02-28 | 2017-04-24 | 402FS+240d | 285d |  |  |
| 404 | 1.2.3.4.2.2 | **Compra de equipo para las ambulancias** | 120d | 2016-02-02 | 2016-07-18 |  | 485d |  |  |
| 405 | 1.2.3.4.2.2.1 | Especificaciones técnicas | 30d | 2016-02-02 | 2016-03-14 | 1369 | 485d | 0d |  |
| 406 | 1.2.3.4.2.2.2 | Selección del proveedor | 50d | 2016-03-15 | 2016-05-23 | 405 | 485d | 0d |  |
| 407 | 1.2.3.4.2.2.3 | Recepción y distribución de los equipos | 40d | 2016-05-24 | 2016-07-18 | 406 | 485d |  |  |
| 408 | 1.2.3.4.3 | **Unidad de gestión de usuarias en salud (UGuS)** | 265d | 2016-02-09 | 2017-02-13 |  | 335d |  | RAC |
| 409 | 1.2.3.4.3.1 | **Institucionalización de la Unidad de Gestión de Usuarios** | 50d | 2016-02-23 | 2016-05-02 |  | 470d |  |  |
| 410 | 1.2.3.4.3.1.1 | Validación del diseño conceptual | 10d | 2016-02-23 | 2016-03-07 | 1369FS+15d | 470d | 0d |  |
| 411 | 1.2.3.4.3.1.2 | Adopción a nivel de la Junta de Gobierno | 20d | 2016-03-08 | 2016-04-04 | 410 | 560d |  |  |
| 412 | 1.2.3.4.3.1.3 | Desarrollo de manuales y procedimientos operativos | 40d | 2016-03-08 | 2016-05-02 | 410 | 470d | 0d |  |
| 413 | 1.2.3.4.3.1.4 | Reubicación de personal del ISECH para la prestación de los servicios | 30d | 2016-03-08 | 2016-04-18 | 410 | 550d |  |  |
| 414 | 1.2.3.4.3.2 | **Fortalecimiento de la infraestructura de telecomunicación** | 240d | 2016-02-09 | 2017-01-09 |  | 360d |  |  |
| 415 | 1.2.3.4.3.2.1 | Validación del diagnóstico de la infraestructura de telecomunicaciones | 50d | 2016-02-09 | 2016-04-18 | 1049 | 440d | 0d |  |

| ID | WBS | Task | Type | Duration | Start | Finish | Predecessors | Total slack | Free slack | Cost |
| --- | --- | --- | --- | --- | --- | --- | --- | --- | --- | --- |
| 416 | 1.2.3.4.3.2.2 | **Adquisición e instalación de equipos de radiocomunicación** |  | 110d | 2016-04-19 | 2016-09-19 |  | 440d |  |  |
| 417 | 1.2.3.4.3.2.2.1 | Especificaciones técnicas |  | 10d | 2016-04-19 | 2016-05-02 | 415 | 440d | 0d |  |
| 418 | 1.2.3.4.3.2.2.2 | Selección de proveedores |  | 60d | 2016-05-03 | 2016-07-25 | 417 | 440d | 0d |  |
| 419 | 1.2.3.4.3.2.2.3 | Recepción e instalación de los equipos |  | 40d | 2016-07-26 | 2016-09-19 | 418 | 440d |  |  |
| 420 | 1.2.3.4.3.2.3 | **Adquisición e instalación de equipos informáticos para la gestión de usuarios** |  | 110d | 2016-04-19 | 2016-09-19 |  | 440d |  |  |
| 421 | 1.2.3.4.3.2.3.1 | Especificaciones técnicas |  | 10d | 2016-04-19 | 2016-05-02 | 415 | 440d | 0d |  |
| 422 | 1.2.3.4.3.2.3.2 | Selección de proveedores |  | 60d | 2016-05-03 | 2016-07-25 | 421 | 440d | 0d |  |
| 423 | 1.2.3.4.3.2.3.3 | Recepción e instalación de los equipos |  | 40d | 2016-07-26 | 2016-09-19 | 422 | 440d |  |  |
| 424 | 1.2.3.4.3.2.4 | **Reahabilitación del equipamiento de telecomunicaciones existente** |  | 190d | 2016-02-09 | 2016-10-31 |  | 410d |  |  |
| 425 | 1.2.3.4.3.2.4.1 | Identificación de necesidades de rehabilitamiento |  | 50d | 2016-02-09 | 2016-04-18 | 1049 | 410d | 0d |  |
| 426 | 1.2.3.4.3.2.4.2 | Selección del proveedor |  | 60d | 2016-04-19 | 2016-07-11 | 425 | 410d | 0d |  |
| 427 | 1.2.3.4.3.2.4.3 | Desarrollo de la rehabilitación |  | 80d | 2016-07-12 | 2016-10-31 | 426 | 410d |  |  |
| 428 | 1.2.3.4.3.2.5 | **Conectividad de la red** |  | 240d | 2016-02-09 | 2017-01-09 |  | 360d |  |  |
| 429 | 1.2.3.4.3.2.5.1 | Servicios de arrendamiento de señales para 2016 |  | 20d | 2016-02-09 | 2016-03-07 | 1049 | 360d | 0d |  |
| 430 | 1.2.3.4.3.2.5.2 | Servicios de arrendamiento de señales para 2017 |  | 20d | 2016-12-13 | 2017-01-09 | 429FS+200d | 360d |  |  |
| 431 | 1.2.3.4.3.3 | **Establecimiento físico de la Unidad** |  | 70d | 2016-05-03 | 2016-08-08 |  | 470d |  |  |
| 432 | 1.2.3.4.3.3.1 | Asignación del espacio físico |  | 20d | 2016-05-03 | 2016-05-30 | 412 | 520d |  |  |
| 433 | 1.2.3.4.3.3.2 | Especificaciones técnicas de equipos a adquirir |  | 15d | 2016-05-03 | 2016-05-23 | 412 | 470d | 0d |  |
| 434 | 1.2.3.4.3.3.3 | selección del proveedor |  | 40d | 2016-05-24 | 2016-07-18 | 433 | 470d | 0d |  |
| 435 | 1.2.3.4.3.3.4 | Recepción de los equipos |  | 15d | 2016-07-19 | 2016-08-08 | 434 | 470d |  |  |
| 436 | 1.2.3.4.3.4 | Capacitación al personal en el uso del SUGUS y en la referencia y contrareferencia |  | 80d | 2016-10-25 | 2017-02-13 | 1086 | 335d |  |  |
| 437 | 1.2.3.5 | **P5: 800 Parteras capacitadas en las nuevas currícula** |  | 180d | 2016-02-02 | 2016-10-10 |  | 425d |  | 25,000 |
| 438 | 1.2.3.5.1 | **Diseno del plan de capacitación de parteras** |  | 80d | 2016-02-02 | 2016-05-23 |  | 425d |  |  |
| 439 | 1.2.3.5.1.1 | **Desarrollo del nuevo manual de parteras** |  | 20d | 2016-02-02 | 2016-02-29 |  | 585d |  |  |
| 440 | 1.2.3.5.1.1.1 | recolección de materiales |  | 20d | 2016-02-02 | 2016-02-29 | 1369 | 585d |  |  |
| 441 | 1.2.3.5.1.1.2 | Iintercambios de experiencias sobre la temática (OPS) |  | 20d | 2016-02-02 | 2016-02-29 | 1369 | 585d |  |  |
| 442 | 1.2.3.5.1.1.3 | Sistematización de la propuesta de nueva curricula | milestone | 20d | 2016-02-02 | 2016-02-29 | 1369 | 585d |  |  |
| 443 | 1.2.3.5.1.2 | Elaboración manual del capacitador de parteras |  | 20d | 2016-02-02 | 2016-02-29 | 1369 | 585d |  |  |
| 444 | 1.2.3.5.1.3 | Elaboración del plan de capacitación de parteras | milestone | 30d | 2016-02-02 | 2016-03-14 | 1369 | 425d | 0d |  |

| ID | WBS | Task | Type | Duration | Start | Finish | Predecessors | Total slack | Free slack | Cost | Text1 |
| --- | --- | --- | --- | --- | --- | --- | --- | --- | --- | --- | --- |
| 445 | 1.2.3.5.1.4 | **Impresión de materiales de capacitación (facilitadores y parteras)** |  | 50d | 2016-03-15 | 2016-05-23 |  | 525d |  |  |  |
| 446 | 1.2.3.5.1.4.1 | Definición de los materiales |  | 5d | 2016-03-15 | 2016-03-21 | 444 | 525d | 0d |  |  |
| 447 | 1.2.3.5.1.4.2 | Diseno de los materiales |  | 10d | 2016-03-22 | 2016-04-04 | 446 | 525d | 0d |  |  |
| 448 | 1.2.3.5.1.4.3 | Selección de los talleres gráficos estatales |  | 10d | 2016-04-05 | 2016-04-18 | 447 | 525d | 0d |  |  |
| 449 | 1.2.3.5.1.4.4 | Recepción de los materiales | milestone | 25d | 2016-04-19 | 2016-05-23 | 448 | 525d |  |  |  |
| 450 | 1.2.3.5.2 | **Capacitación de las parteras** |  | 150d | 2016-03-15 | 2016-10-10 |  | 425d |  | 25,000 |  |
| 451 | 1.2.3.5.2.1 | Calendarización y organización de los talleres |  | 10d | 2016-03-15 | 2016-03-28 | 444 | 565d |  |  |  |
| 452 | 1.2.3.5.2.2 | Identificación de facilitadores |  | 10d | 2016-03-15 | 2016-03-28 | 444 | 425d | 0d |  |  |
| 453 | 1.2.3.5.2.3 | Formación de facilitadores en capacitación de parteras | milestone | 40d | 2016-03-29 | 2016-05-23 | 452 | 425d | 0d | 5,000 |  |
| 454 | 1.2.3.5.2.4 | Desarrollo del plan de capacitación a parteras | milestone | 100d | 2016-05-24 | 2016-10-10 | 453 | 425d |  | 20,000 |  |
| 455 | 1.2.3.6 | **P6: 301 Unidades de salud con pruebas rápidas para exámenes básicos de laboratorio** |  | 360d | 2016-02-02 | 2017-06-19 |  | 245d |  |  |  |
| 456 | 1.2.3.6.1 | **Identificadas las necesidades de pruebas rápidas** |  | 220d | 2016-02-02 | 2016-12-05 |  | 325d |  |  |  |
| 457 | 1.2.3.6.1.1 | Reuniones de identificación de necesidades 2016 |  | 10d | 2016-02-02 | 2016-02-15 | 1369 | 325d | 0d |  |  |
| 458 | 1.2.3.6.1.2 | Reunión identificación de necesidades 2017 |  | 10d | 2016-11-22 | 2016-12-05 | 457FS+200d | 385d |  |  |  |
| 459 | 1.2.3.6.2 | Distribuidas pruebas rápidas de laboratorio |  | 60d | 2017-01-24 | 2017-04-17 | 216 | 290d |  |  |  |
| 460 | 1.2.3.6.3 | **Mejora del sistema de distribución de las pruebas rápidas** |  | 360d | 2016-02-02 | 2017-06-19 |  | 245d |  |  |  |
| 461 | 1.2.3.6.3.1 | Elaboración cuadros de distribución 2016 |  | 15d | 2016-02-16 | 2016-03-07 | 457 | 325d | 0d |  |  |
| 462 | 1.2.3.6.3.2 | Elaboración cuadros de distribución 2017 |  | 15d | 2017-02-07 | 2017-02-27 | 461FS+240d | 325d |  |  |  |
| 463 | 1.2.3.6.3.3 | Distribución a las unidades de salud |  | 360d | 2016-02-02 | 2017-06-19 | 1369 | 245d |  |  |  |
| 464 | 1.2.3.6.3.4 | Monitoreo de la distribución |  | 360d | 2016-02-02 | 2017-06-19 | 1369 | 245d |  |  |  |
| 465 | 1.2.3.7 | **P7: 3,830 Mujeres embarazadas que reciben y cambian vales de transporte en Sitalá, Tumbalá, Chilón, Yajalón y Tila** |  | 522d | 2016-02-01 | 2018-01-30 |  | 84d |  | 368,600 | RRA |
| 466 | 1.2.3.7.1 | **Personal de salud capacidado** |  | 70d | 2016-02-02 | 2016-05-09 |  | 535d |  | 9,000 |  |
| 467 | 1.2.3.7.1.1 | Sensibilización al personal gerencial vinculado |  | 30d | 2016-02-02 | 2016-03-14 | 1369 | 535d | 0d |  |  |
| 468 | 1.2.3.7.1.2 | Capacitación al personal operativo que implementa el mecanismo de vales |  | 40d | 2016-03-15 | 2016-05-09 | 467 | 535d |  | 4,500 |  |
| 469 | 1.2.3.7.1.3 | Capacitación y sensibilización del personal de segundo nivel de atención |  | 40d | 2016-03-15 | 2016-05-09 | 467 | 535d |  | 4,500 |  |

| ID | WBS | Task | Duration | Start | Finish | Predecessors | Total slack | Free slack | Cost |
| --- | --- | --- | --- | --- | --- | --- | --- | --- | --- |
| 470 | 1.2.3.7.2 | **Plan de comunicación implementado** | 60d | 2016-02-02 | 2016-04-25 |  | 545d |  |  |
| 471 | 1.2.3.7.2.1 | Concertación con autoridades para el calendario de visitas | 40d | 2016-02-02 | 2016-03-28 | 1369 | 565d |  |  |
| 472 | 1.2.3.7.2.2 | Reproducción y distribución de materiales | 40d | 2016-02-02 | 2016-03-28 | 1369 | 545d | 0d |  |
| 473 | 1.2.3.7.2.3 | Traducción del video a Tsotsil y Tseltal | 20d | 2016-03-29 | 2016-04-25 | 472 | 545d |  |  |
| 474 | 1.2.3.7.3 | **Incentivo para el control post natal** | 520d | 2016-02-02 | 2018-01-29 |  | 85d |  | 122,400 |
| 475 | 1.2.3.7.3.1 | Definición del mecanismo administrativo | 5d | 2016-02-02 | 2016-02-08 | 1369 | 595d | 0d |  |
| 476 | 1.2.3.7.3.2 | Definición del contenido de las canastillas | 5d | 2016-02-09 | 2016-02-15 | 475 | 595d |  |  |
| 477 | 1.2.3.7.3.3 | **Adquisición de los insumos** | 70d | 2016-02-02 | 2016-05-09 |  | 535d |  |  |
| 478 | 1.2.3.7.3.3.1 | Especificaciones técnicas | 10d | 2016-02-02 | 2016-02-15 | 1369 | 535d | 0d |  |
| 479 | 1.2.3.7.3.3.2 | selección del proveedor | 20d | 2016-02-16 | 2016-03-14 | 478 | 535d | 0d |  |
| 480 | 1.2.3.7.3.3.3 | Recepción de los insumos | 40d | 2016-03-15 | 2016-05-09 | 479 | 535d |  |  |
| 481 | 1.2.3.7.3.4 | **Mecanismo de distribución** | 460d | 2016-04-26 | 2018-01-29 |  | 85d |  | 122,400 |
| 482 | 1.2.3.7.3.4.1 | Análisis de la distribución trimestral de canastillas | 5d | 2016-04-26 | 2016-05-02 | 1369FS+60d | 85d | 0d | 15,300 |
| 483 | 1.2.3.7.3.4.2 | Análisis de la distribución trimestral de canastillas | 5d | 2016-07-26 | 2016-08-01 | 482FS+60d | 85d | 0d | 15,300 |
| 484 | 1.2.3.7.3.4.3 | Análisis de la distribución trimestral de canastillas | 5d | 2016-10-25 | 2016-10-31 | 483FS+60d | 85d | 0d | 15,300 |
| 485 | 1.2.3.7.3.4.4 | Análisis de la distribución trimestral de canastillas | 5d | 2017-01-24 | 2017-01-30 | 484FS+60d | 85d | 0d | 15,300 |
| 486 | 1.2.3.7.3.4.5 | Análisis de la distribución trimestral de canastillas | 5d | 2017-04-25 | 2017-05-01 | 485FS+60d | 85d | 0d | 15,300 |
| 487 | 1.2.3.7.3.4.6 | Análisis de la distribución trimestral de canastillas | 5d | 2017-07-25 | 2017-07-31 | 486FS+60d | 85d | 0d | 15,300 |
| 488 | 1.2.3.7.3.4.7 | Análisis de la distribución trimestral de canastillas | 5d | 2017-10-24 | 2017-10-30 | 487FS+60d | 85d | 0d | 15,300 |
| 489 | 1.2.3.7.3.4.8 | Análisis de la distribución trimestral de canastillas | 5d | 2018-01-23 | 2018-01-29 | 488FS+60d | 85d |  | 15,300 |
| 490 | 1.2.3.7.4 | **Implementación del mecanismo de vales** | 500d | 2016-02-02 | 2018-01-01 |  | 105d |  | 206,000 |
| 491 | 1.2.3.7.4.1 | Impresión de los vales | 40d | 2016-02-02 | 2016-03-28 | 1369 | 565d |  |  |
| 492 | 1.2.3.7.4.2 | Entrega de censos nominales de embarazadas y puerperas | 40d | 2016-02-02 | 2016-03-28 | 1369 | 125d | 0d |  |
| 493 | 1.2.3.7.4.3 | Distribución y canje de los vales | 440d | 2016-03-29 | 2017-12-04 | 492 | 125d |  |  |

| ID | WBS | Task | Duration | Start | Finish | Predecessors | Total slack | Free slack | Constraint | Cost |
| --- | --- | --- | --- | --- | --- | --- | --- | --- | --- | --- |
| 494 | 1.2.3.7.4.4 | **Liquidación sistemática de los recursos financieros** | 500d | 2016-02-02 | 2018-01-01 |  | 105d |  |  | 206,000 |
| 495 | 1.2.3.7.4.4.1 | Solicitud de recursos financieros | 10d | 2016-02-02 | 2016-02-15 | 1369 | 105d | 0d |  | 25,750 |
| 496 | 1.2.3.7.4.4.2 | Liquidación de recursos y solicitud de nuevos recursos | 10d | 2016-05-10 | 2016-05-23 | 495FS+60d | 105d | 0d |  | 25,750 |
| 497 | 1.2.3.7.4.4.3 | Liquidación de recursos y solicitud de nuevos recursos | 10d | 2016-08-16 | 2016-08-29 | 496FS+60d | 105d | 0d |  | 25,750 |
| 498 | 1.2.3.7.4.4.4 | Liquidación de recursos y solicitud de nuevos recursos | 10d | 2016-11-22 | 2016-12-05 | 497FS+60d | 105d | 0d |  | 25,750 |
| 499 | 1.2.3.7.4.4.5 | Liquidación de recursos y solicitud de nuevos recursos | 10d | 2017-02-28 | 2017-03-13 | 498FS+60d | 105d | 0d |  | 25,750 |
| 500 | 1.2.3.7.4.4.6 | Liquidación de recursos y solicitud de nuevos recursos | 10d | 2017-06-06 | 2017-06-19 | 499FS+60d | 105d | 0d |  | 25,750 |
| 501 | 1.2.3.7.4.4.7 | Liquidación de recursos y solicitud de nuevos recursos | 10d | 2017-09-12 | 2017-09-25 | 500FS+60d | 105d | 0d |  | 25,750 |
| 502 | 1.2.3.7.4.4.8 | Liquidación final de recursos | 10d | 2017-12-19 | 2018-01-01 | 501FS+60d | 105d |  |  | 25,750 |
| 503 | 1.2.3.7.5 | **Supervisión y seguimiento** | 522d | 2016-02-01 | 2018-01-30 |  | 84d |  |  | 31,200 |
| 504 | 1.2.3.7.5.1 | Cronograma de visitas | 20d | 2016-02-02 | 2016-02-29 | 1369 | 585d |  |  |  |
| 505 | 1.2.3.7.5.2 | **visitas de supervision del mecanismo de vales** | 522d | 2016-02-01 | 2018-01-30 |  | 84d |  |  | 31,200 |
| 506 | 1.2.3.7.5.2.1 | visitas de supervision del mecanismo de vales 1 | 22d | 2016-02-01 | 2016-03-01 |  | 584d |  | start no earlier than 2016-02-01 | 1,300 |
| 507 | 1.2.3.7.5.2.2 | visitas de supervision del mecanismo de vales 2 | 22d | 2016-03-01 | 2016-03-30 |  | 563d |  | start no earlier than 2016-03-01 | 1,300 |
| 508 | 1.2.3.7.5.2.3 | visitas de supervision del mecanismo de vales 3 | 22d | 2016-04-01 | 2016-05-02 |  | 540d |  | start no earlier than 2016-04-01 | 1,300 |
| 509 | 1.2.3.7.5.2.4 | visitas de supervision del mecanismo de vales 4 | 22d | 2016-05-02 | 2016-05-31 |  | 519d |  | start no earlier than 2016-05-01 | 1,300 |
| 510 | 1.2.3.7.5.2.5 | visitas de supervision del mecanismo de vales 5 | 22d | 2016-06-01 | 2016-06-30 |  | 497d |  | start no earlier than 2016-06-01 | 1,300 |
| 511 | 1.2.3.7.5.2.6 | visitas de supervision del mecanismo de vales 6 | 22d | 2016-07-01 | 2016-08-01 |  | 475d |  | start no earlier than 2016-07-01 | 1,300 |
| 512 | 1.2.3.7.5.2.7 | visitas de supervision del mecanismo de vales 7 | 22d | 2016-08-01 | 2016-08-30 |  | 454d |  | start no earlier than 2016-08-01 | 1,300 |
| 513 | 1.2.3.7.5.2.8 | visitas de supervision del mecanismo de vales 8 | 22d | 2016-09-01 | 2016-09-30 |  | 431d |  | start no earlier than 2016-09-01 | 1,300 |
| 514 | 1.2.3.7.5.2.9 | visitas de supervision del mecanismo de vales 9 | 22d | 2016-10-03 | 2016-11-01 |  | 409d |  | start no earlier than 2016-10-01 | 1,300 |
| 515 | 1.2.3.7.5.2.10 | visitas de supervision del mecanismo de vales 10 | 22d | 2016-11-01 | 2016-11-30 |  | 388d |  | start no earlier than 2016-11-01 | 1,300 |
| 516 | 1.2.3.7.5.2.11 | visitas de supervision del mecanismo de vales 11 | 22d | 2016-12-01 | 2016-12-30 |  | 366d |  | start no earlier than 2016-12-01 | 1,300 |
| 517 | 1.2.3.7.5.2.12 | visitas de supervision del mecanismo de vales 12 | 22d | 2017-01-02 | 2017-01-31 |  | 344d |  | start no earlier than 2017-01-01 | 1,300 |
| 518 | 1.2.3.7.5.2.13 | visitas de supervision del mecanismo de vales 13 | 22d | 2017-02-01 | 2017-03-02 |  | 322d |  | start no earlier than 2017-02-01 | 1,300 |
| 519 | 1.2.3.7.5.2.14 | visitas de supervision del mecanismo de vales 14 | 22d | 2017-03-01 | 2017-03-30 |  | 302d |  | start no earlier than 2017-03-01 | 1,300 |
| 520 | 1.2.3.7.5.2.15 | visitas de supervision del mecanismo de vales 15 | 22d | 2017-04-03 | 2017-05-02 |  | 279d |  | start no earlier than 2017-04-01 | 1,300 |
| 521 | 1.2.3.7.5.2.16 | visitas de supervision del mecanismo de vales 16 | 22d | 2017-05-01 | 2017-05-30 |  | 259d |  | start no earlier than 2017-05-01 | 1,300 |
| 522 | 1.2.3.7.5.2.17 | visitas de supervision del mecanismo de vales 17 | 22d | 2017-06-01 | 2017-06-30 |  | 236d |  | start no earlier than 2017-06-01 | 1,300 |
| 523 | 1.2.3.7.5.2.18 | visitas de supervision del mecanismo de vales 18 | 22d | 2017-07-03 | 2017-08-01 |  | 214d |  | start no earlier than 2017-07-01 | 1,300 |
| 524 | 1.2.3.7.5.2.19 | visitas de supervision del mecanismo de vales 19 | 22d | 2017-08-01 | 2017-08-30 |  | 193d |  | start no earlier than 2017-08-01 | 1,300 |
| 525 | 1.2.3.7.5.2.20 | visitas de supervision del mecanismo de vales 20 | 22d | 2017-09-01 | 2017-10-02 |  | 170d |  | start no earlier than 2017-09-01 | 1,300 |
| 526 | 1.2.3.7.5.2.21 | visitas de supervision del mecanismo de vales 21 | 22d | 2017-10-02 | 2017-10-31 |  | 149d |  | start no earlier than 2017-10-01 | 1,300 |
| 527 | 1.2.3.7.5.2.22 | visitas de supervision del mecanismo de vales 22 | 22d | 2017-11-01 | 2017-11-30 |  | 127d |  | start no earlier than 2017-11-01 | 1,300 |
| 528 | 1.2.3.7.5.2.23 | visitas de supervision del mecanismo de vales 23 | 22d | 2017-12-01 | 2018-01-01 |  | 105d |  | start no earlier than 2017-12-01 | 1,300 |
| 529 | 1.2.3.7.5.2.24 | visitas de supervision del mecanismo de vales 24 | 22d | 2018-01-01 | 2018-01-30 |  | 84d |  | start no earlier than 2018-01-01 | 1,300 |

| ID | WBS | Task | Type | Duration | Start | Finish | Predecessors | Total slack | Free slack | Constraint | Cost | Text1 |
| --- | --- | --- | --- | --- | --- | --- | --- | --- | --- | --- | --- | --- |
| 530 | 1.2.3.7.5.3 | **Informes de supervisión** |  | 430d | 2016-05-10 | 2018-01-01 |  | 105d |  |  |  |  |
| 531 | 1.2.3.7.5.3.1 | Informe trimestral de supervisión mecanismo de vales |  | 10d | 2016-05-10 | 2016-05-23 | 1369FS+70d | 105d | 0d |  |  |  |
| 532 | 1.2.3.7.5.3.2 | Informe trimestral de supervisión mecanismo de vales |  | 10d | 2016-08-16 | 2016-08-29 | 531FS+60d | 105d | 0d |  |  |  |
| 533 | 1.2.3.7.5.3.3 | Informe trimestral de supervisión mecanismo de vales |  | 10d | 2016-11-22 | 2016-12-05 | 532FS+60d | 105d | 0d |  |  |  |
| 534 | 1.2.3.7.5.3.4 | Informe trimestral de supervisión mecanismo de vales |  | 10d | 2017-02-28 | 2017-03-13 | 533FS+60d | 105d | 0d |  |  |  |
| 535 | 1.2.3.7.5.3.5 | Informe trimestral de supervisión mecanismo de vales |  | 10d | 2017-06-06 | 2017-06-19 | 534FS+60d | 105d | 0d |  |  |  |
| 536 | 1.2.3.7.5.3.6 | Informe trimestral de supervisión mecanismo de vales |  | 10d | 2017-09-12 | 2017-09-25 | 535FS+60d | 105d | 0d |  |  |  |
| 537 | 1.2.3.7.5.3.7 | Informe trimestral de supervisión mecanismo de vales |  | 10d | 2017-12-19 | 2018-01-01 | 536FS+60d | 105d |  |  |  |  |
| 538 | 1.2.3.7.5.4 | Evaluación integral del mecanismos de vales |  | 40d | 2017-05-09 | 2017-07-03 | 534FS+40d | 155d | 0d |  |  |  |
| 539 | 1.3 | **HOSPITALES** |  | 522d | 2016-02-01 | 2018-01-31 |  | 84d |  |  | 426,350 |  |
| 540 | 1.3.1 | Indicador 4050: 30% de pacientes institucionales de post parto evaluadas e inscritas por lo menos cada 15 minutos la primera hora y cada 30 minutos la siguiente hora | milestone | 0d | 2018-01-31 | 2018-01-31 |  | 84d |  | start no earlier than 2018-01-31 |  |  |
| 541 | 1.3.2 | Indicador 4090: 92,3% de Partos con periodo activo del periodo de parto en su parto mas reciente | milestone | 0d | 2018-01-31 | 2018-01-31 |  | 84d |  | start no earlier than 2018-01-31 |  |  |
| 542 | 1.3.3 | Indicador 4070: 20% de Neonatos que presentaron una complicación manejada según la norma | milestone | 0d | 2018-01-31 | 2018-01-31 |  | 84d |  | start no earlier than 2018-01-31 |  |  |
| 543 | 1.3.4 | **Indicador 4080: 20,6% de mujeres con complicación obstétrica manejadas según la norma** |  | 481d | 2016-02-01 | 2017-12-04 |  | 125d |  |  | 426,350 |  |
| 544 | 1.3.4.1 | **P1: Implementada estrategia de Gestión clínica en 16 hospitales CONE Básico y Completos** |  | 481d | 2016-02-01 | 2017-12-04 |  | 125d |  |  | 120,000 | JIV |
| 545 | 1.3.4.1.1 | **Impresión de material divulgativo de la estrategia** |  | 110d | 2016-02-02 | 2016-07-04 |  | 495d |  |  |  |  |
| 546 | 1.3.4.1.1.1 | Identificación de los materiales a imprimir |  | 10d | 2016-02-02 | 2016-02-15 | 1369 | 495d | 0d |  |  |  |
| 547 | 1.3.4.1.1.2 | Diagramados materiales a imprimir |  | 10d | 2016-02-16 | 2016-02-29 | 546 | 495d | 0d |  |  |  |
| 548 | 1.3.4.1.1.3 | Contratación de los talleres gráficos del Estado |  | 20d | 2016-03-01 | 2016-03-28 | 547 | 495d | 0d |  |  |  |
| 549 | 1.3.4.1.1.4 | Recepción de los materiales |  | 30d | 2016-03-29 | 2016-05-09 | 548 | 495d | 0d |  |  |  |
| 550 | 1.3.4.1.1.5 | Distribución de los materiales de la estrategia |  | 40d | 2016-05-10 | 2016-07-04 | 549 | 495d |  |  |  |  |
| 551 | 1.3.4.1.2 | **Implementación de la estrategia de gestión clínica** |  | 481d | 2016-02-01 | 2017-12-04 |  | 125d |  |  | 120,000 |  |
| 552 | 1.3.4.1.2.1 | **Equipo del ISECH acompaña a la firma en la implementación local** |  | 481d | 2016-02-01 | 2017-12-04 |  | 125d |  |  | 120,000 |  |
| 553 | 1.3.4.1.2.1.1 | **Acompañamiento a la firma en la gestión clínica** |  | 240d | 2016-02-01 | 2016-12-30 |  | 366d |  |  |  |  |
| 554 | 1.3.4.1.2.1.1.1 | Acompañamiento a la firma en la gestión clínica 2 |  | 22d | 2016-02-01 | 2016-03-01 |  | 584d |  | start no earlier than 2016-02-01 |  |  |
| 555 | 1.3.4.1.2.1.1.2 | Acompañamiento a la firma en la gestión clínica 3 |  | 22d | 2016-03-01 | 2016-03-30 |  | 563d |  | start no earlier than 2016-03-01 |  |  |
| 556 | 1.3.4.1.2.1.1.3 | Acompañamiento a la firma en la gestión clínica 4 |  | 22d | 2016-04-01 | 2016-05-02 |  | 540d |  | start no earlier than 2016-04-01 |  |  |
| 557 | 1.3.4.1.2.1.1.4 | Acompañamiento a la firma en la gestión clínica 5 |  | 22d | 2016-05-02 | 2016-05-31 |  | 519d |  | start no earlier than 2016-05-01 |  |  |
| 558 | 1.3.4.1.2.1.1.5 | Acompañamiento a la firma en la gestión clínica 6 |  | 22d | 2016-06-01 | 2016-06-30 |  | 497d |  | start no earlier than 2016-06-01 |  |  |
| 559 | 1.3.4.1.2.1.1.6 | Acompañamiento a la firma en la gestión clínica 7 |  | 22d | 2016-07-01 | 2016-08-01 |  | 475d |  | start no earlier than 2016-07-01 |  |  |
| 560 | 1.3.4.1.2.1.1.7 | Acompañamiento a la firma en la gestión clínica 8 |  | 22d | 2016-08-01 | 2016-08-30 |  | 454d |  | start no earlier than 2016-08-01 |  |  |
| 561 | 1.3.4.1.2.1.1.8 | Acompañamiento a la firma en la gestión clínica 9 |  | 22d | 2016-09-01 | 2016-09-30 |  | 431d |  | start no earlier than 2016-09-01 |  |  |
| 562 | 1.3.4.1.2.1.1.9 | Acompañamiento a la firma en la gestión clínica 10 |  | 22d | 2016-10-03 | 2016-11-01 |  | 409d |  | start no earlier than 2016-10-01 |  |  |
| 563 | 1.3.4.1.2.1.1.10 | Acompañamiento a la firma en la gestión clínica 11 |  | 22d | 2016-11-01 | 2016-11-30 |  | 388d |  | start no earlier than 2016-11-01 |  |  |
| 564 | 1.3.4.1.2.1.1.11 | Acompañamiento a la firma en la gestión clínica 12 |  | 22d | 2016-12-01 | 2016-12-30 |  | 366d |  | start no earlier than 2016-12-01 |  |  |
| 565 | 1.3.4.1.2.1.2 | Acompañamiento de la firma internacional durante 2017 |  | 240d | 2017-01-03 | 2017-12-04 | 1369FS+240d | 125d |  |  | 120,000 |  |
| 566 | 1.3.4.1.2.1.3 | Taller de revisión de avance en la implementación y toma de decisión |  | 3d | 2016-03-29 | 2016-03-31 | 1369FS+40d | 373d | 0d |  |  |  |
| 567 | 1.3.4.1.2.1.4 | Taller de revisión de avance en la implementación y toma de decisión |  | 3d | 2016-06-24 | 2016-06-28 | 566FS+60d | 373d | 0d |  |  |  |
| 568 | 1.3.4.1.2.1.5 | Taller de revisión de avance en la implementación y toma de decisión |  | 3d | 2016-09-21 | 2016-09-23 | 567FS+60d | 373d | 0d |  |  |  |
| 569 | 1.3.4.1.2.1.6 | Taller de revisión de avance en la implementación y toma de decisión |  | 3d | 2016-12-19 | 2016-12-21 | 568FS+60d | 373d |  |  |  |  |

| ID | WBS | Task | Duration | Start | Finish | Predecessors | Total slack | Free slack | Constraint | Cost | Text1 |
| --- | --- | --- | --- | --- | --- | --- | --- | --- | --- | --- | --- |
| 570 | 1.3.4.1.2.2 | **Adecuaciones para adaptación a procesos clínicos, equipos e insumos de los hospitales** | 95d | 2016-02-02 | 2016-06-13 |  | 510d |  |  |  |  |
| 571 | 1.3.4.1.2.2.1 | **Adecuaciones para adaptación a los procesos clínicos en los hospitales** | 85d | 2016-02-02 | 2016-05-30 |  | 520d |  |  |  |  |
| 572 | 1.3.4.1.2.2.1.1 | espeficaciones técnicas | 15d | 2016-02-02 | 2016-02-22 | 1369 | 520d | 0d |  |  |  |
| 573 | 1.3.4.1.2.2.1.2 | Selección del proveedor | 30d | 2016-02-23 | 2016-04-04 | 572 | 520d | 0d |  |  |  |
| 574 | 1.3.4.1.2.2.1.3 | Recepción de los trabajos | 40d | 2016-04-05 | 2016-05-30 | 573 | 520d |  |  |  |  |
| 575 | 1.3.4.1.2.2.2 | **Adquisición de equipo de hospitales** | 95d | 2016-02-02 | 2016-06-13 |  | 510d |  |  |  |  |
| 576 | 1.3.4.1.2.2.2.1 | espeficaciones técnicas | 15d | 2016-02-02 | 2016-02-22 | 1369 | 510d | 0d |  |  |  |
| 577 | 1.3.4.1.2.2.2.2 | Selección del proveedor | 40d | 2016-02-23 | 2016-04-18 | 576 | 510d | 0d |  |  |  |
| 578 | 1.3.4.1.2.2.2.3 | Recepción de los trabajos | 40d | 2016-04-19 | 2016-06-13 | 577 | 510d |  |  |  |  |
| 579 | 1.3.4.1.3 | **Implementación del esquema de monitoreo** | 240d | 2016-02-05 | 2017-01-05 |  | 362d |  |  |  |  |
| 580 | 1.3.4.1.3.1 | **análisis de reportes sobre toma de decisiones** | 240d | 2016-02-05 | 2017-01-05 |  | 362d |  |  |  |  |
| 581 | 1.3.4.1.3.1.1 | análisis de reportes sobre toma de decisiones 1 | 1d | 2016-02-05 | 2016-02-05 |  | 601d |  | start no earlier than 2016-02-05 |  |  |
| 582 | 1.3.4.1.3.1.2 | análisis de reportes sobre toma de decisiones 2 | 1d | 2016-03-07 | 2016-03-07 |  | 580d |  | start no earlier than 2016-03-05 |  |  |
| 583 | 1.3.4.1.3.1.3 | análisis de reportes sobre toma de decisiones 3 | 1d | 2016-04-05 | 2016-04-05 |  | 559d |  | start no earlier than 2016-04-05 |  |  |
| 584 | 1.3.4.1.3.1.4 | análisis de reportes sobre toma de decisiones 4 | 1d | 2016-05-05 | 2016-05-05 |  | 537d |  | start no earlier than 2016-05-05 |  |  |
| 585 | 1.3.4.1.3.1.5 | análisis de reportes sobre toma de decisiones 5 | 1d | 2016-06-06 | 2016-06-06 |  | 515d |  | start no earlier than 2016-06-05 |  |  |
| 586 | 1.3.4.1.3.1.6 | análisis de reportes sobre toma de decisiones 6 | 1d | 2016-07-05 | 2016-07-05 |  | 494d |  | start no earlier than 2016-07-05 |  |  |
| 587 | 1.3.4.1.3.1.7 | análisis de reportes sobre toma de decisiones 7 | 1d | 2016-08-05 | 2016-08-05 |  | 471d |  | start no earlier than 2016-08-05 |  |  |
| 588 | 1.3.4.1.3.1.8 | análisis de reportes sobre toma de decisiones 8 | 1d | 2016-09-05 | 2016-09-05 |  | 450d |  | start no earlier than 2016-09-05 |  |  |
| 589 | 1.3.4.1.3.1.9 | análisis de reportes sobre toma de decisiones 9 | 1d | 2016-10-05 | 2016-10-05 |  | 428d |  | start no earlier than 2016-10-05 |  |  |
| 590 | 1.3.4.1.3.1.10 | análisis de reportes sobre toma de decisiones 10 | 1d | 2016-11-07 | 2016-11-07 |  | 405d |  | start no earlier than 2016-11-05 |  |  |
| 591 | 1.3.4.1.3.1.11 | análisis de reportes sobre toma de decisiones 11 | 1d | 2016-12-05 | 2016-12-05 |  | 385d |  | start no earlier than 2016-12-05 |  |  |
| 592 | 1.3.4.1.3.1.12 | análisis de reportes sobre toma de decisiones 12 | 1d | 2017-01-05 | 2017-01-05 |  | 362d |  | start no earlier than 2017-01-05 |  |  |
| 593 | 1.3.4.2 | **P2: Formación en la estrategia y en temas clínicos especializados a nivel de 600 profesionales** | 230d | 2016-02-02 | 2016-12-19 |  | 375d |  |  | 283,250 | BLM |
| 594 | 1.3.4.2.1 | **Planificación del programa formativo** | 30d | 2016-02-02 | 2016-03-14 |  | 375d |  |  |  |  |
| 595 | 1.3.4.2.1.1 | Definición de los temas y el alcance de la capacitación | 10d | 2016-02-02 | 2016-02-15 | 1369 | 375d | 0d |  |  |  |
| 596 | 1.3.4.2.1.2 | Planificación del proceso de formación | 20d | 2016-02-16 | 2016-03-14 | 595 | 375d | 0d |  |  |  |

| ID | WBS | Task | Duration | Start | Finish | Predecessors | Total slack | Free slack | Constraint | Cost |
| --- | --- | --- | --- | --- | --- | --- | --- | --- | --- | --- |
| 597 | 1.3.4.2.2 | **Capacitación en emergencia obstétrica y reanimación neonatal** | 160d | 2016-03-15 | 2016-10-24 |  | 375d |  |  | 243,250 |
| 598 | 1.3.4.2.2.1 | Curso en reanimación neonatal | 40d | 2016-03-15 | 2016-05-09 | 596 | 375d | 0d |  | 23,250 |
| 599 | 1.3.4.2.2.2 | Habilidades y destrezas en emergencia obstétrica (HYDEON) Para enfermeras y médicos | 40d | 2016-05-10 | 2016-07-04 | 598 | 375d | 0d |  | 150,000 |
| 600 | 1.3.4.2.2.3 | APEO y vaseptomía | 40d | 2016-07-05 | 2016-08-29 | 599 | 375d | 0d |  | 40,000 |
| 601 | 1.3.4.2.2.4 | Formación en calibrado y mantenimiento de equipos de diagnóstico especializado | 40d | 2016-08-30 | 2016-10-24 | 600 | 375d | 0d |  | 30,000 |
| 602 | 1.3.4.2.3 | Adquisición de manuales especializados en reanimación neonatal | 40d | 2016-10-25 | 2016-12-19 | 601 | 375d |  |  | 40,000 |
| 603 | 1.3.4.3 | **P3: Seguimiento y análisis del 100% de las muertes maternas y perinatales** | 459d | 2016-02-02 | 2017-11-03 |  | 146d |  |  | 23,100 |
| 604 | 1.3.4.3.1 | **Contratación de enfermera (o) de apoyo al proceso** | 459d | 2016-02-02 | 2017-11-03 |  | 146d |  |  | 23,100 |
| 605 | 1.3.4.3.1.1 | Selección de personal | 10d | 2016-02-02 | 2016-02-15 | 1369 | 595d |  |  |  |
| 606 | 1.3.4.3.1.2 | **Desarrollo de los servicios de seguimiento y vigilancia** | 455d | 2016-02-08 | 2017-11-03 |  | 146d |  |  | 23,100 |
| 607 | 1.3.4.3.1.2.1 | **Acompañamiento técnico al análisis de la muerte perinatal** | 455d | 2016-02-08 | 2017-11-03 |  | 146d |  |  | 23,100 |
| 608 | 1.3.4.3.1.2.1.1 | Acompañamiento técnico al análisis de la muerte perinatal 1 | 1mo | 2016-02-08 | 2016-03-04 |  | 581d |  | start no earlier than 2016-02-08 | 1,100 |
| 609 | 1.3.4.3.1.2.1.2 | Acompañamiento técnico al análisis de la muerte perinatal 2 | 1mo | 2016-03-08 | 2016-04-04 |  | 560d |  | start no earlier than 2016-03-08 | 1,100 |
| 610 | 1.3.4.3.1.2.1.3 | Acompañamiento técnico al análisis de la muerte perinatal 3 | 1mo | 2016-04-08 | 2016-05-05 |  | 537d |  | start no earlier than 2016-04-08 | 1,100 |
| 611 | 1.3.4.3.1.2.1.4 | Acompañamiento técnico al análisis de la muerte perinatal 4 | 1mo | 2016-05-09 | 2016-06-03 |  | 516d |  | start no earlier than 2016-05-08 | 1,100 |
| 612 | 1.3.4.3.1.2.1.5 | Acompañamiento técnico al análisis de la muerte perinatal 5 | 1mo | 2016-06-08 | 2016-07-05 |  | 494d |  | start no earlier than 2016-06-08 | 1,100 |
| 613 | 1.3.4.3.1.2.1.6 | Acompañamiento técnico al análisis de la muerte perinatal 6 | 1mo | 2016-07-08 | 2016-08-04 |  | 472d |  | start no earlier than 2016-07-08 | 1,100 |
| 614 | 1.3.4.3.1.2.1.7 | Acompañamiento técnico al análisis de la muerte perinatal 7 | 1mo | 2016-08-08 | 2016-09-02 |  | 451d |  | start no earlier than 2016-08-08 | 1,100 |
| 615 | 1.3.4.3.1.2.1.8 | Acompañamiento técnico al análisis de la muerte perinatal 8 | 1mo | 2016-09-08 | 2016-10-05 |  | 428d |  | start no earlier than 2016-09-08 | 1,100 |
| 616 | 1.3.4.3.1.2.1.9 | Acompañamiento técnico al análisis de la muerte perinatal 9 | 1mo | 2016-10-10 | 2016-11-04 |  | 406d |  | start no earlier than 2016-10-08 | 1,100 |
| 617 | 1.3.4.3.1.2.1.10 | Acompañamiento técnico al análisis de la muerte perinatal 10 | 1mo | 2016-11-08 | 2016-12-05 |  | 385d |  | start no earlier than 2016-11-08 | 1,100 |
| 618 | 1.3.4.3.1.2.1.11 | Acompañamiento técnico al análisis de la muerte perinatal 11 | 1mo | 2016-12-08 | 2017-01-04 |  | 363d |  | start no earlier than 2016-12-08 | 1,100 |
| 619 | 1.3.4.3.1.2.1.12 | Acompañamiento técnico al análisis de la muerte perinatal 12 | 1mo | 2017-01-09 | 2017-02-03 |  | 341d |  | start no earlier than 2017-01-08 | 1,100 |
| 620 | 1.3.4.3.1.2.1.13 | Acompañamiento técnico al análisis de la muerte perinatal 13 | 1mo | 2017-02-08 | 2017-03-07 |  | 319d |  | start no earlier than 2017-02-08 | 1,100 |
| 621 | 1.3.4.3.1.2.1.14 | Acompañamiento técnico al análisis de la muerte perinatal 14 | 1mo | 2017-03-08 | 2017-04-04 |  | 299d |  | start no earlier than 2017-03-08 | 1,100 |
| 622 | 1.3.4.3.1.2.1.15 | Acompañamiento técnico al análisis de la muerte perinatal 15 | 1mo | 2017-04-10 | 2017-05-05 |  | 276d |  | start no earlier than 2017-04-08 | 1,100 |
| 623 | 1.3.4.3.1.2.1.16 | Acompañamiento técnico al análisis de la muerte perinatal 16 | 1mo | 2017-05-08 | 2017-06-02 |  | 256d |  | start no earlier than 2017-05-08 | 1,100 |
| 624 | 1.3.4.3.1.2.1.17 | Acompañamiento técnico al análisis de la muerte perinatal 17 | 1mo | 2017-06-08 | 2017-07-05 |  | 233d |  | start no earlier than 2017-06-08 | 1,100 |
| 625 | 1.3.4.3.1.2.1.18 | Acompañamiento técnico al análisis de la muerte perinatal 18 | 1mo | 2017-07-10 | 2017-08-04 |  | 211d |  | start no earlier than 2017-07-08 | 1,100 |
| 626 | 1.3.4.3.1.2.1.19 | Acompañamiento técnico al análisis de la muerte perinatal 19 | 1mo | 2017-08-08 | 2017-09-04 |  | 190d |  | start no earlier than 2017-08-08 | 1,100 |
| 627 | 1.3.4.3.1.2.1.20 | Acompañamiento técnico al análisis de la muerte perinatal 20 | 1mo | 2017-09-08 | 2017-10-05 |  | 167d |  | start no earlier than 2017-09-08 | 1,100 |
| 628 | 1.3.4.3.1.2.1.21 | Acompañamiento técnico al análisis de la muerte perinatal 21 | 1mo | 2017-10-09 | 2017-11-03 |  | 146d |  | start no earlier than 2017-10-08 | 1,100 |

| ID | WBS | Task | Type | Duration | Start | Finish | Predecessors | Total slack | Free slack | Constraint | Cost |
| --- | --- | --- | --- | --- | --- | --- | --- | --- | --- | --- | --- |
| 629 | 1.3.4.3.2 | **Análisis del 100% de los casos de muertes perinatal de acuerdo al manual** |  | 250d | 2016-02-02 | 2017-01-16 |  | 295d |  |  |  |
| 630 | 1.3.4.3.2.1 | Activar del análisis de muerte perinatal |  | 10d | 2016-02-02 | 2016-02-15 | 1369 | 295d | 0d |  |  |
| 631 | 1.3.4.3.2.2 | Dictámen de muerte perinatal |  | 240d | 2016-02-16 | 2017-01-16 | 630 | 295d | 0d |  |  |
| 632 | 1.3.4.3.2.3 | **Investigación de morbi mortalidad perinatal** |  | 130d | 2016-02-02 | 2016-08-01 |  | 475d |  |  |  |
| 633 | 1.3.4.3.2.3.1 | Diseño de la investigación |  | 20d | 2016-02-02 | 2016-02-29 | 1369 | 475d | 0d |  |  |
| 634 | 1.3.4.3.2.3.2 | Selección de los casos de estudio |  | 30d | 2016-03-01 | 2016-04-11 | 633 | 475d | 0d |  |  |
| 635 | 1.3.4.3.2.3.3 | Desarrollo de la investigación |  | 60d | 2016-04-12 | 2016-07-04 | 634 | 475d | 0d |  |  |
| 636 | 1.3.4.3.2.3.4 | Presentación y socialización de los resultados |  | 20d | 2016-07-05 | 2016-08-01 | 635 | 475d |  |  |  |
| 637 | 2 | **2. Fortalecimiento de la oferta y demanda de servicios de salud y nutrición para niños de 29 días a 5 años.** |  | 620d | 2016-01-05 | 2018-05-21 |  |  |  |  | 106,885.5 |
| 638 | 2.1 | **Indicador: 5060: 63.9% de madres que reportan haber suministrado SRO a sus hijos de 0-59 meses durante el último cuadro de diarrea** |  | 485d | 2016-02-02 | 2017-12-11 |  | 115d |  |  | 1,885.5 |
| 639 | 2.1.1 | **P1: Modelo integrado de atención del niño funcionando en 100% de CONE's Ambulatorios** |  | 395d | 2016-02-02 | 2017-08-07 |  | 205d |  |  | 1,885.5 |
| 640 | 2.1.1.1 | Adoptados los lineamiento de la estrategia de atención integrada del Nino | milestone | 15d | 2016-02-02 | 2016-02-22 |  | 585d |  | start no earlier than 2016-02-02 |  |
| 641 | 2.1.1.2 | **Personal vinculado conoce y adopta los lineamientos de la estrategia** |  | 255d | 2016-02-02 | 2017-01-23 |  | 205d |  |  |  |
| 642 | 2.1.1.2.1 | **Impresión de materiales** |  | 115d | 2016-02-02 | 2016-07-11 |  | 205d |  |  |  |
| 643 | 2.1.1.2.1.1 | Definición de materiales |  | 10d | 2016-02-02 | 2016-02-15 | 1369 | 205d | 0d |  |  |
| 644 | 2.1.1.2.1.2 | Contratación de los talleres gráficos |  | 45d | 2016-02-16 | 2016-04-18 | 643 | 205d | 0d |  |  |
| 645 | 2.1.1.2.1.3 | Recepción de las impresiones | milestone | 40d | 2016-04-19 | 2016-06-13 | 644 | 205d | 0d |  |  |
| 646 | 2.1.1.2.1.4 | Distribución de los materiales |  | 20d | 2016-06-14 | 2016-07-11 | 645 | 205d | 0d |  |  |
| 647 | 2.1.1.2.2 | Actualización de formadores CEC para la aplicación del modelo | milestone | 60d | 2016-07-12 | 2016-10-03 | 646 | 205d | 0d |  |  |
| 648 | 2.1.1.2.3 | Capacitación de personal comunitario en la aplicación del modelo |  | 80d | 2016-10-04 | 2017-01-23 | 647 | 345d |  |  |  |
| 649 | 2.1.1.2.4 | Talleres de socialización y conocimiento de las guías |  | 120d | 2016-07-12 | 2016-12-26 | 646 | 365d |  |  |  |
| 650 | 2.1.1.3 | **Monitoreo, seguimiento y evaluación de la implementación** |  | 395d | 2016-02-02 | 2017-08-07 |  | 205d |  |  | 1,885.5 |
| 651 | 2.1.1.3.1 | **Supervisión de la estrategia de atención** |  | 220d | 2016-10-04 | 2017-08-07 |  | 205d |  |  |  |
| 652 | 2.1.1.3.1.1 | Aplicación de las guías de supervisión | milestone | 220d | 2016-10-04 | 2017-08-07 | 647 | 205d |  |  |  |
| 653 | 2.1.1.3.1.2 | Análisis de resultados y mejora continua del modelo |  | 5d | 2016-11-29 | 2016-12-05 | 647FS+40d | 210d | 0d |  |  |
| 654 | 2.1.1.3.1.3 | Análisis de resultados y mejora continua del modelo |  | 5d | 2017-01-31 | 2017-02-06 | 653FS+40d | 210d | 0d |  |  |
| 655 | 2.1.1.3.1.4 | Análisis de resultados y mejora continua del modelo |  | 5d | 2017-04-04 | 2017-04-10 | 654FS+40d | 210d | 0d |  |  |
| 656 | 2.1.1.3.1.5 | Análisis de resultados y mejora continua del modelo | milestone | 5d | 2017-06-06 | 2017-06-12 | 655FS+40d | 210d | 0d |  |  |
| 657 | 2.1.1.3.1.6 | Análisis de resultados y mejora continua del modelo |  | 5d | 2017-07-25 | 2017-07-31 | 656FS+30d | 210d |  |  |  |

Notes:
- 640: La estrategia se esta elaborando y estaría terminada antes de la II Operación, Ads, may5

| ID | WBS | Task | Type | Duration | Start | Finish | Predecessors | Total slack | Free slack | Cost |
| --- | --- | --- | --- | --- | --- | --- | --- | --- | --- | --- |
| 658 | 2.1.1.3.2 | **Monitoreo y seguimiento del proceso de desparasitación** |  | 220d | 2016-02-02 | 2016-12-05 |  | 380d |  | 1,885.5 |
| 659 | 2.1.1.3.2.1 | **Monitoreo parasitológico** |  | 60d | 2016-02-02 | 2016-04-25 |  | 420d |  | 1,885.5 |
| 660 | 2.1.1.3.2.1.1 | Compra de los insumos |  | 20d | 2016-02-02 | 2016-02-29 | 1369 | 420d | 0d | 1,885.5 |
| 661 | 2.1.1.3.2.1.2 | Aplicación de las muestras |  | 20d | 2016-03-01 | 2016-03-28 | 660 | 420d | 0d |  |
| 662 | 2.1.1.3.2.1.3 | Análisis de los resultados de las muestras |  | 20d | 2016-03-29 | 2016-04-25 | 661 | 420d | 0d |  |
| 663 | 2.1.1.3.2.2 | Informe de resultados y plan de acción |  | 120d | 2016-04-26 | 2016-10-10 | 662 | 420d |  |  |
| 664 | 2.1.1.3.2.3 | **Supervisión de las campanas** |  | 220d | 2016-02-02 | 2016-12-05 |  | 380d |  |  |
| 665 | 2.1.1.3.2.3.1 | Campana 1 2015 | milestone | 10d | 2016-02-02 | 2016-02-15 | 1369 | 380d | 0d |  |
| 666 | 2.1.1.3.2.3.2 | Campana 2 2015 |  | 10d | 2016-06-21 | 2016-07-04 | 665FS+90d | 380d | 0d |  |
| 667 | 2.1.1.3.2.3.3 | Campana 1 2016 | milestone | 10d | 2016-11-22 | 2016-12-05 | 666FS+100d | 380d |  |  |
| 668 | 2.1.1.3.3 | **Evaluación del EsIAN** |  | 240d | 2016-02-02 | 2017-01-02 |  | 360d |  |  |
| 669 | 2.1.1.3.3.1 | Diseno de lo modelo de evaluación |  | 60d | 2016-02-02 | 2016-04-25 | 1369 | 360d | 0d |  |
| 670 | 2.1.1.3.3.2 | Definición del alcance de la evaluación |  | 20d | 2016-04-26 | 2016-05-23 | 669 | 360d | 0d |  |
| 671 | 2.1.1.3.3.3 | Selección del consultor |  | 20d | 2016-05-24 | 2016-06-20 | 670 | 360d | 0d |  |
| 672 | 2.1.1.3.3.4 | Firma del contrato |  | 20d | 2016-06-21 | 2016-07-18 | 671 | 360d | 0d |  |
| 673 | 2.1.1.3.3.5 | Informe de resultados y plan de acción | milestone | 120d | 2016-07-19 | 2017-01-02 | 672 | 360d |  |  |
| 674 | 2.1.2 | **P2 301 Unidades de salud y sus comunidades abastecidas con SRO** |  | 450d | 2016-02-02 | 2017-10-23 |  | 150d |  |  |
| 675 | 2.1.2.1 | **Asegurada la estimación de necesidades para centros de salud y sus puestos de distribución** |  | 265d | 2016-02-02 | 2017-02-06 |  | 335d |  |  |
| 676 | 2.1.2.1.1 | Definición de criterios para el establecimiento de los puestos de distribución |  | 5d | 2016-02-02 | 2016-02-08 | 1369 | 335d | 0d |  |
| 677 | 2.1.2.1.2 | Cuantificación de los puestos de distribución disponibles |  | 20d | 2016-02-09 | 2016-03-07 | 676 | 335d | 0d |  |
| 678 | 2.1.2.1.3 | Estimación de las necesidades para 2016 |  | 15d | 2016-03-08 | 2016-03-28 | 677 | 335d | 0d |  |
| 679 | 2.1.2.1.4 | Estimación de las necesidades para 2017 |  | 15d | 2017-01-17 | 2017-02-06 | 678FS+210d | 335d |  |  |
| 680 | 2.1.2.2 | **Abastecidos los puestos de distribución** |  | 350d | 2016-06-21 | 2017-10-23 |  | 150d |  |  |
| 681 | 2.1.2.2.1 | Identificación de necesidades |  | 30d | 2016-06-21 | 2016-08-01 | 1369FS+100d | 150d | 0d |  |
| 682 | 2.1.2.2.2 | Selección de proveedor |  | 40d | 2016-08-02 | 2016-09-26 | 681 | 150d | 0d |  |
| 683 | 2.1.2.2.3 | Adquisición de las sales para 2016 |  | 40d | 2016-09-27 | 2016-11-21 | 682 | 150d | 0d |  |
| 684 | 2.1.2.2.4 | Adquisición de las sales para 2017 |  | 40d | 2017-08-29 | 2017-10-23 | 683FS+200d | 150d |  |  |

| ID | WBS | Task | Duration | Start | Finish | Predecessors | Total slack | Free slack |
| --- | --- | --- | --- | --- | --- | --- | --- | --- |
| 685 | 2.1.3 | **P3: Implementado el plan de comunicación para prevención y manejo de diarrea en el 100% de servicios de salud y sus comunidades** | 155d | 2016-02-02 | 2016-09-05 |  | 445d |  |
| 686 | 2.1.3.1 | **Reproducción y distribución de materiales educativos** | 105d | 2016-02-02 | 2016-06-27 |  | 495d |  |
| 687 | 2.1.3.1.1 | **Reproducción de materiales** | 85d | 2016-02-02 | 2016-05-30 |  | 495d |  |
| 688 | 2.1.3.1.1.1 | Selección de los materiales | 20d | 2016-02-02 | 2016-02-29 | 1369 | 495d | 0d |
| 689 | 2.1.3.1.1.2 | Diseño gráfico de los materiales | 15d | 2016-03-01 | 2016-03-21 | 688 | 495d | 0d |
| 690 | 2.1.3.1.1.3 | Contratación de talleres gráficos | 10d | 2016-03-22 | 2016-04-04 | 689 | 495d | 0d |
| 691 | 2.1.3.1.1.4 | Recepción de los materiales | 40d | 2016-04-05 | 2016-05-30 | 690 | 495d | 0d |
| 692 | 2.1.3.1.2 | Distribución de los materiales | 20d | 2016-05-31 | 2016-06-27 | 691 | 495d |  |
| 693 | 2.1.3.2 | **Formación y capacitación** | 155d | 2016-02-02 | 2016-09-05 |  | 445d |  |
| 694 | 2.1.3.2.1 | Calendarización y organización de los talleres | 15d | 2016-02-02 | 2016-02-22 | 1369 | 445d | 0d |
| 695 | 2.1.3.2.2 | Capacitación presencial para vocales, auxiliares y parteras en los temas de las visitas domiciliarias | 120d | 2016-02-23 | 2016-08-08 | 694 | 445d | 0d |
| 696 | 2.1.3.2.3 | Supervision de los procesos de capacitación | 100d | 2016-04-19 | 2016-09-05 | 695FS-80d | 445d |  |
| 697 | 2.1.4 | **P4 Al menos 50,000 mujeres recibiendo sales de rehidratación oral y educación** | 480d | 2016-02-02 | 2017-12-04 |  | 120d |  |
| 698 | 2.1.4.1 | **100% de las madres en servicios de salud reciben SRO** | 480d | 2016-02-02 | 2017-12-04 |  | 120d |  |
| 699 | 2.1.4.1.1 | Implementación de la captación de las mujeres en la "hoja de línea de vida" u hoja filtro | 40d | 2016-02-02 | 2016-03-28 | 1369 | 120d | 0d |
| 700 | 2.1.4.1.2 | Entrega de sobres a toda mujer captada | 440d | 2016-03-29 | 2017-12-04 | 699 | 120d |  |
| 701 | 2.1.4.1.3 | Registro de la distribución de las SRO | 440d | 2016-03-29 | 2017-12-04 | 699 | 120d |  |
| 702 | 2.1.4.2 | **100% de las madres en las comunidades pueden acceder a las SRO en los puestos de distribución.** | 480d | 2016-02-02 | 2017-12-04 |  | 120d |  |
| 703 | 2.1.4.2.1 | Creación de puestos de distribución (de acuerdo a lineamiento establecido) en las comunidades más alejadas de cada unidad de salud | 40d | 2016-02-02 | 2016-03-28 | 1369 | 560d |  |
| 704 | 2.1.4.2.2 | Establecer un puesto de distribución donde existe un auxiliar de salud | 40d | 2016-02-02 | 2016-03-28 | 1369 | 120d | 0d |
| 705 | 2.1.4.2.3 | Registro de la distribución de las SRO | 440d | 2016-03-29 | 2017-12-04 | 704 | 120d |  |
| 706 | 2.1.4.3 | **Captación de madres para distribución de sales de rehidratación oral en semanas de la salud, talleres comunitarios, ferias de la salud** | 480d | 2016-02-02 | 2017-12-04 |  | 120d |  |
| 707 | 2.1.4.3.1 | **Distribución de SRO en las semanas nacionales de salud** | 440d | 2016-03-29 | 2017-12-04 |  | 120d |  |
| 708 | 2.1.4.3.1.1 | Semana de la salud I 2016 | 30d | 2016-03-29 | 2016-05-09 | 1369FS+40d | 120d | 0d |
| 709 | 2.1.4.3.1.2 | Semana de la salud II 2016 | 30d | 2016-07-05 | 2016-08-15 | 708FS+40d | 120d | 0d |
| 710 | 2.1.4.3.1.3 | Semana de la salud III 2016 | 30d | 2016-10-11 | 2016-11-21 | 709FS+40d | 120d | 0d |
| 711 | 2.1.4.3.1.4 | Semana de la salud I 2017 | 30d | 2017-03-14 | 2017-04-24 | 710FS+80d | 120d | 0d |
| 712 | 2.1.4.3.1.5 | Semana de la salud II 2017 | 30d | 2017-06-20 | 2017-07-31 | 711FS+40d | 120d | 0d |
| 713 | 2.1.4.3.1.6 | Semana de la salud III 2017 | 30d | 2017-10-24 | 2017-12-04 | 712FS+60d | 120d |  |
| 714 | 2.1.4.3.2 | Distribución de sobre en los talleres comunitarios | 440d | 2016-02-02 | 2017-10-09 | 1369 | 160d |  |
| 715 | 2.1.4.3.3 | Distribución de sobres en las ferias de la salud. | 440d | 2016-02-02 | 2017-10-09 | 1369 | 160d |  |
| 716 | 2.1.4.3.4 | Registro de la distribución de las SRO | 440d | 2016-02-02 | 2017-10-09 | 1369 | 160d |  |

| ID | WBS | Task | Duration | Start | Finish | Predecessors | Total slack | Free slack |
| --- | --- | --- | --- | --- | --- | --- | --- | --- |
| 717 | 2.1.5 | **P5: Reducción de la carga parasitaria en niños preescolares entre 2 y 5 anios** | 230d | 2016-02-02 | 2016-12-19 |  | 370d |  |
| 718 | 2.1.5.1 | **Diseno del modelo operativo (jardines infantiles) en SNS y campañas específicas** | 80d | 2016-02-02 | 2016-05-23 |  | 520d |  |
| 719 | 2.1.5.1.1 | Establecimiento del plan operativo | 20d | 2016-02-02 | 2016-02-29 | 1369 | 520d | 0d |
| 720 | 2.1.5.1.2 | Creación del grupo de trabajo | 20d | 2016-03-01 | 2016-03-28 | 719 | 520d | 0d |
| 721 | 2.1.5.1.3 | Designación del grupo técnico | 20d | 2016-03-29 | 2016-04-25 | 720 | 520d | 0d |
| 722 | 2.1.5.1.4 | Manual operativo de trabajo | 20d | 2016-04-26 | 2016-05-23 | 721 | 520d |  |
| 723 | 2.1.5.2 | **Adquisición de insumos para las campañas de desparasitación** | 230d | 2016-02-02 | 2016-12-19 |  | 370d |  |
| 724 | 2.1.5.2.1 | Identificación de las necesidades | 30d | 2016-02-02 | 2016-03-14 | 1369 | 370d | 0d |
| 725 | 2.1.5.2.2 | Selección del proveedor | 40d | 2016-03-15 | 2016-05-09 | 724 | 370d | 0d |
| 726 | 2.1.5.2.3 | Recepción de los insumos | 40d | 2016-05-10 | 2016-07-04 | 725 | 370d | 0d |
| 727 | 2.1.5.2.4 | Distribución de los insumos | 120d | 2016-07-05 | 2016-12-19 | 726 | 370d |  |
| 728 | 2.1.5.2.5 | Distribución de los medicamentos | 120d | 2016-07-05 | 2016-12-19 | 726 | 370d |  |
| 729 | 2.1.5.3 | **Evaluación de carga parasitaria por medio de Kato Katz** | 140d | 2016-02-02 | 2016-08-15 |  | 460d |  |
| 730 | 2.1.5.3.1 | Diseño de las muestras | 20d | 2016-02-02 | 2016-02-29 | 1369 | 460d | 0d |
| 731 | 2.1.5.3.2 | Compra de materiales para muestras | 40d | 2016-03-01 | 2016-04-25 | 730 | 460d | 0d |
| 732 | 2.1.5.3.3 | Toma de muestras y de seroconversión | 40d | 2016-04-26 | 2016-06-20 | 731 | 460d | 0d |
| 733 | 2.1.5.3.4 | Estudio de las muestras y resultados | 20d | 2016-06-21 | 2016-07-18 | 732 | 460d | 0d |
| 734 | 2.1.5.3.5 | Definición de acciones correctivas | 20d | 2016-07-19 | 2016-08-15 | 733 | 460d |  |
| 735 | 2.1.6 | **P6: Implementada la estrategia EsIAN en 301 unidades de salud y sus comunidades** | 485d | 2016-02-02 | 2017-12-11 |  | 115d |  |
| 736 | 2.1.6.1 | **Reproducción y distribución de manuales y materiales educativos de la EsIAN** | 280d | 2016-02-02 | 2017-02-27 |  | 320d |  |
| 737 | 2.1.6.1.1 | Recepción del material del nivel Federal | 20d | 2016-02-02 | 2016-02-29 | 1369 | 580d |  |
| 738 | 2.1.6.1.2 | Estimación de necesidades del material adaptado | 20d | 2016-02-02 | 2016-02-29 | 1369 | 390d | 0d |
| 739 | 2.1.6.1.3 | Especificaciones técnicas | 10d | 2016-03-01 | 2016-03-14 | 738 | 390d | 0d |
| 740 | 2.1.6.1.4 | Contratación de talleres gráficos | 20d | 2016-03-15 | 2016-04-11 | 739 | 390d | 0d |
| 741 | 2.1.6.1.5 | Recepción de los materiales | 40d | 2016-04-12 | 2016-06-06 | 740 | 390d | 0d |
| 742 | 2.1.6.1.6 | Distribución del material adaptado | 120d | 2016-06-07 | 2016-11-21 | 741 | 390d |  |
| 743 | 2.1.6.1.7 | Recepción de material del nivel Federal para el 2017 | 60d | 2016-12-06 | 2017-02-27 | 1369FS+220d | 320d |  |

| ID | WBS | Task | Duration | Start | Finish | Predecessors | Total slack | Constraint |
| --- | --- | --- | --- | --- | --- | --- | --- | --- |
| 744 | 2.1.6.2 | **Implementación de la comunicación interpersonal** | 480d | 2016-02-02 | 2017-12-04 |  | 120d |  |
| 745 | 2.1.6.2.1 | Consejería en el contexto de las consultas | 480d | 2016-02-02 | 2017-12-04 | 1369 | 120d |  |
| 746 | 2.1.6.2.2 | Talleres comunitarios con las beneficiarias | 480d | 2016-02-02 | 2017-12-04 | 1369 | 120d |  |
| 747 | 2.1.6.2.3 | Visitas domiciliarias | 480d | 2016-02-02 | 2017-12-04 | 1369 | 120d |  |
| 748 | 2.1.6.3 | **Sistema de supervisión de la comunicación interpersonal** | 481d | 2016-02-02 | 2017-12-05 |  | 119d |  |
| 749 | 2.1.6.3.1 | Diseño del modelo de supervisión | 20d | 2016-02-02 | 2016-02-29 | 1369 | 580d |  |
| 750 | 2.1.6.3.2 | **Informe de supervisión del nivel local y comunitario** | 457d | 2016-03-07 | 2017-12-05 |  | 119d |  |
| 751 | 2.1.6.3.2.1 | Informe de supervisión del nivel local y comunitario 1 | 22d | 2016-03-07 | 2016-04-05 |  | 554d | start no earlier than 2016-03-05 |
| 752 | 2.1.6.3.2.2 | Informe de supervisión del nivel local y comunitario 2 | 22d | 2016-04-05 | 2016-05-04 |  | 533d | start no earlier than 2016-04-05 |
| 753 | 2.1.6.3.2.3 | Informe de supervisión del nivel local y comunitario 3 | 22d | 2016-05-05 | 2016-06-03 |  | 511d | start no earlier than 2016-05-05 |
| 754 | 2.1.6.3.2.4 | Informe de supervisión del nivel local y comunitario 4 | 22d | 2016-06-06 | 2016-07-05 |  | 489d | start no earlier than 2016-06-05 |
| 755 | 2.1.6.3.2.5 | Informe de supervisión del nivel local y comunitario 5 | 22d | 2016-07-05 | 2016-08-03 |  | 468d | start no earlier than 2016-07-05 |
| 756 | 2.1.6.3.2.6 | Informe de supervisión del nivel local y comunitario 6 | 22d | 2016-08-05 | 2016-09-05 |  | 445d | start no earlier than 2016-08-05 |
| 757 | 2.1.6.3.2.7 | Informe de supervisión del nivel local y comunitario 7 | 22d | 2016-09-05 | 2016-10-04 |  | 424d | start no earlier than 2016-09-05 |
| 758 | 2.1.6.3.2.8 | Informe de supervisión del nivel local y comunitario 8 | 22d | 2016-10-05 | 2016-11-03 |  | 402d | start no earlier than 2016-10-05 |
| 759 | 2.1.6.3.2.9 | Informe de supervisión del nivel local y comunitario 9 | 22d | 2016-11-07 | 2016-12-06 |  | 379d | start no earlier than 2016-11-05 |
| 760 | 2.1.6.3.2.10 | Informe de supervisión del nivel local y comunitario 10 | 22d | 2016-12-05 | 2017-01-03 |  | 359d | start no earlier than 2016-12-05 |
| 761 | 2.1.6.3.2.11 | Informe de supervisión del nivel local y comunitario 11 | 22d | 2017-01-05 | 2017-02-03 |  | 336d | start no earlier than 2017-01-05 |
| 762 | 2.1.6.3.2.12 | Informe de supervisión del nivel local y comunitario 12 | 22d | 2017-02-06 | 2017-03-07 |  | 314d | start no earlier than 2017-02-05 |
| 763 | 2.1.6.3.2.13 | Informe de supervisión del nivel local y comunitario 13 | 22d | 2017-03-06 | 2017-04-04 |  | 294d | start no earlier than 2017-03-05 |
| 764 | 2.1.6.3.2.14 | Informe de supervisión del nivel local y comunitario 14 | 22d | 2017-04-05 | 2017-05-04 |  | 272d | start no earlier than 2017-04-05 |
| 765 | 2.1.6.3.2.15 | Informe de supervisión del nivel local y comunitario 15 | 22d | 2017-05-05 | 2017-06-05 |  | 250d | start no earlier than 2017-05-05 |
| 766 | 2.1.6.3.2.16 | Informe de supervisión del nivel local y comunitario 16 | 22d | 2017-06-05 | 2017-07-04 |  | 229d | start no earlier than 2017-06-05 |
| 767 | 2.1.6.3.2.17 | Informe de supervisión del nivel local y comunitario 17 | 22d | 2017-07-05 | 2017-08-03 |  | 207d | start no earlier than 2017-07-05 |
| 768 | 2.1.6.3.2.18 | Informe de supervisión del nivel local y comunitario 18 | 22d | 2017-08-07 | 2017-09-05 |  | 184d | start no earlier than 2017-08-05 |
| 769 | 2.1.6.3.2.19 | Informe de supervisión del nivel local y comunitario 19 | 22d | 2017-09-05 | 2017-10-04 |  | 163d | start no earlier than 2017-09-05 |
| 770 | 2.1.6.3.2.20 | Informe de supervisión del nivel local y comunitario 20 | 22d | 2017-10-05 | 2017-11-03 |  | 141d | start no earlier than 2017-10-05 |
| 771 | 2.1.6.3.2.21 | Informe de supervisión del nivel local y comunitario 21 | 22d | 2017-11-06 | 2017-12-05 |  | 119d | start no earlier than 2017-11-05 |

| ID | WBS | Task | Duration | Start | Finish | Predecessors | Total slack | Free slack | Cost |
| --- | --- | --- | --- | --- | --- | --- | --- | --- | --- |
| 772 | 2.1.6.4 | **Seguimiento y monitoreo de la implementación de la estrategia** | 395d | 2016-06-07 | 2017-12-11 |  | 115d |  |  |
| 773 | 2.1.6.4.1 | Informes trimestrales de monitoreo del EsIAN | 5d | 2016-06-07 | 2016-06-13 | 1369FS+90d | 115d | 0d |  |
| 774 | 2.1.6.4.2 | Informes trimestrales de monitoreo del EsIAN | 5d | 2016-09-06 | 2016-09-12 | 773FS+60d | 115d | 0d |  |
| 775 | 2.1.6.4.3 | Informes trimestrales de monitoreo del EsIAN | 5d | 2016-12-06 | 2016-12-12 | 774FS+60d | 115d | 0d |  |
| 776 | 2.1.6.4.4 | Informes trimestrales de monitoreo del EsIAN | 5d | 2017-03-07 | 2017-03-13 | 775FS+60d | 115d | 0d |  |
| 777 | 2.1.6.4.5 | Informes trimestrales de monitoreo del EsIAN | 5d | 2017-06-06 | 2017-06-12 | 776FS+60d | 115d | 0d |  |
| 778 | 2.1.6.4.6 | Informes trimestrales de monitoreo del EsIAN | 5d | 2017-09-05 | 2017-09-11 | 777FS+60d | 115d | 0d |  |
| 779 | 2.1.6.4.7 | Informes trimestrales de monitoreo del EsIAN | 5d | 2017-12-05 | 2017-12-11 | 778FS+60d | 115d |  |  |
| 780 | 2.1.6.5 | **Comunicación masiva** | 420d | 2016-02-02 | 2017-09-11 |  | 180d |  |  |
| 781 | 2.1.6.5.1 | Definición del alcance de la campaña | 20d | 2016-02-02 | 2016-02-29 | 1369 | 180d | 0d |  |
| 782 | 2.1.6.5.2 | Coordinación con el sistema de la radio y televisión Chiapaneco y otros canales de radio indigenista | 60d | 2016-03-01 | 2016-05-23 | 781 | 180d | 0d |  |
| 783 | 2.1.6.5.3 | Contratar los medios de comunicación | 60d | 2016-05-24 | 2016-08-15 | 782 | 180d | 0d |  |
| 784 | 2.1.6.5.4 | Implementación de la campaña | 240d | 2016-08-16 | 2017-07-17 | 783 | 180d | 0d |  |
| 785 | 2.1.6.5.5 | Disenar y supervisar la implementación de la campaña | 200d | 2016-12-06 | 2017-09-11 | 784FS-160d | 180d |  |  |
| 786 | 2.2 | **Indicador cobertura de vacunacion de la triple viral en al menos el 57,5% en niños de 12 a 23 meses.** | 600d | 2016-02-02 | 2018-05-21 |  | 0d |  | 55,000 |
| 787 | 2.2.1 | **P1 181 Unidades de salud con disponibilidad permanente de vacunas** | 482d | 2016-02-02 | 2017-12-06 |  | 118d |  |  |
| 788 | 2.2.1.1 | **Asegurada la adecuada programación de necesidades de vacunas** | 260d | 2016-04-26 | 2017-04-24 |  | 280d |  |  |
| 789 | 2.2.1.1.1 | **Identificación de necesidades de vacuna con base al universo de niños de 12 a 23 meses en área de responsabilidad del ISECH.** | 260d | 2016-04-26 | 2017-04-24 |  | 280d |  |  |
| 790 | 2.2.1.1.1.1 | Necesidades del 2017 | 20d | 2016-04-26 | 2016-05-23 | 1369FS+60d | 280d | 0d |  |
| 791 | 2.2.1.1.1.2 | Necesidades del 2018 | 20d | 2017-03-28 | 2017-04-24 | 790FS+220d | 280d |  |  |
| 792 | 2.2.1.1.2 | **Identificacar las necesidades de insumos para la vacunación.** | 260d | 2016-04-26 | 2017-04-24 |  | 280d |  |  |
| 793 | 2.2.1.1.2.1 | Necesidades del 2017 | 20d | 2016-04-26 | 2016-05-23 | 1369FS+60d | 280d | 0d |  |
| 794 | 2.2.1.1.2.2 | Necesidades del 2018 | 20d | 2017-03-28 | 2017-04-24 | 793FS+220d | 280d |  |  |
| 795 | 2.2.1.2 | **Seguimiento a la compra de las vacunas en el Estado** | 482d | 2016-02-02 | 2017-12-06 |  | 118d |  |  |
| 796 | 2.2.1.2.1 | Firma del convenio con la empresa BIRMEX | 30d | 2016-02-02 | 2016-03-14 | 1369 | 250d | 0d |  |
| 797 | 2.2.1.2.2 | Vigilar el seguimiento de la distribución de vacunas por BIRMEX 2016 | 60d | 2016-03-15 | 2016-06-06 | 796 | 250d | 0d |  |
| 798 | 2.2.1.2.3 | Vigilar el seguimiento de la distribución de vacunas por BIRMEX 2017 | 60d | 2017-03-14 | 2017-06-05 | 797FS+200d | 250d |  |  |

| ID | WBS | Task | Duration | Start | Finish | Total slack | Constraint |
| --- | --- | --- | --- | --- | --- | --- | --- |
| 799 | 2.2.1.2.4 | **monitoreo de la distribución de vacunas a nivel Jurisdiccional** | 479d | 2016-02-05 | 2017-12-06 | 118d |  |
| 800 | 2.2.1.2.4.1 | monitoreo de la distribución de vacunas 2 | 2d | 2016-02-05 | 2016-02-08 | 595d | start no earlier than 2016-02-05 |
| 801 | 2.2.1.2.4.2 | monitoreo de la distribución de vacunas 3 | 2d | 2016-03-07 | 2016-03-08 | 574d | start no earlier than 2016-03-05 |
| 802 | 2.2.1.2.4.3 | monitoreo de la distribución de vacunas 4 | 2d | 2016-04-05 | 2016-04-06 | 553d | start no earlier than 2016-04-05 |
| 803 | 2.2.1.2.4.4 | monitoreo de la distribución de vacunas 5 | 2d | 2016-05-05 | 2016-05-06 | 531d | start no earlier than 2016-05-05 |
| 804 | 2.2.1.2.4.5 | monitoreo de la distribución de vacunas 6 | 2d | 2016-06-06 | 2016-06-07 | 509d | start no earlier than 2016-06-05 |
| 805 | 2.2.1.2.4.6 | monitoreo de la distribución de vacunas 7 | 2d | 2016-07-05 | 2016-07-06 | 488d | start no earlier than 2016-07-05 |
| 806 | 2.2.1.2.4.7 | monitoreo de la distribución de vacunas 8 | 2d | 2016-08-05 | 2016-08-08 | 465d | start no earlier than 2016-08-05 |
| 807 | 2.2.1.2.4.8 | monitoreo de la distribución de vacunas 9 | 2d | 2016-09-05 | 2016-09-06 | 444d | start no earlier than 2016-09-05 |
| 808 | 2.2.1.2.4.9 | monitoreo de la distribución de vacunas 10 | 2d | 2016-10-05 | 2016-10-06 | 422d | start no earlier than 2016-10-05 |
| 809 | 2.2.1.2.4.10 | monitoreo de la distribución de vacunas 11 | 2d | 2016-11-07 | 2016-11-08 | 399d | start no earlier than 2016-11-05 |
| 810 | 2.2.1.2.4.11 | monitoreo de la distribución de vacunas 12 | 2d | 2016-12-05 | 2016-12-06 | 379d | start no earlier than 2016-12-05 |
| 811 | 2.2.1.2.4.12 | monitoreo de la distribución de vacunas 13 | 2d | 2017-01-05 | 2017-01-06 | 356d | start no earlier than 2017-01-05 |
| 812 | 2.2.1.2.4.13 | monitoreo de la distribución de vacunas 14 | 2d | 2017-02-06 | 2017-02-07 | 334d | start no earlier than 2017-02-05 |
| 813 | 2.2.1.2.4.14 | monitoreo de la distribución de vacunas 15 | 2d | 2017-03-06 | 2017-03-07 | 314d | start no earlier than 2017-03-05 |
| 814 | 2.2.1.2.4.15 | monitoreo de la distribución de vacunas 16 | 2d | 2017-04-05 | 2017-04-06 | 292d | start no earlier than 2017-04-05 |
| 815 | 2.2.1.2.4.16 | monitoreo de la distribución de vacunas 17 | 2d | 2017-05-05 | 2017-05-08 | 270d | start no earlier than 2017-05-05 |
| 816 | 2.2.1.2.4.17 | monitoreo de la distribución de vacunas 18 | 2d | 2017-06-05 | 2017-06-06 | 249d | start no earlier than 2017-06-05 |
| 817 | 2.2.1.2.4.18 | monitoreo de la distribución de vacunas 19 | 2d | 2017-07-05 | 2017-07-06 | 227d | start no earlier than 2017-07-05 |
| 818 | 2.2.1.2.4.19 | monitoreo de la distribución de vacunas 20 | 2d | 2017-08-07 | 2017-08-08 | 204d | start no earlier than 2017-08-05 |
| 819 | 2.2.1.2.4.20 | monitoreo de la distribución de vacunas 21 | 2d | 2017-09-05 | 2017-09-06 | 183d | start no earlier than 2017-09-05 |
| 820 | 2.2.1.2.4.21 | monitoreo de la distribución de vacunas 22 | 2d | 2017-10-05 | 2017-10-06 | 161d | start no earlier than 2017-10-05 |
| 821 | 2.2.1.2.4.22 | monitoreo de la distribución de vacunas 23 | 2d | 2017-11-06 | 2017-11-07 | 139d | start no earlier than 2017-11-05 |
| 822 | 2.2.1.2.4.23 | monitoreo de la distribución de vacunas 24 | 2d | 2017-12-05 | 2017-12-06 | 118d | start no earlier than 2017-12-05 |

| ID | WBS | Task | Duration | Start | Finish | Predecessors | Total slack | Free slack | Constraint | Cost |
| --- | --- | --- | --- | --- | --- | --- | --- | --- | --- | --- |
| 823 | 2.2.1.3 | **Garantizar las necesidades de vacuna e insumos para la vacunación** | 110d | 2016-04-26 | 2016-09-26 |  | 430d |  |  |  |
| 824 | 2.2.1.3.1 | **Estimación de necesidades de adquisición de emergencia** | 110d | 2016-04-26 | 2016-09-26 |  | 430d |  |  |  |
| 825 | 2.2.1.3.1.1 | Especificaciones técnicas | 20d | 2016-04-26 | 2016-05-23 | 1369FS+60d | 430d | 0d |  |  |
| 826 | 2.2.1.3.1.2 | Selección del proveedor | 40d | 2016-05-24 | 2016-07-18 | 825 | 430d | 0d |  |  |
| 827 | 2.2.1.3.1.3 | Recepción de las vacunas | 50d | 2016-07-19 | 2016-09-26 | 826 | 430d |  |  |  |
| 828 | 2.2.1.3.2 | **Estimación de necesidades de adquisición complementaria de vacunas para 2017** | 110d | 2016-04-26 | 2016-09-26 |  | 430d |  |  |  |
| 829 | 2.2.1.3.2.1 | Especificaciones técnicas | 20d | 2016-04-26 | 2016-05-23 | 1369FS+60d | 430d | 0d |  |  |
| 830 | 2.2.1.3.2.2 | Selección del proveedor | 40d | 2016-05-24 | 2016-07-18 | 829 | 430d | 0d |  |  |
| 831 | 2.2.1.3.2.3 | Recepción de las vacunas | 50d | 2016-07-19 | 2016-09-26 | 830 | 430d |  |  |  |
| 832 | 2.2.2 | **P2 181 unidades de salud con cadena de frío funcionando de acuerdo a norma** | 508d | 2016-02-02 | 2018-01-11 |  | 92d |  |  | 55,000 |
| 833 | 2.2.2.1 | **Adquisición y distribución de equipo de red de frío (datalogger, equipos solares, equipos basicos)** | 125d | 2016-02-02 | 2016-07-25 |  | 475d |  |  | 55,000 |
| 834 | 2.2.2.1.1 | Especificaciones técnicas | 5d | 2016-02-02 | 2016-02-08 | 1369 | 475d | 0d |  |  |
| 835 | 2.2.2.1.2 | Selección del proveedor | 40d | 2016-02-09 | 2016-04-04 | 834 | 475d | 0d |  |  |
| 836 | 2.2.2.1.3 | recepción de Datalogger | 40d | 2016-04-05 | 2016-05-30 | 835 | 515d |  |  | 50,000 |
| 837 | 2.2.2.1.4 | Recepción de refrigeradoras solares | 40d | 2016-04-05 | 2016-05-30 | 835 | 475d | 0d |  |  |
| 838 | 2.2.2.1.5 | Recepción de equipos de frío | 40d | 2016-04-05 | 2016-05-30 | 835 | 515d |  |  |  |
| 839 | 2.2.2.1.6 | equipo informatico para la operación del sistema de monitoreo de la red | 40d | 2016-04-05 | 2016-05-30 | 835 | 515d |  |  |  |
| 840 | 2.2.2.1.7 | Instalación y prueba de los equipos de frío | 40d | 2016-05-31 | 2016-07-25 | 837 | 475d |  |  | 5,000 |
| 841 | 2.2.2.2 | **Red de frío monitoreada adecuadamente** | 398d | 2016-07-05 | 2018-01-11 |  | 92d |  |  |  |
| 842 | 2.2.2.2.1 | Capacitación para la operación del sistema | 60d | 2016-10-25 | 2017-01-16 | 1090 | 350d |  |  |  |
| 843 | 2.2.2.2.2 | **Gestión de la herramienta informática de gestión de la red de frío** | 398d | 2016-07-05 | 2018-01-11 |  | 92d |  |  |  |
| 844 | 2.2.2.2.2.1 | **recepción, procesamiento y análisis de la información y temperatura** | 398d | 2016-07-05 | 2018-01-11 |  | 92d |  |  |  |
| 845 | 2.2.2.2.2.1.1 | recepción, procesamiento y análisis de la información y temperatura 1 | 5d | 2016-07-05 | 2016-07-11 |  | 485d |  | start no earlier than 2016-07-05 |  |
| 846 | 2.2.2.2.2.1.2 | recepción, procesamiento y análisis de la información y temperatura 2 | 5d | 2016-08-05 | 2016-08-11 |  | 462d |  | start no earlier than 2016-08-05 |  |
| 847 | 2.2.2.2.2.1.3 | recepción, procesamiento y análisis de la información y temperatura 3 | 5d | 2016-09-05 | 2016-09-09 |  | 441d |  | start no earlier than 2016-09-05 |  |
| 848 | 2.2.2.2.2.1.4 | recepción, procesamiento y análisis de la información y temperatura 4 | 5d | 2016-10-05 | 2016-10-11 |  | 419d |  | start no earlier than 2016-10-05 |  |
| 849 | 2.2.2.2.2.1.5 | recepción, procesamiento y análisis de la información y temperatura 5 | 5d | 2016-11-07 | 2016-11-11 |  | 396d |  | start no earlier than 2016-11-05 |  |
| 850 | 2.2.2.2.2.1.6 | recepción, procesamiento y análisis de la información y temperatura 6 | 5d | 2016-12-05 | 2016-12-09 |  | 376d |  | start no earlier than 2016-12-05 |  |
| 851 | 2.2.2.2.2.1.7 | recepción, procesamiento y análisis de la información y temperatura 7 | 5d | 2017-01-05 | 2017-01-11 |  | 353d |  | start no earlier than 2017-01-05 |  |
| 852 | 2.2.2.2.2.1.8 | recepción, procesamiento y análisis de la información y temperatura 8 | 5d | 2017-02-06 | 2017-02-10 |  | 331d |  | start no earlier than 2017-02-05 |  |
| 853 | 2.2.2.2.2.1.9 | recepción, procesamiento y análisis de la información y temperatura 9 | 5d | 2017-03-06 | 2017-03-10 |  | 311d |  | start no earlier than 2017-03-05 |  |
| 854 | 2.2.2.2.2.1.10 | recepción, procesamiento y análisis de la información y temperatura 10 | 5d | 2017-04-05 | 2017-04-11 |  | 289d |  | start no earlier than 2017-04-05 |  |
| 855 | 2.2.2.2.2.1.11 | recepción, procesamiento y análisis de la información y temperatura 11 | 5d | 2017-05-05 | 2017-05-11 |  | 267d |  | start no earlier than 2017-05-05 |  |
| 856 | 2.2.2.2.2.1.12 | recepción, procesamiento y análisis de la información y temperatura 12 | 5d | 2017-06-05 | 2017-06-09 |  | 246d |  | start no earlier than 2017-06-05 |  |
| 857 | 2.2.2.2.2.1.13 | recepción, procesamiento y análisis de la información y temperatura 13 | 5d | 2017-07-05 | 2017-07-11 |  | 224d |  | start no earlier than 2017-07-05 |  |
| 858 | 2.2.2.2.2.1.14 | recepción, procesamiento y análisis de la información y temperatura 14 | 5d | 2017-08-07 | 2017-08-11 |  | 201d |  | start no earlier than 2017-08-05 |  |
| 859 | 2.2.2.2.2.1.15 | recepción, procesamiento y análisis de la información y temperatura 15 | 5d | 2017-09-05 | 2017-09-11 |  | 180d |  | start no earlier than 2017-09-05 |  |
| 860 | 2.2.2.2.2.1.16 | recepción, procesamiento y análisis de la información y temperatura 16 | 5d | 2017-10-05 | 2017-10-11 |  | 158d |  | start no earlier than 2017-10-05 |  |
| 861 | 2.2.2.2.2.1.17 | recepción, procesamiento y análisis de la información y temperatura 17 | 5d | 2017-11-06 | 2017-11-10 |  | 136d |  | start no earlier than 2017-11-05 |  |
| 862 | 2.2.2.2.2.1.18 | recepción, procesamiento y análisis de la información y temperatura 18 | 5d | 2017-12-05 | 2017-12-11 |  | 115d |  | start no earlier than 2017-12-05 |  |
| 863 | 2.2.2.2.2.1.19 | recepción, procesamiento y análisis de la información y temperatura 19 | 5d | 2018-01-05 | 2018-01-11 |  | 92d |  | start no earlier than 2018-01-05 |  |

| ID | WBS | Task | Duration | Start | Finish | Predecessors | Total slack | Constraint |
| --- | --- | --- | --- | --- | --- | --- | --- | --- |
| 864 | 2.2.2.3 | **Mantenimiento de la red de frío** | 500d | 2016-02-02 | 2018-01-01 |  | 100d |  |
| 865 | 2.2.2.3.1 | Plan Jurisdiccional de mantenimiento de la red de frío. | 40d | 2016-02-02 | 2016-03-28 | 1369 | 560d |  |
| 866 | 2.2.2.3.2 | **Monitoreo del mantenimiento preventivo y correctivo de la red** | 479d | 2016-02-05 | 2017-12-06 |  | 118d |  |
| 867 | 2.2.2.3.2.1 | Monitoreo del mantenimiento preventivo y correctivo de la red 2 | 2d | 2016-02-05 | 2016-02-08 |  | 595d | start no earlier than 2016-02-05 |
| 868 | 2.2.2.3.2.2 | Monitoreo del mantenimiento preventivo y correctivo de la red 3 | 2d | 2016-03-07 | 2016-03-08 |  | 574d | start no earlier than 2016-03-05 |
| 869 | 2.2.2.3.2.3 | Monitoreo del mantenimiento preventivo y correctivo de la red 4 | 2d | 2016-04-05 | 2016-04-06 |  | 553d | start no earlier than 2016-04-05 |
| 870 | 2.2.2.3.2.4 | Monitoreo del mantenimiento preventivo y correctivo de la red 5 | 2d | 2016-05-05 | 2016-05-06 |  | 531d | start no earlier than 2016-05-05 |
| 871 | 2.2.2.3.2.5 | Monitoreo del mantenimiento preventivo y correctivo de la red 6 | 2d | 2016-06-06 | 2016-06-07 |  | 509d | start no earlier than 2016-06-05 |
| 872 | 2.2.2.3.2.6 | Monitoreo del mantenimiento preventivo y correctivo de la red 7 | 2d | 2016-07-05 | 2016-07-06 |  | 488d | start no earlier than 2016-07-05 |
| 873 | 2.2.2.3.2.7 | Monitoreo del mantenimiento preventivo y correctivo de la red 8 | 2d | 2016-08-05 | 2016-08-08 |  | 465d | start no earlier than 2016-08-05 |
| 874 | 2.2.2.3.2.8 | Monitoreo del mantenimiento preventivo y correctivo de la red 9 | 2d | 2016-09-05 | 2016-09-06 |  | 444d | start no earlier than 2016-09-05 |
| 875 | 2.2.2.3.2.9 | Monitoreo del mantenimiento preventivo y correctivo de la red 10 | 2d | 2016-10-05 | 2016-10-06 |  | 422d | start no earlier than 2016-10-05 |
| 876 | 2.2.2.3.2.10 | Monitoreo del mantenimiento preventivo y correctivo de la red 11 | 2d | 2016-11-07 | 2016-11-08 |  | 399d | start no earlier than 2016-11-05 |
| 877 | 2.2.2.3.2.11 | Monitoreo del mantenimiento preventivo y correctivo de la red 12 | 2d | 2016-12-05 | 2016-12-06 |  | 379d | start no earlier than 2016-12-05 |
| 878 | 2.2.2.3.2.12 | Monitoreo del mantenimiento preventivo y correctivo de la red 13 | 2d | 2017-01-05 | 2017-01-06 |  | 356d | start no earlier than 2017-01-05 |
| 879 | 2.2.2.3.2.13 | Monitoreo del mantenimiento preventivo y correctivo de la red 14 | 2d | 2017-02-06 | 2017-02-07 |  | 334d | start no earlier than 2017-02-05 |
| 880 | 2.2.2.3.2.14 | Monitoreo del mantenimiento preventivo y correctivo de la red 15 | 2d | 2017-03-06 | 2017-03-07 |  | 314d | start no earlier than 2017-03-05 |
| 881 | 2.2.2.3.2.15 | Monitoreo del mantenimiento preventivo y correctivo de la red 16 | 2d | 2017-04-05 | 2017-04-06 |  | 292d | start no earlier than 2017-04-05 |
| 882 | 2.2.2.3.2.16 | Monitoreo del mantenimiento preventivo y correctivo de la red 17 | 2d | 2017-05-05 | 2017-05-08 |  | 270d | start no earlier than 2017-05-05 |
| 883 | 2.2.2.3.2.17 | Monitoreo del mantenimiento preventivo y correctivo de la red 18 | 2d | 2017-06-05 | 2017-06-06 |  | 249d | start no earlier than 2017-06-05 |
| 884 | 2.2.2.3.2.18 | Monitoreo del mantenimiento preventivo y correctivo de la red 19 | 2d | 2017-07-05 | 2017-07-06 |  | 227d | start no earlier than 2017-07-05 |
| 885 | 2.2.2.3.2.19 | Monitoreo del mantenimiento preventivo y correctivo de la red 20 | 2d | 2017-08-07 | 2017-08-08 |  | 204d | start no earlier than 2017-08-05 |
| 886 | 2.2.2.3.2.20 | Monitoreo del mantenimiento preventivo y correctivo de la red 21 | 2d | 2017-09-05 | 2017-09-06 |  | 183d | start no earlier than 2017-09-05 |
| 887 | 2.2.2.3.2.21 | Monitoreo del mantenimiento preventivo y correctivo de la red 22 | 2d | 2017-10-05 | 2017-10-06 |  | 161d | start no earlier than 2017-10-05 |
| 888 | 2.2.2.3.2.22 | Monitoreo del mantenimiento preventivo y correctivo de la red 23 | 2d | 2017-11-06 | 2017-11-07 |  | 139d | start no earlier than 2017-11-05 |
| 889 | 2.2.2.3.2.23 | Monitoreo del mantenimiento preventivo y correctivo de la red 24 | 2d | 2017-12-05 | 2017-12-06 |  | 118d | start no earlier than 2017-12-05 |

| ID | WBS | Task | Duration | Start | Finish | Predecessors | Total slack | Free slack | Constraint |
| --- | --- | --- | --- | --- | --- | --- | --- | --- | --- |
| 890 | 2.2.2.3.3 | **Mantenimiento correctivo de la red de frío** | 497d | 2016-02-05 | 2018-01-01 |  | 100d |  |  |
| 891 | 2.2.2.3.3.1 | **Mantenimiento correctivo de la red de frío** | 497d | 2016-02-05 | 2018-01-01 |  | 100d |  |  |
| 892 | 2.2.2.3.3.1.1 | Mantenimiento correctivo de la red de frío 2 | 10d | 2016-02-05 | 2016-02-18 |  | 587d |  | start no earlier than 2016-02-05 |
| 893 | 2.2.2.3.3.1.2 | Mantenimiento correctivo de la red de frío 3 | 10d | 2016-03-07 | 2016-03-18 |  | 566d |  | start no earlier than 2016-03-05 |
| 894 | 2.2.2.3.3.1.3 | Mantenimiento correctivo de la red de frío 4 | 10d | 2016-04-05 | 2016-04-18 |  | 545d |  | start no earlier than 2016-04-05 |
| 895 | 2.2.2.3.3.1.4 | Mantenimiento correctivo de la red de frío 5 | 10d | 2016-05-05 | 2016-05-18 |  | 523d |  | start no earlier than 2016-05-05 |
| 896 | 2.2.2.3.3.1.5 | Mantenimiento correctivo de la red de frío 6 | 10d | 2016-06-06 | 2016-06-17 |  | 501d |  | start no earlier than 2016-06-05 |
| 897 | 2.2.2.3.3.1.6 | Mantenimiento correctivo de la red de frío 7 | 10d | 2016-07-05 | 2016-07-18 |  | 480d |  | start no earlier than 2016-07-05 |
| 898 | 2.2.2.3.3.1.7 | Mantenimiento correctivo de la red de frío 8 | 10d | 2016-08-05 | 2016-08-18 |  | 457d |  | start no earlier than 2016-08-05 |
| 899 | 2.2.2.3.3.1.8 | Mantenimiento correctivo de la red de frío 9 | 10d | 2016-09-05 | 2016-09-16 |  | 436d |  | start no earlier than 2016-09-05 |
| 900 | 2.2.2.3.3.1.9 | Mantenimiento correctivo de la red de frío 10 | 10d | 2016-10-05 | 2016-10-18 |  | 414d |  | start no earlier than 2016-10-05 |
| 901 | 2.2.2.3.3.1.10 | Mantenimiento correctivo de la red de frío 11 | 10d | 2016-11-07 | 2016-11-18 |  | 391d |  | start no earlier than 2016-11-05 |
| 902 | 2.2.2.3.3.1.11 | Mantenimiento correctivo de la red de frío 12 | 10d | 2016-12-05 | 2016-12-16 |  | 371d |  | start no earlier than 2016-12-05 |
| 903 | 2.2.2.3.3.1.12 | Mantenimiento correctivo de la red de frío 13 | 10d | 2017-01-05 | 2017-01-18 |  | 348d |  | start no earlier than 2017-01-05 |
| 904 | 2.2.2.3.3.1.13 | Mantenimiento correctivo de la red de frío 14 | 10d | 2017-02-06 | 2017-02-17 |  | 326d |  | start no earlier than 2017-02-05 |
| 905 | 2.2.2.3.3.1.14 | Mantenimiento correctivo de la red de frío 15 | 10d | 2017-03-06 | 2017-03-17 |  | 306d |  | start no earlier than 2017-03-05 |
| 906 | 2.2.2.3.3.1.15 | Mantenimiento correctivo de la red de frío 16 | 10d | 2017-04-05 | 2017-04-18 |  | 284d |  | start no earlier than 2017-04-05 |
| 907 | 2.2.2.3.3.1.16 | Mantenimiento correctivo de la red de frío 17 | 10d | 2017-05-05 | 2017-05-18 |  | 262d |  | start no earlier than 2017-05-05 |
| 908 | 2.2.2.3.3.1.17 | Mantenimiento correctivo de la red de frío 18 | 10d | 2017-06-05 | 2017-06-16 |  | 241d |  | start no earlier than 2017-06-05 |
| 909 | 2.2.2.3.3.1.18 | Mantenimiento correctivo de la red de frío 19 | 10d | 2017-07-05 | 2017-07-18 |  | 219d |  | start no earlier than 2017-07-05 |
| 910 | 2.2.2.3.3.1.19 | Mantenimiento correctivo de la red de frío 20 | 10d | 2017-08-07 | 2017-08-18 |  | 196d |  | start no earlier than 2017-08-05 |
| 911 | 2.2.2.3.3.1.20 | Mantenimiento correctivo de la red de frío 21 | 10d | 2017-09-05 | 2017-09-18 |  | 175d |  | start no earlier than 2017-09-05 |
| 912 | 2.2.2.3.3.1.21 | Mantenimiento correctivo de la red de frío 22 | 10d | 2017-10-05 | 2017-10-18 |  | 153d |  | start no earlier than 2017-10-05 |
| 913 | 2.2.2.3.3.1.22 | Mantenimiento correctivo de la red de frío 23 | 10d | 2017-11-06 | 2017-11-17 |  | 131d |  | start no earlier than 2017-11-05 |
| 914 | 2.2.2.3.3.1.23 | Mantenimiento correctivo de la red de frío 24 | 10d | 2017-12-05 | 2017-12-18 |  | 100d | 0d | start no earlier than 2017-12-05 |
| 915 | 2.2.2.3.3.1.24 | Mantenimiento correctivo de la red de frío 1 | 10d | 2017-12-19 | 2018-01-01 | 914 | 100d |  | start no earlier than 2016-01-05 |

| ID | WBS | Task | Duration | Start | Finish | Predecessors | Total slack | Free slack |
| --- | --- | --- | --- | --- | --- | --- | --- | --- |
| 916 | 2.2.3 | **P3 100% de niños vacunados y registrados correctamente** | 490d | 2016-02-02 | 2017-12-18 |  | 110d |  |
| 917 | 2.2.3.1 | **Identificados los niños por localidad y estado vacunal** | 490d | 2016-02-02 | 2017-12-18 |  | 110d |  |
| 918 | 2.2.3.1.1 | Diseño del modelo de encuesta y de la selección probabilistica de las muestras | 20d | 2016-02-02 | 2016-02-29 | 1369 | 580d |  |
| 919 | 2.2.3.1.2 | **Encuesta rápida a Unidades de salud sobre censos de niños y su estado vacunal** | 430d | 2016-04-26 | 2017-12-18 | 1369 | 110d |  |
| 920 | 2.2.3.1.2.1 | Informe trimestral del monitoreo del censo nominal | 10d | 2016-04-26 | 2016-05-09 | 1369FS+60d | 110d | 0d |
| 921 | 2.2.3.1.2.2 | Informe trimestral del monitoreo del censo nominal | 10d | 2016-08-02 | 2016-08-15 | 920FS+60d | 110d | 0d |
| 922 | 2.2.3.1.2.3 | Informe trimestral del monitoreo del censo nominal | 10d | 2016-11-08 | 2016-11-21 | 921FS+60d | 110d | 0d |
| 923 | 2.2.3.1.2.4 | Informe trimestral del monitoreo del censo nominal | 10d | 2017-02-14 | 2017-02-27 | 922FS+60d | 110d | 0d |
| 924 | 2.2.3.1.2.5 | Informe trimestral del monitoreo del censo nominal | 10d | 2017-05-23 | 2017-06-05 | 923FS+60d | 110d | 0d |
| 925 | 2.2.3.1.2.6 | Informe trimestral del monitoreo del censo nominal | 10d | 2017-08-29 | 2017-09-11 | 924FS+60d | 110d | 0d |
| 926 | 2.2.3.1.2.7 | Informe trimestral del monitoreo del censo nominal | 10d | 2017-12-05 | 2017-12-18 | 925FS+60d | 110d |  |
| 927 | 2.2.3.2 | **Madres con cartilla de vacunación del niño con registro correcto y oportuno.** | 490d | 2016-02-02 | 2017-12-18 |  | 110d |  |
| 928 | 2.2.3.2.1 | Diseño del modelo de encuesta y de la selección probabilistica de las muestras | 20d | 2016-02-02 | 2016-02-29 | 1369 | 580d |  |
| 929 | 2.2.3.2.2 | **Encuesta a hogares sobre estado de la cartilla vacunal** | 430d | 2016-04-26 | 2017-12-18 |  | 110d |  |
| 930 | 2.2.3.2.2.1 | Informe trimestral del monitoreo de la cartilla vacunal a nivel del hogar | 10d | 2016-04-26 | 2016-05-09 | 1369FS+60d | 110d | 0d |
| 931 | 2.2.3.2.2.2 | Informe trimestral del monitoreo de la cartilla vacunal a nivel del hogar | 10d | 2016-08-02 | 2016-08-15 | 930FS+60d | 110d | 0d |
| 932 | 2.2.3.2.2.3 | Informe trimestral del monitoreo de la cartilla vacunal a nivel del hogar | 10d | 2016-11-08 | 2016-11-21 | 931FS+60d | 110d | 0d |
| 933 | 2.2.3.2.2.4 | Informe trimestral del monitoreo de la cartilla vacunal a nivel del hogar | 10d | 2017-02-14 | 2017-02-27 | 932FS+60d | 110d | 0d |
| 934 | 2.2.3.2.2.5 | Informe trimestral del monitoreo de la cartilla vacunal a nivel del hogar | 10d | 2017-05-23 | 2017-06-05 | 933FS+60d | 110d | 0d |
| 935 | 2.2.3.2.2.6 | Informe trimestral del monitoreo de la cartilla vacunal a nivel del hogar | 10d | 2017-08-29 | 2017-09-11 | 934FS+60d | 110d | 0d |
| 936 | 2.2.3.2.2.7 | Informe trimestral del monitoreo de la cartilla vacunal a nivel del hogar | 10d | 2017-12-05 | 2017-12-18 | 935FS+60d | 110d |  |
| 937 | 2.2.4 | **P4 360 personal permanente actualizado y 162 de personal nuevo ingreso capacitado en vacunación** | 80d | 2016-02-02 | 2016-05-23 |  | 520d |  |
| 938 | 2.2.4.1 | **100% del personal permanente responsable de aplicación de vacunas, actualizado en las normas de vacunación** | 80d | 2016-02-02 | 2016-05-23 |  | 520d |  |
| 939 | 2.2.4.1.1 | Elaborar la carta descriptiva para la capacitación | 10d | 2016-02-02 | 2016-02-15 | 1369 | 520d | 0d |
| 940 | 2.2.4.1.2 | Elaborar el calendario de capacitación para cada una de las jurisdicciones | 10d | 2016-02-16 | 2016-02-29 | 939 | 520d | 0d |
| 941 | 2.2.4.1.3 | Desarrollo de la capacitación | 60d | 2016-03-01 | 2016-05-23 | 940 | 520d |  |

| ID | WBS | Task | Duration | Start | Finish | Predecessors | Total slack | Free slack | Cost |
| --- | --- | --- | --- | --- | --- | --- | --- | --- | --- |
| 942 | 2.2.4.2 | **100% del personal de nuevo ingreso con responsabilidades en vacunación, capacitados en normas de vacunacion.** | 80d | 2016-02-02 | 2016-05-23 |  | 520d |  |  |
| 943 | 2.2.4.2.1 | Elaborar la carta descriptiva para la capacitación | 10d | 2016-02-02 | 2016-02-15 | 1369 | 520d | 0d |  |
| 944 | 2.2.4.2.2 | Elaborar el calendario de capacitación para cada una de las jurisdicciones | 10d | 2016-02-16 | 2016-02-29 | 943 | 520d | 0d |  |
| 945 | 2.2.4.2.3 | Desarrollo de la capacitación | 60d | 2016-03-01 | 2016-05-23 | 944 | 520d |  |  |
| 946 | 2.2.5 | **P5: 62,889 niños vacunados con esquema completo de acuerdo a la edad** | 600d | 2016-02-02 | 2018-05-21 |  | 0d |  |  |
| 947 | 2.2.5.1 | **Realizadas las 3 semanas nacionales de Salud y vacunación** | 520d | 2016-05-24 | 2018-05-21 |  | 0d |  |  |
| 948 | 2.2.5.1.1 | Monitoreo de la cobertura de vacunación de las semanas nacionales | 20d | 2016-05-24 | 2016-06-20 | 1369FS+80d | 0d |  |  |
| 949 | 2.2.5.1.2 | Monitoreo de la cobertura de vacunación de las semanas nacionales | 20d | 2016-10-11 | 2016-11-07 | 948FS+80d | 0d |  |  |
| 950 | 2.2.5.1.3 | Monitoreo de la cobertura de vacunación de las semanas nacionales | 20d | 2017-02-28 | 2017-03-27 | 949FS+80d | 0d |  |  |
| 951 | 2.2.5.1.4 | Monitoreo de la cobertura de vacunación de las semanas nacionales | 20d | 2017-07-18 | 2017-08-14 | 950FS+80d | 0d |  |  |
| 952 | 2.2.5.1.5 | Monitoreo de la cobertura de vacunación de las semanas nacionales | 20d | 2017-12-05 | 2018-01-01 | 951FS+80d | 0d |  |  |
| 953 | 2.2.5.1.6 | Monitoreo de la cobertura de vacunación de las semanas nacionales | 20d | 2018-04-24 | 2018-05-21 | 952FS+80d | 0d |  |  |
| 954 | 2.2.5.2 | **Realizacion de campañas especiales para abatir el rezago en áreas de dificil acceso y dispersas** | 450d | 2016-02-02 | 2017-10-23 |  | 150d |  |  |
| 955 | 2.2.5.2.1 | Identificación de los niños con rezago en vacuna SRP (meta) | 20d | 2016-02-02 | 2016-02-29 | 1369 | 150d | 0d |  |
| 956 | 2.2.5.2.2 | Identificar las areas con mayor rezago mediante encuestas rápidas de cobertura | 30d | 2016-03-01 | 2016-04-11 | 955 | 150d | 0d |  |
| 957 | 2.2.5.2.3 | Desarrollo de las campañas especiales de vacunación 2016 | 100d | 2016-04-12 | 2016-08-29 | 956 | 150d | 0d |  |
| 958 | 2.2.5.2.4 | Desarrollo de las campañas especiales de vacunación 2017 | 100d | 2017-06-06 | 2017-10-23 | 957FS+200d | 150d |  |  |
| 959 | 2.3 | Asistencia técnica en temas de vacunación e inmunología | 240d | 2016-02-02 | 2017-01-02 | 1369 | 360d |  | 50,000 |
| 960 | 3 | **3. Fortalecimiento de los sistemas de apoyo y estrategias transversales a la salud materno-infantil** | 530d | 2016-02-01 | 2018-02-09 |  | 0d |  | 589,584 |
| 961 | 3.1 | **P1 Diseno y operación de un sistema de abasto integrado en materia materna infantil** | 521d | 2016-02-01 | 2018-01-29 |  |  |  | 157,784 |
| 962 | 3.1.1 | **Implantación del modelo de identificación de necesidades según perfil epidemiológico (CONE)** | 200d | 2016-02-02 | 2016-11-07 |  | 320d |  | 50,000 |
| 963 | 3.1.1.1 | Talleres de capacitación e identificación de productos según demanda potencial por servicio | 60d | 2016-02-02 | 2016-04-25 | 1369 | 460d |  |  |
| 964 | 3.1.1.2 | Aval del area de Atención Médica y Salud Pública de los medicamentos según tipo de atención para 2016 | 40d | 2016-02-02 | 2016-03-28 | 1369 | 480d |  |  |
| 965 | 3.1.1.3 | Asistencia técnica para temas de abasto | 200d | 2016-02-02 | 2016-11-07 | 1369 | 320d |  | 50,000 |

| ID | WBS | Task | Duration | Start | Finish | Predecessors | Total slack | Free slack | Constraint | Cost |
| --- | --- | --- | --- | --- | --- | --- | --- | --- | --- | --- |
| 966 | 3.1.2 | **Mejora del abastecimiento y distribución (almacenes juridisccionales y hospitales)** | 521d | 2016-02-01 | 2018-01-29 |  | 0d |  |  | 107,784 |
| 967 | 3.1.2.1 | Contratación de consultores en formación de RRHH de abasto y en apoyo a la gestión de adquisiciones | 20d | 2016-02-02 | 2016-02-29 | 1369 | 500d |  |  |  |
| 968 | 3.1.2.2 | **Servicios de apoyo al sistema de abasto** | 519d | 2016-02-01 | 2018-01-25 |  | 2d |  |  | 107,784 |
| 969 | 3.1.2.2.1 | Servicios de apoyo al sistema de abasto 2 | 1mo | 2016-02-01 | 2016-02-26 |  | 501d |  | start no earlier than 2016-02-01 | 4,491 |
| 970 | 3.1.2.2.2 | Servicios de apoyo al sistema de abasto 3 | 1mo | 2016-03-01 | 2016-03-28 |  | 480d |  | start no earlier than 2016-03-01 | 4,491 |
| 971 | 3.1.2.2.3 | Servicios de apoyo al sistema de abasto 4 | 1mo | 2016-04-01 | 2016-04-28 |  | 457d |  | start no earlier than 2016-04-01 | 4,491 |
| 972 | 3.1.2.2.4 | Servicios de apoyo al sistema de abasto 5 | 1mo | 2016-05-02 | 2016-05-27 |  | 436d |  | start no earlier than 2016-05-01 | 4,491 |
| 973 | 3.1.2.2.5 | Servicios de apoyo al sistema de abasto 6 | 1mo | 2016-06-01 | 2016-06-28 |  | 414d |  | start no earlier than 2016-06-01 | 4,491 |
| 974 | 3.1.2.2.6 | Servicios de apoyo al sistema de abasto 7 | 1mo | 2016-07-01 | 2016-07-28 |  | 392d |  | start no earlier than 2016-07-01 | 4,491 |
| 975 | 3.1.2.2.7 | Servicios de apoyo al sistema de abasto 8 | 1mo | 2016-08-01 | 2016-08-26 |  | 371d |  | start no earlier than 2016-08-01 | 4,491 |
| 976 | 3.1.2.2.8 | Servicios de apoyo al sistema de abasto 9 | 1mo | 2016-09-01 | 2016-09-28 |  | 348d |  | start no earlier than 2016-09-01 | 4,491 |
| 977 | 3.1.2.2.9 | Servicios de apoyo al sistema de abasto 10 | 1mo | 2016-10-03 | 2016-10-28 |  | 326d |  | start no earlier than 2016-10-01 | 4,491 |
| 978 | 3.1.2.2.10 | Servicios de apoyo al sistema de abasto 11 | 1mo | 2016-11-01 | 2016-11-28 |  | 305d |  | start no earlier than 2016-11-01 | 4,491 |
| 979 | 3.1.2.2.11 | Servicios de apoyo al sistema de abasto 12 | 1mo | 2016-12-01 | 2016-12-28 |  | 283d |  | start no earlier than 2016-12-01 | 4,491 |
| 980 | 3.1.2.2.12 | Servicios de apoyo al sistema de abasto 13 | 1mo | 2017-01-02 | 2017-01-27 |  | 261d |  | start no earlier than 2017-01-01 | 4,491 |
| 981 | 3.1.2.2.13 | Servicios de apoyo al sistema de abasto 14 | 1mo | 2017-02-01 | 2017-02-28 |  | 239d |  | start no earlier than 2017-02-01 | 4,491 |
| 982 | 3.1.2.2.14 | Servicios de apoyo al sistema de abasto 15 | 1mo | 2017-03-01 | 2017-03-28 |  | 219d |  | start no earlier than 2017-03-01 | 4,491 |
| 983 | 3.1.2.2.15 | Servicios de apoyo al sistema de abasto 16 | 1mo | 2017-04-03 | 2017-04-28 |  | 196d |  | start no earlier than 2017-04-01 | 4,491 |
| 984 | 3.1.2.2.16 | Servicios de apoyo al sistema de abasto 17 | 1mo | 2017-05-01 | 2017-05-26 |  | 176d |  | start no earlier than 2017-05-01 | 4,491 |
| 985 | 3.1.2.2.17 | Servicios de apoyo al sistema de abasto 18 | 1mo | 2017-06-01 | 2017-06-28 |  | 153d |  | start no earlier than 2017-06-01 | 4,491 |
| 986 | 3.1.2.2.18 | Servicios de apoyo al sistema de abasto 19 | 1mo | 2017-07-03 | 2017-07-28 |  | 131d |  | start no earlier than 2017-07-01 | 4,491 |
| 987 | 3.1.2.2.19 | Servicios de apoyo al sistema de abasto 20 | 1mo | 2017-08-01 | 2017-08-28 |  | 110d |  | start no earlier than 2017-08-01 | 4,491 |
| 988 | 3.1.2.2.20 | Servicios de apoyo al sistema de abasto 21 | 1mo | 2017-09-01 | 2017-09-28 |  | 87d |  | start no earlier than 2017-09-01 | 4,491 |
| 989 | 3.1.2.2.21 | Servicios de apoyo al sistema de abasto 22 | 1mo | 2017-10-02 | 2017-10-27 |  | 66d |  | start no earlier than 2017-10-01 | 4,491 |
| 990 | 3.1.2.2.22 | Servicios de apoyo al sistema de abasto 23 | 1mo | 2017-11-01 | 2017-11-28 |  | 44d |  | start no earlier than 2017-11-01 | 4,491 |
| 991 | 3.1.2.2.23 | Servicios de apoyo al sistema de abasto 24 | 1mo | 2017-12-01 | 2017-12-28 |  | 2d | 0d | start no earlier than 2017-12-01 | 4,491 |
| 992 | 3.1.2.2.24 | Servicios de apoyo al sistema de abasto 1 | 1mo | 2017-12-29 | 2018-01-25 | 991 | 2d |  | start no earlier than 2016-01-01 | 4,491 |

| ID | WBS | Task | Duration | Start | Finish | Predecessors | Total slack | Free slack | Cost |
| --- | --- | --- | --- | --- | --- | --- | --- | --- | --- |
| 993 | 3.1.2.3 | **mejoras al equipamiento básico de almacenes** | 105d | 2016-02-02 | 2016-06-27 |  | 415d |  |  |
| 994 | 3.1.2.3.1 | Identificación de necesidades | 15d | 2016-02-02 | 2016-02-22 | 1369 | 415d | 0d |  |
| 995 | 3.1.2.3.2 | Especificaciones técnicas | 10d | 2016-02-23 | 2016-03-07 | 994 | 415d | 0d |  |
| 996 | 3.1.2.3.3 | Selección del proveedor | 40d | 2016-03-08 | 2016-05-02 | 995 | 415d | 0d |  |
| 997 | 3.1.2.3.4 | Recepción y distribución de los equipos | 40d | 2016-05-03 | 2016-06-27 | 996 | 415d |  |  |
| 998 | 3.1.2.4 | **Equipos para el manejo de la herramienta informática y los datos** | 105d | 2016-03-29 | 2016-08-22 |  | 375d |  |  |
| 999 | 3.1.2.4.1 | Identificación de necesidades | 15d | 2016-03-29 | 2016-04-18 | 1369FS+40d | 375d | 0d |  |
| 1000 | 3.1.2.4.2 | Especificaciones técnicas | 20d | 2016-04-19 | 2016-05-16 | 999 | 375d | 0d |  |
| 1001 | 3.1.2.4.3 | Selección del proveedor | 40d | 2016-05-17 | 2016-07-11 | 1000 | 375d | 0d |  |
| 1002 | 3.1.2.4.4 | Recepción y distribución de los equipos | 30d | 2016-07-12 | 2016-08-22 | 1001 | 375d |  |  |
| 1003 | 3.1.2.5 | **Aseguramiento de la calidad de los insumos** | 460d | 2016-04-26 | 2018-01-29 |  | 0d |  |  |
| 1004 | 3.1.2.5.1 | Monitoreo de los elementos de calidad en los almacenes | 5d | 2016-04-26 | 2016-05-02 | 1369FS+60d | 0d |  |  |
| 1005 | 3.1.2.5.2 | Monitoreo de los elementos de calidad en los almacenes | 5d | 2016-07-26 | 2016-08-01 | 1004FS+60d | 0d |  |  |
| 1006 | 3.1.2.5.3 | Monitoreo de los elementos de calidad en los almacenes | 5d | 2016-10-25 | 2016-10-31 | 1005FS+60d | 0d |  |  |
| 1007 | 3.1.2.5.4 | Monitoreo de los elementos de calidad en los almacenes | 5d | 2017-01-24 | 2017-01-30 | 1006FS+60d | 0d |  |  |
| 1008 | 3.1.2.5.5 | Monitoreo de los elementos de calidad en los almacenes | 5d | 2017-04-25 | 2017-05-01 | 1007FS+60d | 0d |  |  |
| 1009 | 3.1.2.5.6 | Monitoreo de los elementos de calidad en los almacenes | 5d | 2017-07-25 | 2017-07-31 | 1008FS+60d | 0d |  |  |
| 1010 | 3.1.2.5.7 | Monitoreo de los elementos de calidad en los almacenes | 5d | 2017-10-24 | 2017-10-30 | 1009FS+60d | 0d |  |  |
| 1011 | 3.1.2.5.8 | Monitoreo de los elementos de calidad en los almacenes | 5d | 2018-01-23 | 2018-01-29 | 1010FS+60d | 0d |  |  |
| 1012 | 3.1.2.6 | Talleres de gestión logística | 120d | 2016-02-02 | 2016-07-18 | 1369 | 400d |  |  |
| 1013 | 3.2 | **P2: Estrategia de aseguramiento de la calidad funcionando** | 480d | 2016-02-02 | 2017-12-04 |  | 125d |  | 231,000 |
| 1014 | 3.2.1 | **Desarrollo y puesta en funcionamiento de las unidades de gestión de calidad a nivel estatal, jurisdiccionales y hospitales** | 480d | 2016-02-02 | 2017-12-04 |  | 125d |  | 180,000 |
| 1015 | 3.2.1.1 | Identificados los RH que conformaran las unidades | 5d | 2016-02-02 | 2016-02-08 | 1369 | 590d | 0d |  |
| 1016 | 3.2.1.2 | Definida la infraestructura y equipadas las unidades | 10d | 2016-02-09 | 2016-02-22 | 1015 | 590d |  |  |
| 1017 | 3.2.1.3 | Acompanamiento técnico a las unidades de calidad formadas (Coaching) 2do año. | 240d | 2016-02-02 | 2017-01-02 | 1369 | 125d | 0d |  |
| 1018 | 3.2.1.4 | Acompañamiento técnicos con capacidades locales | 240d | 2017-01-03 | 2017-12-04 | 1017 | 125d |  |  |
| 1019 | 3.2.1.5 | Acompañamiento a las unidades de gestión de calidad locales | 240d | 2016-02-02 | 2017-01-02 | 1369 | 125d | 0d |  |
| 1020 | 3.2.1.6 | Asistencia técnica para el acompañamiento técnico | 240d | 2017-01-03 | 2017-12-04 | 1019 | 125d |  | 180,000 |

| ID | WBS | Task | Duration | Start | Finish | Predecessors | Total slack | Free slack | Cost |
| --- | --- | --- | --- | --- | --- | --- | --- | --- | --- |
| 1021 | 3.2.2 | **Fortalecimiento de 4 comités jurisdiccionales y 4 comités en Hospitales** | 120d | 2016-02-02 | 2016-07-18 |  | 485d |  |  |
| 1022 | 3.2.2.1 | Reactivados y fortalecidos los comités jurisdiccionales | 120d | 2016-02-02 | 2016-07-18 | 1369 | 485d |  |  |
| 1023 | 3.2.2.2 | Reactivados y fortalecidos los comités hospitalarios | 120d | 2016-02-02 | 2016-07-18 | 1369 | 485d |  |  |
| 1024 | 3.2.3 | **25 equipos zonales capacitados y desarrollando las actividades de aseguramiento de la calidad** | 480d | 2016-02-02 | 2017-12-04 |  | 125d |  | 11,000 |
| 1025 | 3.2.3.1 | **Equipados y con los insumos necesarios para hacer la medición de la calidad** | 95d | 2016-02-02 | 2016-06-13 |  | 510d |  | 11,000 |
| 1026 | 3.2.3.1.1 | Identificación de necesidades | 15d | 2016-02-02 | 2016-02-22 | 1369 | 510d | 0d |  |
| 1027 | 3.2.3.1.2 | Especificaciones técnicas | 10d | 2016-02-23 | 2016-03-07 | 1026 | 510d | 0d |  |
| 1028 | 3.2.3.1.3 | selección del proveedor | 30d | 2016-03-08 | 2016-04-18 | 1027 | 510d | 0d |  |
| 1029 | 3.2.3.1.4 | recepción de los equipos | 40d | 2016-04-19 | 2016-06-13 | 1028 | 510d |  | 11,000 |
| 1030 | 3.2.3.2 | Actualización de conocimientos a los equipos zonales y de calidad con respecto a las estrategias de trabajo | 240d | 2016-02-02 | 2017-01-02 | 1369 | 365d |  |  |
| 1031 | 3.2.3.3 | Realizadas las visitas de seguimiento a los servicios de salud | 480d | 2016-02-02 | 2017-12-04 | 1369 | 125d |  |  |
| 1032 | 3.2.3.4 | Elaborados y entregados los informes de aseguramiento de la calidad de las visitas de seguimiento | 480d | 2016-02-02 | 2017-12-04 | 1369 | 125d |  |  |
| 1033 | 3.2.4 | **255 equipos de mejora continua en las unidades de salud** | 240d | 2016-02-02 | 2017-01-02 |  | 365d |  | 40,000 |
| 1034 | 3.2.4.1 | **Equipados y con los insumos necesarios para hacer la medición de la calidad** | 95d | 2016-02-02 | 2016-06-13 |  | 510d |  | 40,000 |
| 1035 | 3.2.4.1.1 | Identificación de necesidades | 15d | 2016-02-02 | 2016-02-22 | 1369 | 510d | 0d |  |
| 1036 | 3.2.4.1.2 | Especificaciones técnicas | 10d | 2016-02-23 | 2016-03-07 | 1035 | 510d | 0d |  |
| 1037 | 3.2.4.1.3 | selección del proveedor | 30d | 2016-03-08 | 2016-04-18 | 1036 | 510d | 0d |  |
| 1038 | 3.2.4.1.4 | recepción de los equipos | 40d | 2016-04-19 | 2016-06-13 | 1037 | 510d |  | 40,000 |
| 1039 | 3.2.4.2 | Desarrolladas las mediciones mensuales y definición de las acciones de mejora | 240d | 2016-02-02 | 2017-01-02 | 1369 | 365d |  |  |
| 1040 | 3.2.5 | **Adquisición de equipos para almacenamiento y seguridad de datos** | 115d | 2016-02-02 | 2016-07-11 |  | 490d |  |  |
| 1041 | 3.2.5.1 | Identificación de necesidades | 15d | 2016-02-02 | 2016-02-22 | 1369 | 490d | 0d |  |
| 1042 | 3.2.5.2 | Selección del proveedor | 40d | 2016-02-23 | 2016-04-18 | 1041 | 490d | 0d |  |
| 1043 | 3.2.5.3 | Recepción de equipos para almacenamiento y seguridad de de datos | 60d | 2016-04-19 | 2016-07-11 | 1042 | 490d |  |  |
| 1044 | 3.3 | **P3: Desarrollos informáticos para gestión de calidad, gestión logística, y monitoreo de la red de frio** | 523d | 2016-02-01 | 2018-01-31 |  |  |  | 200,800 |
| 1045 | 3.3.1 | **Conformación del equipo de profesionales** | 523d | 2016-02-01 | 2018-01-31 |  | 0d |  | 106,800 |
| 1046 | 3.3.1.1 | Identificación de necesidades | 15d | 2016-02-02 | 2016-02-22 | 1369 | 502d | 0d |  |
| 1047 | 3.3.1.2 | Terminos de referencia | 5d | 2016-02-23 | 2016-02-29 | 1046 | 502d |  |  |

| ID | WBS | Task | Duration | Start | Finish | Predecessors | Total slack | Free slack | Constraint | Cost |
| --- | --- | --- | --- | --- | --- | --- | --- | --- | --- | --- |
| 1048 | 3.3.1.3 | **Selección de los técnicos** | 523d | 2016-02-01 | 2018-01-31 |  | 0d |  |  | 106,800 |
| 1049 | 3.3.1.3.1 | Contratación coordinador de desarrollo informático | 5d | 2016-02-02 | 2016-02-08 | 1369 | 360d | 0d |  |  |
| 1050 | 3.3.1.3.2 | **Acciones de coordinación para el desarrollo informático** | 523d | 2016-02-01 | 2018-01-31 |  |  |  |  | 106,800 |
| 1051 | 3.3.1.3.2.1 | Acciones de coordinación para el desarrollo informático 2 | 22d | 2016-02-01 | 2016-03-01 |  | 584d |  | start no earlier than 2016-02-01 | 4,450 |
| 1052 | 3.3.1.3.2.2 | Acciones de coordinación para el desarrollo informático 3 | 22d | 2016-03-01 | 2016-03-30 |  | 563d |  | start no earlier than 2016-03-01 | 4,450 |
| 1053 | 3.3.1.3.2.3 | Acciones de coordinación para el desarrollo informático 4 | 22d | 2016-04-01 | 2016-05-02 |  | 540d |  | start no earlier than 2016-04-01 | 4,450 |
| 1054 | 3.3.1.3.2.4 | Acciones de coordinación para el desarrollo informático 5 | 22d | 2016-05-02 | 2016-05-31 |  | 519d |  | start no earlier than 2016-05-01 | 4,450 |
| 1055 | 3.3.1.3.2.5 | Acciones de coordinación para el desarrollo informático 6 | 22d | 2016-06-01 | 2016-06-30 |  | 497d |  | start no earlier than 2016-06-01 | 4,450 |
| 1056 | 3.3.1.3.2.6 | Acciones de coordinación para el desarrollo informático 7 | 22d | 2016-07-01 | 2016-08-01 |  | 475d |  | start no earlier than 2016-07-01 | 4,450 |
| 1057 | 3.3.1.3.2.7 | Acciones de coordinación para el desarrollo informático 8 | 22d | 2016-08-01 | 2016-08-30 |  | 454d |  | start no earlier than 2016-08-01 | 4,450 |
| 1058 | 3.3.1.3.2.8 | Acciones de coordinación para el desarrollo informático 9 | 22d | 2016-09-01 | 2016-09-30 |  | 431d |  | start no earlier than 2016-09-01 | 4,450 |
| 1059 | 3.3.1.3.2.9 | Acciones de coordinación para el desarrollo informático 10 | 22d | 2016-10-03 | 2016-11-01 |  | 409d |  | start no earlier than 2016-10-01 | 4,450 |
| 1060 | 3.3.1.3.2.10 | Acciones de coordinación para el desarrollo informático 11 | 22d | 2016-11-01 | 2016-11-30 |  | 388d |  | start no earlier than 2016-11-01 | 4,450 |
| 1061 | 3.3.1.3.2.11 | Acciones de coordinación para el desarrollo informático 12 | 22d | 2016-12-01 | 2016-12-30 |  | 366d |  | start no earlier than 2016-12-01 | 4,450 |
| 1062 | 3.3.1.3.2.12 | Acciones de coordinación para el desarrollo informático 13 | 22d | 2017-01-02 | 2017-01-31 |  | 344d |  | start no earlier than 2017-01-01 | 4,450 |
| 1063 | 3.3.1.3.2.13 | Acciones de coordinación para el desarrollo informático 14 | 22d | 2017-02-01 | 2017-03-02 |  | 322d |  | start no earlier than 2017-02-01 | 4,450 |
| 1064 | 3.3.1.3.2.14 | Acciones de coordinación para el desarrollo informático 15 | 22d | 2017-03-01 | 2017-03-30 |  | 302d |  | start no earlier than 2017-03-01 | 4,450 |
| 1065 | 3.3.1.3.2.15 | Acciones de coordinación para el desarrollo informático 16 | 22d | 2017-04-03 | 2017-05-02 |  | 279d |  | start no earlier than 2017-04-01 | 4,450 |
| 1066 | 3.3.1.3.2.16 | Acciones de coordinación para el desarrollo informático 17 | 22d | 2017-05-01 | 2017-05-30 |  | 259d |  | start no earlier than 2017-05-01 | 4,450 |
| 1067 | 3.3.1.3.2.17 | Acciones de coordinación para el desarrollo informático 18 | 22d | 2017-06-01 | 2017-06-30 |  | 236d |  | start no earlier than 2017-06-01 | 4,450 |
| 1068 | 3.3.1.3.2.18 | Acciones de coordinación para el desarrollo informático 19 | 22d | 2017-07-03 | 2017-08-01 |  | 214d |  | start no earlier than 2017-07-01 | 4,450 |
| 1069 | 3.3.1.3.2.19 | Acciones de coordinación para el desarrollo informático 20 | 22d | 2017-08-01 | 2017-08-30 |  | 193d |  | start no earlier than 2017-08-01 | 4,450 |
| 1070 | 3.3.1.3.2.20 | Acciones de coordinación para el desarrollo informático 21 | 22d | 2017-09-01 | 2017-10-02 |  | 170d |  | start no earlier than 2017-09-01 | 4,450 |
| 1071 | 3.3.1.3.2.21 | Acciones de coordinación para el desarrollo informático 22 | 22d | 2017-10-02 | 2017-10-31 |  | 149d |  | start no earlier than 2017-10-01 | 4,450 |
| 1072 | 3.3.1.3.2.22 | Acciones de coordinación para el desarrollo informático 23 | 22d | 2017-11-01 | 2017-11-30 |  | 127d |  | start no earlier than 2017-11-01 | 4,450 |
| 1073 | 3.3.1.3.2.23 | Acciones de coordinación para el desarrollo informático 24 | 22d | 2017-12-01 | 2018-01-01 |  | 83d | 0d | start no earlier than 2017-12-01 | 4,450 |
| 1074 | 3.3.1.3.2.24 | Acciones de coordinación para el desarrollo informático 1 | 22d | 2018-01-02 | 2018-01-31 | 1073 | 83d |  | start no earlier than 2016-01-01 | 4,450 |
| 1075 | 3.3.1.4 | Contratación de consultores informáticos | 20d | 2016-02-02 | 2016-02-29 | 1369 | 502d |  |  |  |

| ID | WBS | Task | Duration | Start | Finish | Predecessors | Total slack | Free slack | Cost |
| --- | --- | --- | --- | --- | --- | --- | --- | --- | --- |
| 1076 | 3.3.2 | **Desarrollo de software de gestión para la gestión logística (SIAL 2.0)** | 270d | 2016-02-02 | 2017-02-13 |  | 252d |  | 40,000 |
| 1077 | 3.3.2.1 | Diseño del plan de negocios | 20d | 2016-02-02 | 2016-02-29 | 1369 | 252d | 0d |  |
| 1078 | 3.3.2.2 | Adaptación de las reglamentación de gestión y control vinculada a activos | 50d | 2016-03-01 | 2016-05-09 | 1077 | 452d |  |  |
| 1079 | 3.3.2.3 | Desarrollo de la herramienta informática | 180d | 2016-03-01 | 2016-11-07 | 1077 | 252d | 0d | 40,000 |
| 1080 | 3.3.2.4 | Migración de los datos actuales | 20d | 2016-10-11 | 2016-11-07 | 1079FS-20d | 252d | 0d |  |
| 1081 | 3.3.2.5 | Construcción de las bases de datos relacionadas | 30d | 2016-09-27 | 2016-11-07 | 1080FS-30d | 252d | 0d |  |
| 1082 | 3.3.2.6 | pruebas y puesta en aplicación | 20d | 2016-11-08 | 2016-12-05 | 1081 | 252d | 0d |  |
| 1083 | 3.3.2.7 | capacitación al personal | 50d | 2016-12-06 | 2017-02-13 | 1082 | 252d |  |  |
| 1084 | 3.3.3 | **Diseño y validación del SUGUS** | 370d | 2016-02-02 | 2017-07-03 |  | 152d |  | 36,000 |
| 1085 | 3.3.3.1 | Conceptualización, diseño del software del modelo de comunicación | 10d | 2016-02-02 | 2016-02-15 | 1369 | 152d | 0d |  |
| 1086 | 3.3.3.2 | Desarrollo del SUGUS (sistema único de gestión de usuarios) | 180d | 2016-02-16 | 2016-10-24 | 1085 | 152d | 0d | 36,000 |
| 1087 | 3.3.3.3 | Implementación del modelo | 180d | 2016-10-25 | 2017-07-03 | 1086 | 152d |  |  |
| 1088 | 3.3.4 | **Desarrollo de la herramienta informática de monitoreo de la red de frío** | 310d | 2016-02-02 | 2017-04-10 |  | 212d |  |  |
| 1089 | 3.3.4.1 | Conceptualización, diseño del software del modelo de comunicación | 10d | 2016-02-02 | 2016-02-15 | 1369 | 212d | 0d |  |
| 1090 | 3.3.4.2 | Desarrollo de la herramienta para el monitoreo de la red de frío | 180d | 2016-02-16 | 2016-10-24 | 1089 | 212d | 0d |  |
| 1091 | 3.3.4.3 | Implementación del modelo | 180d | 2016-08-02 | 2017-04-10 | 1090FS-60d | 212d |  |  |
| 1092 | 3.3.5 | **Ampliación mejoras del tablero de control, CIUM y tablero de gestión de calidad** | 240d | 2016-02-02 | 2017-01-02 |  | 282d |  | 18,000 |
| 1093 | 3.3.5.1 | Plan de negocios | 20d | 2016-02-02 | 2016-02-29 | 1369 | 282d | 0d |  |
| 1094 | 3.3.5.2 | Desarrollo de la Herramienta | 120d | 2016-03-01 | 2016-08-15 | 1093 | 282d | 0d | 18,000 |
| 1095 | 3.3.5.3 | Pruebas e implantación | 40d | 2016-08-16 | 2016-10-10 | 1094 | 282d | 0d |  |
| 1096 | 3.3.5.4 | Capacitación en la aplicación de la herramienta | 60d | 2016-10-11 | 2017-01-02 | 1095 | 282d |  |  |
| 1097 | 3.4 | **P4: Estrategia de comunicación** | 240d | 2016-02-02 | 2017-01-02 |  | 365d |  |  |
| 1098 | 3.4.1 | **Estrategia socializada en todos los niveles del ISECH** | 240d | 2016-02-02 | 2017-01-02 |  | 365d |  |  |
| 1099 | 3.4.1.1 | Reuniones de coordinación con el nivel Federal | 240d | 2016-02-02 | 2017-01-02 | 1369 | 365d |  |  |
| 1100 | 3.4.1.2 | Reuniones de coordinación con el nivel estatal | 240d | 2016-02-02 | 2017-01-02 | 1369 | 365d |  |  |
| 1101 | 3.4.1.3 | Reuniones de coordinación con el nivel jurisdiccional | 240d | 2016-02-02 | 2017-01-02 | 1369 | 365d |  |  |
| 1102 | 3.4.1.4 | Elementos comunicaciones de la estrategia | 240d | 2016-02-02 | 2017-01-02 | 1369 | 365d |  |  |

| ID | WBS | Task | Duration | Start | Finish | Predecessors | Total slack | Constraint |
| --- | --- | --- | --- | --- | --- | --- | --- | --- |
| 1103 | 3.4.2 | **Seguimiento a la ejecución de la estrategia** | 200d | 2016-02-02 | 2016-11-07 |  | 405d |  |
| 1104 | 3.4.2.1 | Visitas de campo para seguimiento de ejecución de la estrategia a nivel Jurisdiccional | 200d | 2016-02-02 | 2016-11-07 | 1369 | 405d |  |
| 1105 | 3.4.2.2 | Visitas de campo para seguimiento de ejecución de la estrategia a nivel Estatal | 200d | 2016-02-02 | 2016-11-07 | 1369 | 405d |  |
| 1106 | 3.5 | **P5: Estrategia gerencial funcionando** | 260d | 2016-02-01 | 2017-01-27 |  |  |  |
| 1107 | 3.5.1 | **Tablero de control funcionando adecuadamente** | 241d | 2016-02-01 | 2017-01-02 |  | 19d |  |
| 1108 | 3.5.1.1 | Desarrollo informáticos adicionales | 120d | 2016-02-02 | 2016-07-18 | 1369 | 139d |  |
| 1109 | 3.5.1.2 | **Visitas de apoyo para desarrollo de competencias en el uso de herramientas a nivel de todo el ISECH** | 225d | 2016-02-01 | 2016-12-09 |  | 35d |  |
| 1110 | 3.5.1.2.1 | talleres inductivos para el uso de la herramienta | 40d | 2016-02-02 | 2016-03-28 | 1369 | 219d |  |
| 1111 | 3.5.1.2.2 | Guía para el desarrollo de competencias | 20d | 2016-02-02 | 2016-02-29 | 1369 | 239d |  |
| 1112 | 3.5.1.2.3 | **visitas de acompañamiento en el uso del tablero** | 225d | 2016-02-01 | 2016-12-09 |  | 35d |  |
| 1113 | 3.5.1.2.3.1 | visitas de acompañamiento en el uso del tablero 1 | 5d | 2016-02-01 | 2016-02-05 |  | 255d | start no earlier than 2016-01-05 |
| 1114 | 3.5.1.2.3.2 | visitas de acompañamiento en el uso del tablero 2 | 5d | 2016-02-05 | 2016-02-11 |  | 251d | start no earlier than 2016-02-05 |
| 1115 | 3.5.1.2.3.3 | visitas de acompañamiento en el uso del tablero 3 | 5d | 2016-03-07 | 2016-03-11 |  | 230d | start no earlier than 2016-03-05 |
| 1116 | 3.5.1.2.3.4 | visitas de acompañamiento en el uso del tablero 4 | 5d | 2016-04-05 | 2016-04-11 |  | 209d | start no earlier than 2016-04-05 |
| 1117 | 3.5.1.2.3.5 | visitas de acompañamiento en el uso del tablero 5 | 5d | 2016-05-05 | 2016-05-11 |  | 187d | start no earlier than 2016-05-05 |
| 1118 | 3.5.1.2.3.6 | visitas de acompañamiento en el uso del tablero 6 | 5d | 2016-06-06 | 2016-06-10 |  | 165d | start no earlier than 2016-06-05 |
| 1119 | 3.5.1.2.3.7 | visitas de acompañamiento en el uso del tablero 7 | 5d | 2016-07-05 | 2016-07-11 |  | 144d | start no earlier than 2016-07-05 |
| 1120 | 3.5.1.2.3.8 | visitas de acompañamiento en el uso del tablero 8 | 5d | 2016-08-05 | 2016-08-11 |  | 121d | start no earlier than 2016-08-05 |
| 1121 | 3.5.1.2.3.9 | visitas de acompañamiento en el uso del tablero 9 | 5d | 2016-09-05 | 2016-09-09 |  | 100d | start no earlier than 2016-09-05 |
| 1122 | 3.5.1.2.3.10 | visitas de acompañamiento en el uso del tablero 10 | 5d | 2016-10-05 | 2016-10-11 |  | 78d | start no earlier than 2016-10-05 |
| 1123 | 3.5.1.2.3.11 | visitas de acompañamiento en el uso del tablero 11 | 5d | 2016-11-07 | 2016-11-11 |  | 55d | start no earlier than 2016-11-05 |
| 1124 | 3.5.1.2.3.12 | visitas de acompañamiento en el uso del tablero 12 | 5d | 2016-12-05 | 2016-12-09 |  | 35d | start no earlier than 2016-12-05 |
| 1125 | 3.5.1.3 | Incorporación sistemática de nuevos indicadores | 240d | 2016-02-02 | 2017-01-02 | 1369 | 19d |  |
| 1126 | 3.5.2 | **Puesta en marcha de la estrategia gerencial** | 240d | 2016-02-02 | 2017-01-02 |  | 19d |  |
| 1127 | 3.5.2.1 | Análisis de resultados para la gestión estratégica de las salud a nivel estatal | 240d | 2016-02-02 | 2017-01-02 | 1369 | 19d |  |
| 1128 | 3.5.2.2 | Análisis de resultados para la gestión estratégica de las salud a nivel Jurisdiccional | 240d | 2016-02-02 | 2017-01-02 | 1369 | 19d |  |
| 1129 | 3.5.2.3 | Análisis de resultados para la gestión estratégica de las salud a nivel hospitales | 240d | 2016-02-02 | 2017-01-02 | 1369 | 19d |  |
| 1130 | 3.5.2.4 | Análisis de resultados para la gestión estratégica de las salud a nivel de Meso red | 240d | 2016-02-02 | 2017-01-02 | 1369 | 19d |  |

| ID | WBS | Task | Type | Duration | Start | Finish | Predecessors | Total slack | Free slack | Constraint |
| --- | --- | --- | --- | --- | --- | --- | --- | --- | --- | --- |
| 1131 | 3.6 | **Aprendizaje, diálogo de políticas, M@E y Riesgos** |  | 529d | 2016-02-02 | 2018-02-09 |  | 76d |  |  |
| 1132 | 3.6.1 | **Proceso de medición II Operación** |  | 60d | 2017-08-15 | 2017-11-06 |  | 145d |  |  |
| 1133 | 3.6.1.1 | **Inicio encuestas de desempeño de la II Operación** |  | 60d | 2017-08-15 | 2017-11-06 |  | 145d |  |  |
| 1134 | 3.6.1.1.1 | Cartas de autorización para realización de las encuestas a nivel de hogares |  | 60d | 2017-08-15 | 2017-11-06 | 1369FS+400d | 145d |  |  |
| 1135 | 3.6.1.1.2 | Memorando a las unidades de salud informando sobre las encuestas a realizarse | milestone | 60d | 2017-08-15 | 2017-11-06 | 1369FS+400d | 145d |  |  |
| 1136 | 3.6.1.1.3 | Actualización listados de unidades de salud y red de referencia |  | 60d | 2017-08-15 | 2017-11-06 | 1369FS+400d | 145d |  |  |
| 1137 | 3.6.1.1.4 | Actualización de listados sobre los segmentos censales |  | 40d | 2017-08-15 | 2017-10-09 | 1369FS+400d | 165d |  |  |
| 1138 | 3.6.2 | **Diálogo de políticas** |  | 200d | 2017-01-17 | 2017-10-23 |  | 155d |  |  |
| 1139 | 3.6.2.1 | **Decisiones sobre los resultados del piloto de recursos humanos implementado** |  | 60d | 2017-05-09 | 2017-07-31 |  | 215d |  |  |
| 1140 | 3.6.2.1.1 | Reporte sistematizados sobre la estrategia comunitaria y las casas maternas |  | 60d | 2017-05-09 | 2017-07-31 | 326 | 215d |  |  |
| 1141 | 3.6.2.1.2 | Análisis costo beneficio de la introducción de los trabajadores comunitarios y la expansión de las casas maternas |  | 60d | 2017-05-09 | 2017-07-31 | 326 | 215d |  |  |
| 1142 | 3.6.2.2 | **Decisiones sobre intervenciones comunitarias orientadas a reducir la muerte materna** |  | 60d | 2017-01-17 | 2017-04-10 |  | 295d |  |  |
| 1143 | 3.6.2.2.1 | Reporte sistematizados sobre la estrategia comunitaria y las casas maternas |  | 60d | 2017-01-17 | 2017-04-10 | 631 | 295d |  |  |
| 1144 | 3.6.2.2.2 | Análisis costo beneficio de la introducción de los trabajadores comunitarios y la expansión de las casas maternas |  | 60d | 2017-01-17 | 2017-04-10 | 631 | 295d |  |  |
| 1145 | 3.6.2.3 | **Decisiones sobre intervenciones de incentivos a la demanda para aumentar el parto institucional y el control posnatal** |  | 80d | 2017-07-04 | 2017-10-23 |  | 155d |  |  |
| 1146 | 3.6.2.3.1 | Reporte sistematizado sobre intervenciones para incentivar la demanda para aumentar el parto institucional |  | 60d | 2017-07-04 | 2017-09-25 | 538 | 175d |  |  |
| 1147 | 3.6.2.3.2 | Análisis costo beneficio del incentivo a la demanda para incrementar el parto institucional |  | 80d | 2017-07-04 | 2017-10-23 | 538 | 155d |  |  |
| 1148 | 3.6.3 | **Reportes del tablero de control e Hitos de la Operación** |  | 468d | 2016-04-27 | 2018-02-09 |  | 76d |  |  |
| 1149 | 3.6.3.1 | reportes trimestrales de avance de Hitos y tablero de control |  | 10d | 2016-04-27 | 2016-05-10 | 1369FS+60d | 402d | 0d | finish no earlier than 2016-05-10 |
| 1150 | 3.6.3.2 | reportes trimestrales de avance de Hitos y tablero de control |  | 8d | 2016-08-03 | 2016-08-12 | 1149FS+60d | 402d | 0d | start no earlier than 2016-08-01 |
| 1151 | 3.6.3.3 | reportes trimestrales de avance de Hitos y tablero de control |  | 4d | 2016-11-07 | 2016-11-10 | 1150FS+60d | 402d |  | finish no earlier than 2016-11-10 |
| 1152 | 3.6.3.4 | reportes trimestrales de avance de Hitos y tablero de control |  | 11d | 2017-01-27 | 2017-02-10 |  | 336d |  | start no earlier than 2017-01-27 |
| 1153 | 3.6.3.5 | reportes trimestrales de avance de Hitos y tablero de control |  | 8d | 2017-05-01 | 2017-05-10 |  | 177d | 8d | start no earlier than 2017-05-01 |
| 1154 | 3.6.3.6 | reportes trimestrales de avance de Hitos y tablero de control |  | 8d | 2017-08-01 | 2017-08-10 | 1153FS+50d | 169d | 28d | start no earlier than 2017-08-01 |
| 1155 | 3.6.3.7 | reportes trimestrales de avance de Hitos y tablero de control |  | 8d | 2017-11-01 | 2017-11-10 | 1154FS+30d | 141d |  | start no earlier than 2017-11-01 |
| 1156 | 3.6.3.8 | reportes trimestrales de avance de Hitos y tablero de control |  | 9d | 2018-01-30 | 2018-02-09 |  | 76d |  | start no earlier than 2018-01-30 |

| ID | WBS | Task | Duration | Start | Finish | Predecessors | Total slack | Free slack |
| --- | --- | --- | --- | --- | --- | --- | --- | --- |
| 1157 | 3.6.4 | **Gestión de riesgos** | 488d | 2016-02-02 | 2017-12-14 | 1369 | 117d |  |
| 1158 | 3.6.4.1 | **Acciones generales** | 488d | 2016-02-02 | 2017-12-14 |  | 117d |  |
| 1159 | 3.6.4.1.1 | Establecer un diálologo con el secretario de Hacienda y el Secretario de Salud sobre los acuerdos esenciales para el éxito de la II Operación | 20d | 2016-02-02 | 2016-02-29 |  | 585d |  |
| 1160 | 3.6.4.1.2 | Establecer en la Misión de Arranque los mecanismos para el monitoreo del progreso en la interculturalidad y el abasto estratégico de medicamentos vacunas e insumos esenciales | 20d | 2016-02-02 | 2016-02-29 |  | 585d |  |
| 1161 | 3.6.4.1.3 | Realizar las acciones de negociación necesarias entre el ISECH y los otros prestadores de servicios de salud para asegurar un rol proactivo en temas materno infantil estratégicos | 40d | 2016-02-02 | 2016-03-28 |  | 565d |  |
| 1162 | 3.6.4.1.4 | **Establecer una comunicación permanente con el Secretario de Salud y otras autoridades sobre el avance y los desafíos de la Operación** | 428d | 2016-04-26 | 2017-12-14 |  | 117d |  |
| 1163 | 3.6.4.1.4.1 | Visitas trimestrales de presentación de resultados y actualización de acuerdos | 1d | 2016-04-26 | 2016-04-26 | 1369FS+60d | 117d | 0d |
| 1164 | 3.6.4.1.4.2 | Visitas trimestrales de presentación de resultados y actualización de acuerdos | 1d | 2016-07-20 | 2016-07-20 | 1163FS+60d | 117d | 0d |
| 1165 | 3.6.4.1.4.3 | Visitas trimestrales de presentación de resultados y actualización de acuerdos | 1d | 2016-10-13 | 2016-10-13 | 1164FS+60d | 117d | 0d |
| 1166 | 3.6.4.1.4.4 | Visitas trimestrales de presentación de resultados y actualización de acuerdos | 1d | 2017-01-06 | 2017-01-06 | 1165FS+60d | 117d | 0d |
| 1167 | 3.6.4.1.4.5 | Visitas trimestrales de presentación de resultados y actualización de acuerdos | 1d | 2017-04-03 | 2017-04-03 | 1166FS+60d | 117d | 0d |
| 1168 | 3.6.4.1.4.6 | Visitas trimestrales de presentación de resultados y actualización de acuerdos | 1d | 2017-06-27 | 2017-06-27 | 1167FS+60d | 117d | 0d |
| 1169 | 3.6.4.1.4.7 | Visitas trimestrales de presentación de resultados y actualización de acuerdos | 1d | 2017-09-20 | 2017-09-20 | 1168FS+60d | 117d | 0d |
| 1170 | 3.6.4.1.4.8 | Visitas trimestrales de presentación de resultados y actualización de acuerdos | 1d | 2017-12-14 | 2017-12-14 | 1169FS+60d | 117d |  |
| 1171 | 3.6.4.2 | **1. Riesgos relativos a atención y servicios** | 40d | 2016-02-02 | 2016-03-28 |  | 565d |  |
| 1172 | 3.6.4.2.1 | Definir un mecanismo para motorear y garantizar la presencia de especialistas en los CONE BASICO y COMPLETO | 20d | 2016-02-02 | 2016-02-29 | 1369 | 585d |  |
| 1173 | 3.6.4.2.2 | Garantizar con las autoridades del ISECH la designación del personasl requeridos para los comités de aseguramiento de la calidad | 5d | 2016-02-02 | 2016-02-08 |  | 600d |  |
| 1174 | 3.6.4.2.3 | Apoyar a las jurisdicciones y municipios en la preparación y puesta en marcha de planes locales para la implementación de la II Operación. | 40d | 2016-02-02 | 2016-03-28 | 1369 | 565d |  |
| 1175 | 3.6.4.3 | **2. Riesgos relativos a la interculturalidad** | 30d | 2016-02-02 | 2016-03-14 |  | 575d |  |
| 1176 | 3.6.4.3.1 | Integrar la interculturalidad en los modelos de planificación de acciones a nivel comunitario | 20d | 2016-02-02 | 2016-02-29 |  | 585d |  |
| 1177 | 3.6.4.3.2 | Integrar en los TOR's del piloto de RRHH la aspiración de interculturalidad de la Operación | 10d | 2016-02-02 | 2016-02-15 |  | 595d |  |
| 1178 | 3.6.4.3.3 | Armonizar los conceptos de modificación del CV de las parteras con el pensamiento y las acciones del ISECH y de las comunidades vinculadas | 20d | 2016-02-02 | 2016-02-29 | 1369 | 585d |  |
| 1179 | 3.6.4.3.4 | Verificar ques casas maternas incluyen los conceptos de interculturalidad comunmente aceptados en la zona de influencia | 10d | 2016-02-02 | 2016-02-15 |  | 595d |  |
| 1180 | 3.6.4.3.5 | Socializar a nivel municipal el modelo de establecimiento y desarrollo de las casas maternas | 30d | 2016-02-02 | 2016-03-14 |  | 575d |  |

| ID | WBS | Task | Duration | Start | Finish | Predecessors | Total slack | Free slack | Constraint | Cost |
| --- | --- | --- | --- | --- | --- | --- | --- | --- | --- | --- |
| 1181 | 3.6.4.4 | **3. Riesgos relativo al liderazgo** | 20d | 2016-02-02 | 2016-02-29 |  | 585d |  |  |  |
| 1182 | 3.6.4.4.1 | Actualizar y adoptar con el Secretario de Salud la modalidad de monitoreo de la Operación y responsables designados de cada área | 20d | 2016-02-02 | 2016-02-29 | 1369 | 585d |  |  |  |
| 1183 | 3.6.4.4.2 | Obtener acuerdo del Secretario de Salud en ratificación del rol y relevancia de la UCP de cara al inicio de la II Operación | 10d | 2016-02-02 | 2016-02-15 | 1369 | 595d |  |  |  |
| 1184 | 3.6.4.4.3 | Remitir comunicado a las autoridades municipales donde se establecerán las casas maternas sobre la relevancia de los objetivos vinculados con dichas posadas | 10d | 2016-02-02 | 2016-02-15 |  | 595d |  |  |  |
| 1185 | 3.6.4.4.4 | Gestionar ante las autoridades del ISECH la idoneidad técnica del personal de la UCP (sea recontatado o nuevo) | 10d | 2016-02-02 | 2016-02-15 | 1369 | 595d |  |  |  |
| 1186 | 3.6.4.5 | **4. Riesgos relativos a las adquisiciones** | 60d | 2016-02-02 | 2016-04-25 |  | 545d |  |  |  |
| 1187 | 3.6.4.5.1 | Presentación oficial del plan de adquisiciones a la Secretaria de Hacienda | 10d | 2016-02-02 | 2016-02-15 | 1369 | 580d | 0d |  |  |
| 1188 | 3.6.4.5.2 | Establecer un taller de actualización en temas fiduciarios al personal del ISECH y Secretaria de Hacienda | 15d | 2016-02-16 | 2016-03-07 | 1187 | 580d |  |  |  |
| 1189 | 3.6.4.5.3 | Verificar la puesta en ejecución de los acuerdos que le dan existecnia y capacidad operativa la Unidad de Gestión Logística | 30d | 2016-02-02 | 2016-03-14 |  | 575d |  |  |  |
| 1190 | 3.6.4.5.4 | Establecer un mapeo de procesos y responsables de las adquisiciones y verificar su conocimiento por parte del personal vinculado | 60d | 2016-02-02 | 2016-04-25 |  | 545d |  |  |  |
| 1191 | 3.6.4.5.5 | Acordar un mecanismo de ajuste de la planificación que limite a 3 los momentos en los que se hacen cambios al PA | 15d | 2016-02-02 | 2016-02-22 | 1369 | 590d |  |  |  |
| 1192 | 3.6.4.5.6 | Establecer una bases de datos de proveedores, para mantenerlos informados y darle seguimiento a sus gestiones. | 40d | 2016-02-02 | 2016-03-28 |  | 565d |  |  |  |
| 1193 | 3.6.4.6 | **5. Riesgos financieros** | 220d | 2016-02-02 | 2016-12-05 |  | 385d |  |  |  |
| 1194 | 3.6.4.6.1 | Establecer el mapeo de los procesos de acreditación de presupuestos, de elaboración de los expedientes técnicos y de liberación de los recursos | 20d | 2016-02-02 | 2016-02-29 |  | 585d |  |  |  |
| 1195 | 3.6.4.6.2 | Activar un diálogo con las autoridades del ISECH, Secretaría de Hacienda y Seguro Popular para garantizar los recursos de la contra partida para el 2016 | 20d | 2016-02-02 | 2016-02-29 |  | 385d | 0d |  |  |
| 1196 | 3.6.4.6.3 | Activar un diálogo con las autoridades del ISECH, Secretaría de Hacienda y Seguro Popular para garantizar los recursos de la contra partida para el 2017 | 20d | 2016-11-08 | 2016-12-05 | 1195FS+180d | 385d |  |  |  |
| 1197 | 3.6.4.7 | **6. Gestión de oportunidades** | 15d | 2016-02-02 | 2016-02-22 |  | 590d |  |  |  |
| 1198 | 3.6.4.7.1 | Verificar que el plan comunicacional incluye la dimensión innovadora y los resultados de la Iniciativa | 10d | 2016-02-02 | 2016-02-15 | 1369 | 595d |  |  |  |
| 1199 | 3.6.4.7.2 | Someter a la consideración de la UC el aporte de recursos para generar una publicación técnica sobre los resultados en materia de salud materno infantil logrados en la I Operación | 15d | 2016-02-02 | 2016-02-22 | 1369 | 590d |  |  |  |
| 1200 | 4 | **4. UCP, Auditoría y seguimiento** | 606d | 2016-02-01 | 2018-05-28 |  | 0d |  |  | 376,848 |
| 1201 | 4.1 | **Operación de la UCP** | 601d | 2016-02-01 | 2018-05-21 |  | 5d |  |  | 336,848 |
| 1202 | 4.1.1 | **Contratación del personal y recursos operativos** | 520d | 2016-02-01 | 2018-01-26 |  | 86d |  |  | 326,848 |
| 1203 | 4.1.1.1 | **Contratación de personal** | 520d | 2016-02-01 | 2018-01-26 |  | 86d |  |  | 275,448 |
| 1204 | 4.1.1.1.1 | **Honorarios equipo de Coordinación de la Operación** | 520d | 2016-02-01 | 2018-01-26 |  | 86d |  |  | 275,448 |
| 1205 | 4.1.1.1.1.1 | Honorarios equipo de Coordinación de la Operación 1 | 1mo | 2016-02-01 | 2016-02-26 |  | 586d |  | start no earlier than 2016-02-01 | 11,477 |
| 1206 | 4.1.1.1.1.2 | Honorarios equipo de Coordinación de la Operación 2 | 1mo | 2016-03-01 | 2016-03-28 |  | 565d |  | start no earlier than 2016-03-01 | 11,477 |
| 1207 | 4.1.1.1.1.3 | Honorarios equipo de Coordinación de la Operación 3 | 1mo | 2016-04-01 | 2016-04-28 |  | 542d |  | start no earlier than 2016-04-01 | 11,477 |
| 1208 | 4.1.1.1.1.4 | Honorarios equipo de Coordinación de la Operación 4 | 1mo | 2016-05-02 | 2016-05-27 |  | 521d |  | start no earlier than 2016-05-01 | 11,477 |
| 1209 | 4.1.1.1.1.5 | Honorarios equipo de Coordinación de la Operación 5 | 1mo | 2016-06-01 | 2016-06-28 |  | 499d |  | start no earlier than 2016-06-01 | 11,477 |
| 1210 | 4.1.1.1.1.6 | Honorarios equipo de Coordinación de la Operación 6 | 1mo | 2016-07-01 | 2016-07-28 |  | 477d |  | start no earlier than 2016-07-01 | 11,477 |
| 1211 | 4.1.1.1.1.7 | Honorarios equipo de Coordinación de la Operación 7 | 1mo | 2016-08-01 | 2016-08-26 |  | 456d |  | start no earlier than 2016-08-01 | 11,477 |
| 1212 | 4.1.1.1.1.8 | Honorarios equipo de Coordinación de la Operación 8 | 1mo | 2016-09-01 | 2016-09-28 |  | 433d |  | start no earlier than 2016-09-01 | 11,477 |
| 1213 | 4.1.1.1.1.9 | Honorarios equipo de Coordinación de la Operación 9 | 1mo | 2016-10-03 | 2016-10-28 |  | 411d |  | start no earlier than 2016-10-01 | 11,477 |
| 1214 | 4.1.1.1.1.10 | Honorarios equipo de Coordinación de la Operación 10 | 1mo | 2016-11-01 | 2016-11-28 |  | 390d |  | start no earlier than 2016-11-01 | 11,477 |
| 1215 | 4.1.1.1.1.11 | Honorarios equipo de Coordinación de la Operación 11 | 1mo | 2016-12-01 | 2016-12-28 |  | 368d |  | start no earlier than 2016-12-01 | 11,477 |
| 1216 | 4.1.1.1.1.12 | Honorarios equipo de Coordinación de la Operación 12 | 1mo | 2017-01-02 | 2017-01-27 |  | 346d |  | start no earlier than 2017-01-01 | 11,477 |
| 1217 | 4.1.1.1.1.13 | Honorarios equipo de Coordinación de la Operación 13 | 1mo | 2017-02-01 | 2017-02-28 |  | 324d |  | start no earlier than 2017-02-01 | 11,477 |
| 1218 | 4.1.1.1.1.14 | Honorarios equipo de Coordinación de la Operación 14 | 1mo | 2017-03-01 | 2017-03-28 |  | 304d |  | start no earlier than 2017-03-01 | 11,477 |
| 1219 | 4.1.1.1.1.15 | Honorarios equipo de Coordinación de la Operación 15 | 1mo | 2017-04-03 | 2017-04-28 |  | 281d |  | start no earlier than 2017-04-01 | 11,477 |
| 1220 | 4.1.1.1.1.16 | Honorarios equipo de Coordinación de la Operación 16 | 1mo | 2017-05-01 | 2017-05-26 |  | 261d |  | start no earlier than 2017-05-01 | 11,477 |
| 1221 | 4.1.1.1.1.17 | Honorarios equipo de Coordinación de la Operación 17 | 1mo | 2017-06-01 | 2017-06-28 |  | 238d |  | start no earlier than 2017-06-01 | 11,477 |
| 1222 | 4.1.1.1.1.18 | Honorarios equipo de Coordinación de la Operación 18 | 1mo | 2017-07-03 | 2017-07-28 |  | 216d |  | start no earlier than 2017-07-01 | 11,477 |
| 1223 | 4.1.1.1.1.19 | Honorarios equipo de Coordinación de la Operación 19 | 1mo | 2017-08-01 | 2017-08-28 |  | 195d |  | start no earlier than 2017-08-01 | 11,477 |
| 1224 | 4.1.1.1.1.20 | Honorarios equipo de Coordinación de la Operación 20 | 1mo | 2017-09-01 | 2017-09-28 |  | 172d |  | start no earlier than 2017-09-01 | 11,477 |
| 1225 | 4.1.1.1.1.21 | Honorarios equipo de Coordinación de la Operación 21 | 1mo | 2017-10-02 | 2017-10-27 |  | 151d |  | start no earlier than 2017-10-01 | 11,477 |
| 1226 | 4.1.1.1.1.22 | Honorarios equipo de Coordinación de la Operación 22 | 1mo | 2017-11-01 | 2017-11-28 |  | 129d |  | start no earlier than 2017-11-01 | 11,477 |
| 1227 | 4.1.1.1.1.23 | Honorarios equipo de Coordinación de la Operación 23 | 1mo | 2017-12-01 | 2017-12-28 |  | 107d |  | start no earlier than 2017-12-01 | 11,477 |
| 1228 | 4.1.1.1.1.24 | Honorarios equipo de Coordinación de la Operación 24 | 1mo | 2018-01-01 | 2018-01-26 |  | 86d |  | start no earlier than 2018-01-01 | 11,477 |

Notes:
- 1202: Estos procesos se avanzarán en el marco de la I Operación aspirándose a disponer de los mismos al inicio de la II Operación. Pilar Abr22

| ID | WBS | Task | Type | Duration | Start | Finish | Predecessors | Total slack | Free slack | Constraint | Cost |
| --- | --- | --- | --- | --- | --- | --- | --- | --- | --- | --- | --- |
| 1229 | 4.1.1.2 | **Contratación de servicios de telefonía e internet** |  | 500d | 2016-02-02 | 2018-01-01 |  | 105d |  |  | 11,400 |
| 1230 | 4.1.1.2.1 | Servicios de telefonia e internet 2016 |  | 240d | 2016-02-02 | 2017-01-02 | 1369 | 105d | 0d |  | 5,400 |
| 1231 | 4.1.1.2.2 | Servicios de telefonia e internet 2017 |  | 260d | 2017-01-03 | 2018-01-01 | 1230 | 105d |  |  | 6,000 |
| 1232 | 4.1.1.3 | **Alquiler de oficinas** |  | 500d | 2016-02-02 | 2018-01-01 |  | 105d |  |  |  |
| 1233 | 4.1.1.3.1 | Alquiler de oficinas 2016 |  | 240d | 2016-02-02 | 2017-01-02 | 1369 | 105d | 0d |  |  |
| 1234 | 4.1.1.3.2 | Alquiler de oficinas 2017 |  | 260d | 2017-01-03 | 2018-01-01 | 1233 | 105d |  |  |  |
| 1235 | 4.1.1.4 | **Bienes de consumo (papelería y otros)** |  | 500d | 2016-02-02 | 2018-01-01 |  | 105d |  |  | 15,000 |
| 1236 | 4.1.1.4.1 | Bienes de consumo 2016 |  | 240d | 2016-02-02 | 2017-01-02 | 1369 | 105d | 0d |  | 7,000 |
| 1237 | 4.1.1.4.2 | Bienes de consumo 2017 |  | 260d | 2017-01-03 | 2018-01-01 | 1236 | 105d |  |  | 8,000 |
| 1238 | 4.1.1.5 | **Gastos operativos** |  | 500d | 2016-02-02 | 2018-01-01 |  | 105d |  |  | 25,000 |
| 1239 | 4.1.1.5.1 | Gastos operativos 2016 |  | 240d | 2016-02-02 | 2017-01-02 | 1369 | 105d | 0d |  | 12,000 |
| 1240 | 4.1.1.5.2 | Gastos operativos 2017 |  | 260d | 2017-01-03 | 2018-01-01 | 1239 | 105d |  |  | 13,000 |
| 1241 | 4.1.2 | **Coordinación general de la Operación** |  | 528d | 2016-02-02 | 2018-02-08 |  | 77d |  |  |  |
| 1242 | 4.1.2.1 | Socialización y divulgación del convenio de Ejecución de la Operación | milestone | 20d | 2016-02-02 | 2016-02-29 | 1369 | 585d |  |  |  |
| 1243 | 4.1.2.2 | **Acciones de seguimiento y coordinación** |  | 506d | 2016-03-03 | 2018-02-08 |  | 77d |  |  |  |
| 1244 | 4.1.2.2.1 | Acciones de seguimiento y coordinación 1 |  | 22d | 2016-03-03 | 2016-04-01 | 1369FS+22d | 77d | 0d | start no earlier than 2014-10-01 |  |
| 1245 | 4.1.2.2.2 | Acciones de seguimiento y coordinación 2 |  | 22d | 2016-04-04 | 2016-05-03 | 1244 | 77d | 0d | start no earlier than 2014-11-01 |  |
| 1246 | 4.1.2.2.3 | Acciones de seguimiento y coordinación 3 |  | 22d | 2016-05-04 | 2016-06-02 | 1245 | 77d | 0d | start no earlier than 2014-12-01 |  |
| 1247 | 4.1.2.2.4 | Acciones de seguimiento y coordinación 4 |  | 22d | 2016-06-03 | 2016-07-04 | 1246 | 77d | 0d | start no earlier than 2015-01-01 |  |
| 1248 | 4.1.2.2.5 | Acciones de seguimiento y coordinación 5 |  | 22d | 2016-07-05 | 2016-08-03 | 1247 | 77d | 0d | start no earlier than 2015-02-01 |  |
| 1249 | 4.1.2.2.6 | Acciones de seguimiento y coordinación 6 |  | 22d | 2016-08-04 | 2016-09-02 | 1248 | 77d | 0d | start no earlier than 2015-03-01 |  |
| 1250 | 4.1.2.2.7 | Acciones de seguimiento y coordinación 7 |  | 22d | 2016-09-05 | 2016-10-04 | 1249 | 77d | 0d | start no earlier than 2015-04-01 |  |
| 1251 | 4.1.2.2.8 | Acciones de seguimiento y coordinación 8 |  | 22d | 2016-10-05 | 2016-11-03 | 1250 | 77d | 0d | start no earlier than 2015-05-01 |  |
| 1252 | 4.1.2.2.9 | Acciones de seguimiento y coordinación 9 |  | 22d | 2016-11-04 | 2016-12-05 | 1251 | 77d | 0d | start no earlier than 2015-06-01 |  |
| 1253 | 4.1.2.2.10 | Acciones de seguimiento y coordinación 10 |  | 22d | 2016-12-06 | 2017-01-04 | 1252 | 77d | 0d | start no earlier than 2015-07-01 |  |
| 1254 | 4.1.2.2.11 | Acciones de seguimiento y coordinación 11 |  | 22d | 2017-01-05 | 2017-02-03 | 1253 | 77d | 0d | start no earlier than 2015-08-01 |  |
| 1255 | 4.1.2.2.12 | Acciones de seguimiento y coordinación 12 |  | 22d | 2017-02-06 | 2017-03-07 | 1254 | 77d | 0d | start no earlier than 2015-09-01 |  |
| 1256 | 4.1.2.2.13 | Acciones de seguimiento y coordinación 13 |  | 22d | 2017-03-08 | 2017-04-06 | 1255 | 77d | 0d | start no earlier than 2015-10-01 |  |
| 1257 | 4.1.2.2.14 | Acciones de seguimiento y coordinación 14 |  | 22d | 2017-04-07 | 2017-05-08 | 1256 | 77d | 0d | start no earlier than 2015-11-01 |  |
| 1258 | 4.1.2.2.15 | Acciones de seguimiento y coordinación 15 |  | 22d | 2017-05-09 | 2017-06-07 | 1257 | 77d | 0d | start no earlier than 2015-12-01 |  |
| 1259 | 4.1.2.2.16 | Acciones de seguimiento y coordinación 16 |  | 22d | 2017-06-08 | 2017-07-07 | 1258 | 77d | 0d | start no earlier than 2016-01-01 |  |
| 1260 | 4.1.2.2.17 | Acciones de seguimiento y coordinación 17 |  | 22d | 2017-07-10 | 2017-08-08 | 1259 | 77d | 0d | start no earlier than 2016-02-01 |  |
| 1261 | 4.1.2.2.18 | Acciones de seguimiento y coordinación 18 |  | 22d | 2017-08-09 | 2017-09-07 | 1260 | 77d | 0d | start no earlier than 2016-03-01 |  |
| 1262 | 4.1.2.2.19 | Acciones de seguimiento y coordinación 19 |  | 22d | 2017-09-08 | 2017-10-09 | 1261 | 77d | 0d |  |  |
| 1263 | 4.1.2.2.20 | Acciones de seguimiento y coordinación 20 |  | 22d | 2017-10-10 | 2017-11-08 | 1262 | 77d | 0d |  |  |
| 1264 | 4.1.2.2.21 | Acciones de seguimiento y coordinación 21 |  | 22d | 2017-11-09 | 2017-12-08 | 1263 | 77d | 0d |  |  |
| 1265 | 4.1.2.2.22 | Acciones de seguimiento y coordinación 22 |  | 22d | 2017-12-11 | 2018-01-09 | 1264 | 77d | 0d |  |  |
| 1266 | 4.1.2.2.23 | Acciones de seguimiento y coordinación 23 |  | 22d | 2018-01-10 | 2018-02-08 | 1265 | 77d |  |  |  |

| ID | WBS | Task | Type | Duration | Start | Finish | Predecessors | Total slack | Free slack | Constraint |
| --- | --- | --- | --- | --- | --- | --- | --- | --- | --- | --- |
| 1267 | 4.1.2.3 | **Acompanamiento a misiones trimestrales de supervisión** |  | 440d | 2016-02-02 | 2017-10-09 |  | 165d |  |  |
| 1268 | 4.1.2.3.1 | Misión de arranque la II Operación |  | 10d | 2016-02-02 | 2016-02-15 | 1369 | 595d |  |  |
| 1269 | 4.1.2.3.2 | Misiones trimestrales |  | 10d | 2016-04-26 | 2016-05-09 | 1369FS+60d | 165d | 0d |  |
| 1270 | 4.1.2.3.3 | Misiones trimestrales |  | 10d | 2016-08-02 | 2016-08-15 | 1269FS+60d | 165d | 0d |  |
| 1271 | 4.1.2.3.4 | Misiones trimestrales |  | 10d | 2016-11-08 | 2016-11-21 | 1270FS+60d | 165d | 0d |  |
| 1272 | 4.1.2.3.5 | Misiones trimestrales |  | 10d | 2017-02-14 | 2017-02-27 | 1271FS+60d | 165d | 0d |  |
| 1273 | 4.1.2.3.6 | Misiones trimestrales |  | 10d | 2017-05-23 | 2017-06-05 | 1272FS+60d | 165d | 0d |  |
| 1274 | 4.1.2.3.7 | Misiones trimestrales |  | 10d | 2017-07-18 | 2017-07-31 | 1273FS+30d | 165d | 0d |  |
| 1275 | 4.1.2.3.8 | Misiones trimestrales |  | 10d | 2017-09-26 | 2017-10-09 | 1274FS+40d | 165d |  |  |
| 1276 | 4.1.3 | **Gestión de los procesos de planificación y monitoreo** |  | 528d | 2016-02-02 | 2018-02-08 |  | 77d |  |  |
| 1277 | 4.1.3.1 | **Apoyo a la implementación a nivel de jurisdicciones** |  | 445d | 2016-02-02 | 2017-10-16 |  | 160d |  |  |
| 1278 | 4.1.3.1.1 | Socialización del PEP de las jurisdicciones |  | 20d | 2016-02-02 | 2016-02-29 | 1369 | 585d |  |  |
| 1279 | 4.1.3.1.2 | Monitoreo trimestral del PEP de las jurisdicciones |  | 5d | 2016-04-26 | 2016-05-02 | 1369FS+60d | 160d | 0d |  |
| 1280 | 4.1.3.1.3 | Monitoreo trimestral del PEP de las jurisdicciones |  | 5d | 2016-07-26 | 2016-08-01 | 1279FS+60d | 160d | 0d |  |
| 1281 | 4.1.3.1.4 | Monitoreo trimestral del PEP de las jurisdicciones |  | 5d | 2016-10-25 | 2016-10-31 | 1280FS+60d | 160d | 0d |  |
| 1282 | 4.1.3.1.5 | Monitoreo trimestral del PEP de las jurisdicciones |  | 5d | 2017-01-24 | 2017-01-30 | 1281FS+60d | 160d | 0d |  |
| 1283 | 4.1.3.1.6 | Monitoreo trimestral del PEP de las jurisdicciones |  | 5d | 2017-04-25 | 2017-05-01 | 1282FS+60d | 160d | 0d |  |
| 1284 | 4.1.3.1.7 | Monitoreo trimestral del PEP de las jurisdicciones |  | 5d | 2017-07-25 | 2017-07-31 | 1283FS+60d | 160d | 0d |  |
| 1285 | 4.1.3.1.8 | Monitoreo trimestral del PEP de las jurisdicciones |  | 5d | 2017-10-10 | 2017-10-16 | 1284FS+50d | 160d |  |  |
| 1286 | 4.1.3.2 | **Informes mensuales de ejecución** |  | 508d | 2016-03-01 | 2018-02-08 |  | 77d |  |  |
| 1287 | 4.1.3.2.1 | Informes mensuales de ejecución 1 |  | 2d | 2016-03-01 | 2016-03-02 | 1369FS+20d | 77d | 0d | start no earlier than 2014-10-01 |
| 1288 | 4.1.3.2.2 | Informes mensuales de ejecución 2 |  | 2d | 2016-03-31 | 2016-04-01 | 1287FS+20d | 77d | 0d | start no earlier than 2014-11-01 |
| 1289 | 4.1.3.2.3 | Informes mensuales de ejecución 3 |  | 2d | 2016-05-02 | 2016-05-03 | 1288FS+20d | 77d | 0d | start no earlier than 2014-12-01 |
| 1290 | 4.1.3.2.4 | Informes mensuales de ejecución 4 |  | 2d | 2016-06-01 | 2016-06-02 | 1289FS+20d | 77d | 0d | start no earlier than 2015-01-01 |
| 1291 | 4.1.3.2.5 | Informes mensuales de ejecución 5 |  | 2d | 2016-07-01 | 2016-07-04 | 1290FS+20d | 77d | 0d | start no earlier than 2015-02-01 |
| 1292 | 4.1.3.2.6 | Informes mensuales de ejecución 6 |  | 2d | 2016-08-02 | 2016-08-03 | 1291FS+20d | 77d | 0d | start no earlier than 2015-03-01 |
| 1293 | 4.1.3.2.7 | Informes mensuales de ejecución 7 |  | 2d | 2016-09-01 | 2016-09-02 | 1292FS+20d | 77d | 0d | start no earlier than 2015-04-01 |
| 1294 | 4.1.3.2.8 | Informes mensuales de ejecución 8 |  | 2d | 2016-10-03 | 2016-10-04 | 1293FS+20d | 77d | 0d | start no earlier than 2015-05-01 |
| 1295 | 4.1.3.2.9 | Informes mensuales de ejecución 9 |  | 2d | 2016-11-02 | 2016-11-03 | 1294FS+20d | 77d | 0d | start no earlier than 2015-06-01 |
| 1296 | 4.1.3.2.10 | Informes mensuales de ejecución 10 |  | 2d | 2016-12-02 | 2016-12-05 | 1295FS+20d | 77d | 0d | start no earlier than 2015-07-01 |
| 1297 | 4.1.3.2.11 | Informes mensuales de ejecución 11 |  | 2d | 2017-01-03 | 2017-01-04 | 1296FS+20d | 77d | 0d | start no earlier than 2015-08-01 |
| 1298 | 4.1.3.2.12 | Informes mensuales de ejecución 12 |  | 2d | 2017-02-02 | 2017-02-03 | 1297FS+20d | 77d | 0d | start no earlier than 2015-09-01 |
| 1299 | 4.1.3.2.13 | Informes mensuales de ejecución 13 |  | 2d | 2017-03-06 | 2017-03-07 | 1298FS+20d | 77d | 0d | start no earlier than 2015-10-01 |
| 1300 | 4.1.3.2.14 | Informes mensuales de ejecución 14 |  | 2d | 2017-04-05 | 2017-04-06 | 1299FS+20d | 77d | 0d | start no earlier than 2015-11-01 |
| 1301 | 4.1.3.2.15 | Informes mensuales de ejecución 15 |  | 2d | 2017-05-05 | 2017-05-08 | 1300FS+20d | 77d | 0d | start no earlier than 2015-12-01 |
| 1302 | 4.1.3.2.16 | Informes mensuales de ejecución 16 |  | 2d | 2017-06-06 | 2017-06-07 | 1301FS+20d | 77d | 0d | start no earlier than 2016-01-01 |
| 1303 | 4.1.3.2.17 | Informes mensuales de ejecución 17 |  | 2d | 2017-07-06 | 2017-07-07 | 1302FS+20d | 77d | 0d | start no earlier than 2016-02-01 |
| 1304 | 4.1.3.2.18 | Informes mensuales de ejecución 18 |  | 2d | 2017-08-07 | 2017-08-08 | 1303FS+20d | 77d | 0d | start no earlier than 2016-03-01 |
| 1305 | 4.1.3.2.19 | Informes mensuales de ejecución 19 |  | 2d | 2017-09-06 | 2017-09-07 | 1304FS+20d | 77d | 0d |  |
| 1306 | 4.1.3.2.20 | Informes mensuales de ejecución 20 |  | 2d | 2017-10-06 | 2017-10-09 | 1305FS+20d | 77d | 0d |  |
| 1307 | 4.1.3.2.21 | Informes mensuales de ejecución 21 |  | 2d | 2017-11-07 | 2017-11-08 | 1306FS+20d | 77d | 0d |  |
| 1308 | 4.1.3.2.22 | Informes mensuales de ejecución 22 |  | 2d | 2017-12-07 | 2017-12-08 | 1307FS+20d | 77d | 0d |  |
| 1309 | 4.1.3.2.23 | Informes mensuales de ejecución 23 |  | 2d | 2018-01-08 | 2018-01-09 | 1308FS+20d | 77d | 0d |  |
| 1310 | 4.1.3.2.24 | Informes mensuales de ejecución 24 |  | 2d | 2018-02-07 | 2018-02-08 | 1309FS+20d | 77d |  |  |
| 1311 | 4.1.3.2.25 | Informes semestrales de ejecución | milestone | 5d | 2016-07-19 | 2016-07-25 | 1369FS+120d | 125d | 0d |  |
| 1312 | 4.1.3.2.26 | Informes semestrales de ejecución | milestone | 5d | 2017-05-02 | 2017-05-08 | 1311FS+200d | 125d | 0d |  |
| 1313 | 4.1.3.2.27 | Informes semestrales de ejecución |  | 5d | 2017-08-01 | 2017-08-07 | 1312FS+60d | 125d | 0d |  |
| 1314 | 4.1.3.2.28 | Informe final de ejecución | milestone | 5d | 2017-11-28 | 2017-12-04 | 1313FS+80d | 125d |  |  |

| ID | WBS | Task | Type | Duration | Start | Finish | Predecessors | Total slack | Free slack | Constraint |
| --- | --- | --- | --- | --- | --- | --- | --- | --- | --- | --- |
| 1315 | 4.1.4 | **Gestión del proceso de adquisiciones** |  | 390d | 2016-02-02 | 2017-07-31 |  | 215d |  |  |
| 1316 | 4.1.4.1 | Socialización del plan de adquisiciones a nivel de los involucrados |  | 20d | 2016-02-02 | 2016-02-29 | 1369 | 525d | 0d |  |
| 1317 | 4.1.4.2 | Capacitación en procesos BID a nivel de personal vinculado |  | 60d | 2016-03-01 | 2016-05-23 | 1316 | 525d |  |  |
| 1318 | 4.1.4.3 | Reporte trimestral y semestral de adquisiciones |  | 10d | 2016-04-26 | 2016-05-09 | 1369FS+60d | 215d | 0d |  |
| 1319 | 4.1.4.4 | Reporte trimestral y semestral de adquisiciones |  | 10d | 2016-08-02 | 2016-08-15 | 1318FS+60d | 215d | 0d |  |
| 1320 | 4.1.4.5 | Reporte trimestral y semestral de adquisiciones |  | 10d | 2016-11-08 | 2016-11-21 | 1319FS+60d | 215d | 0d |  |
| 1321 | 4.1.4.6 | Reporte trimestral y semestral de adquisiciones |  | 10d | 2017-02-14 | 2017-02-27 | 1320FS+60d | 215d | 0d |  |
| 1322 | 4.1.4.7 | Reporte trimestral y semestral de adquisiciones |  | 10d | 2017-05-09 | 2017-05-22 | 1321FS+50d | 215d | 0d |  |
| 1323 | 4.1.4.8 | Reporte trimestral y semestral de adquisiciones |  | 10d | 2017-07-18 | 2017-07-31 | 1322FS+40d | 215d |  |  |
| 1324 | 4.1.5 | **Gestión financiero contable** |  | 600d | 2016-02-02 | 2018-05-21 |  | 5d |  |  |
| 1325 | 4.1.5.1 | Elaboración de los expedientes técnicos | milestone | 30d | 2016-08-02 | 2016-09-12 | 1369FS+130d | 175d | 0d |  |
| 1326 | 4.1.5.2 | Activación de los mecanismos de gestión de recursos | milestone | 30d | 2016-02-02 | 2016-03-14 | 1369 | 575d |  |  |
| 1327 | 4.1.5.3 | **Solicitud y liquidación de fondos ante el Banco** |  | 340d | 2016-02-02 | 2017-05-22 |  | 265d |  |  |
| 1328 | 4.1.5.3.1 | Solicitud Inicial | milestone | 20d | 2016-02-02 | 2016-02-29 | 1369 | 265d | 0d |  |
| 1329 | 4.1.5.3.2 | Justiticación y solicitud de fondos |  | 5d | 2016-08-16 | 2016-08-22 | 1328FS+120d | 265d | 0d |  |
| 1330 | 4.1.5.3.3 | Justiticación y solicitud de fondos |  | 5d | 2016-11-15 | 2016-11-21 | 1329FS+60d | 265d | 0d |  |
| 1331 | 4.1.5.3.4 | Justiticación y solicitud de fondos |  | 5d | 2017-02-14 | 2017-02-20 | 1330FS+60d | 265d | 0d |  |
| 1332 | 4.1.5.3.5 | Justiticación y solicitud de fondos |  | 5d | 2017-05-16 | 2017-05-22 | 1331FS+60d | 265d |  |  |
| 1333 | 4.1.5.4 | **Apoyo al proceso de auditoría externa** |  | 400d | 2016-11-08 | 2018-05-21 |  | 5d |  |  |
| 1334 | 4.1.5.4.1 | Proceso de auditoría 2016 |  | 80d | 2016-11-08 | 2017-02-27 | 1369FS+200d | 325d |  |  |
| 1335 | 4.1.5.4.2 | Proceso de auditoría de cierre |  | 120d | 2017-12-05 | 2018-05-21 | 1369FS+480d | 5d |  |  |
| 1336 | 4.1.5.5 | Procedimiento de autorización de recursos para 2016 |  | 30d | 2017-08-15 | 2017-09-25 | 1325FS+240d | 175d |  |  |
| 1337 | 4.1.5.6 | **Ejecución de recursos financieros** |  | 528d | 2016-02-02 | 2018-02-08 |  | 77d |  |  |
| 1338 | 4.1.5.6.1 | Pago de gastos y servicios 1 |  | 22d | 2016-02-02 | 2016-03-02 | 1369 | 77d | 0d | start no earlier than 2014-10-01 |
| 1339 | 4.1.5.6.2 | Pago de gastos y servicios 2 |  | 22d | 2016-03-03 | 2016-04-01 | 1338 | 77d | 0d | start no earlier than 2014-11-01 |
| 1340 | 4.1.5.6.3 | Pago de gastos y servicios 3 |  | 22d | 2016-04-04 | 2016-05-03 | 1339 | 77d | 0d | start no earlier than 2014-12-01 |
| 1341 | 4.1.5.6.4 | Pago de gastos y servicios 4 |  | 22d | 2016-05-04 | 2016-06-02 | 1340 | 77d | 0d | start no earlier than 2015-01-01 |
| 1342 | 4.1.5.6.5 | Pago de gastos y servicios 5 |  | 22d | 2016-06-03 | 2016-07-04 | 1341 | 77d | 0d | start no earlier than 2015-02-01 |
| 1343 | 4.1.5.6.6 | Pago de gastos y servicios 6 |  | 22d | 2016-07-05 | 2016-08-03 | 1342 | 77d | 0d | start no earlier than 2015-03-01 |
| 1344 | 4.1.5.6.7 | Pago de gastos y servicios 7 |  | 22d | 2016-08-04 | 2016-09-02 | 1343 | 77d | 0d | start no earlier than 2015-04-01 |
| 1345 | 4.1.5.6.8 | Pago de gastos y servicios 8 |  | 22d | 2016-09-05 | 2016-10-04 | 1344 | 77d | 0d | start no earlier than 2015-05-01 |
| 1346 | 4.1.5.6.9 | Pago de gastos y servicios 9 |  | 22d | 2016-10-05 | 2016-11-03 | 1345 | 77d | 0d | start no earlier than 2015-06-01 |
| 1347 | 4.1.5.6.10 | Pago de gastos y servicios 10 |  | 22d | 2016-11-04 | 2016-12-05 | 1346 | 77d | 0d | start no earlier than 2015-07-01 |
| 1348 | 4.1.5.6.11 | Pago de gastos y servicios 11 |  | 22d | 2016-12-06 | 2017-01-04 | 1347 | 77d | 0d | start no earlier than 2015-08-01 |
| 1349 | 4.1.5.6.12 | Pago de gastos y servicios 12 |  | 22d | 2017-01-05 | 2017-02-03 | 1348 | 77d | 0d | start no earlier than 2015-09-01 |
| 1350 | 4.1.5.6.13 | Pago de gastos y servicios 13 |  | 22d | 2017-02-06 | 2017-03-07 | 1349 | 77d | 0d | start no earlier than 2015-10-01 |
| 1351 | 4.1.5.6.14 | Pago de gastos y servicios 14 |  | 22d | 2017-03-08 | 2017-04-06 | 1350 | 77d | 0d | start no earlier than 2015-11-01 |
| 1352 | 4.1.5.6.15 | Pago de gastos y servicios 15 |  | 22d | 2017-04-07 | 2017-05-08 | 1351 | 77d | 0d | start no earlier than 2015-12-01 |
| 1353 | 4.1.5.6.16 | Pago de gastos y servicios 16 |  | 22d | 2017-05-09 | 2017-06-07 | 1352 | 77d | 0d | start no earlier than 2016-01-01 |
| 1354 | 4.1.5.6.17 | Pago de gastos y servicios 17 |  | 22d | 2017-06-08 | 2017-07-07 | 1353 | 77d | 0d | start no earlier than 2016-02-01 |
| 1355 | 4.1.5.6.18 | Pago de gastos y servicios 18 |  | 22d | 2017-07-10 | 2017-08-08 | 1354 | 77d | 0d | start no earlier than 2016-03-01 |
| 1356 | 4.1.5.6.19 | Pago de gastos y servicios 19 |  | 22d | 2017-08-09 | 2017-09-07 | 1355 | 77d | 0d |  |
| 1357 | 4.1.5.6.20 | Pago de gastos y servicios 20 |  | 22d | 2017-09-08 | 2017-10-09 | 1356 | 77d | 0d |  |
| 1358 | 4.1.5.6.21 | Pago de gastos y servicios 21 |  | 22d | 2017-10-10 | 2017-11-08 | 1357 | 77d | 0d |  |
| 1359 | 4.1.5.6.22 | Pago de gastos y servicios 22 |  | 22d | 2017-11-09 | 2017-12-08 | 1358 | 77d | 0d |  |
| 1360 | 4.1.5.6.23 | Pago de gastos y servicios 23 |  | 22d | 2017-12-11 | 2018-01-09 | 1359 | 77d | 0d |  |
| 1361 | 4.1.5.6.24 | Pago de gastos y servicios 24 |  | 22d | 2018-01-10 | 2018-02-08 | 1360 | 77d |  |  |

| ID | WBS | Task | Duration | Start | Finish | Predecessors | Total slack | Free slack | Constraint | Cost |
| --- | --- | --- | --- | --- | --- | --- | --- | --- | --- | --- |
| 1362 | 4.1.6 | **Desarrollo de capacidades a nivel de la UCP** | 300d | 2016-02-02 | 2017-03-27 |  | 305d |  |  | 10,000 |
| 1363 | 4.1.6.1 | Elaboración de un plan de formación | 60d | 2016-02-02 | 2016-04-25 | 1369 | 305d | 0d |  |  |
| 1364 | 4.1.6.2 | Ejecución de la capacitación y formación | 240d | 2016-04-26 | 2017-03-27 | 1363 | 305d |  |  | 10,000 |
| 1365 | 4.2 | **Auditoría externa** | 455d | 2016-08-30 | 2018-05-28 |  | 0d |  |  | 40,000 |
| 1366 | 4.2.1 | Selección de la firma de Auditoría | 40d | 2016-08-30 | 2016-10-24 | 1369FS+150d | 0d |  |  |  |
| 1367 | 4.2.2 | Auditoría del periodo 2016 | 120d | 2016-10-25 | 2017-04-10 | 1366 | 0d |  |  | 15,000 |
| 1368 | 4.2.3 | Auditoría de fin de la II Operación | 120d | 2017-12-12 | 2018-05-28 | 1367FS+175d | 0d |  |  | 25,000 |
| 1369 | 5 | Elegibilidad de la operación | 1d | 2016-02-01 | 2016-02-01 |  | 0d |  | start no earlier than 2016-02-01 |  |
